# Cronograma

Schedule from MS Project, 2018-07-01 to 2019-06-27, costs in S.

## Calendars

- Estándar: Mon-Fri 07:00-13:00, 14:00-17:00; Sat 07:00-13:00; Sun 07:00-12:00.

## Resources

| Resource | Group | Rate | Cost per use |
| --- | --- | --- | --- |
| OPERARIO | Mano de Obra | 21.02 |  |
| OFICIAL | Mano de Obra | 17.04 |  |
| PEON | Mano de Obra | 15.34 |  |
| ARQUEOLOGO | Mano de Obra | 4237.29 |  |
| FLETE | Material | 770.25 |  |
| FLETE TERRESTRE RURAL | Material | 533.76 |  |
| MOVILIZACION Y DESMOVILIZACION | Material | 544.07 |  |
| TRASLADO DE EQUIPO DE PERFORACION | Material |  | 145.2 |
| ALAMBRE NEGRO N° 16 | Material |  | 3.81 |
| ALAMBRE NEGRO N° 8 | Material |  | 3.81 |
| ACERO CORRUGADO fy = 4200 kg/cm2 GRADO 60 | Material |  | 3.81 |
| CLAVOS PARA MADERA CON CABEZA DE 3" | Material |  | 3.81 |
| CLAVOS 2" - 4" | Material |  | 3.81 |
| BLINDAJE METALICO CON PLANCHA DE ACERO 4.16 x 2.86m e=1/4" | Material |  | 12.39 |
| PANTALLA DE ACERO E=1/4" | Material |  | 17.5 |
| GAVION TIPO CAJA DE 5.0 x 1 x 1 m (2.7 mm) | Material |  | 230.45 |
| GAVION TIPO COLCHON 5x2x0.30 (2.7 mm) | Material |  | 248.58 |
| ACERO 5/8" | Material |  | 5.31 |
| TUBERIA PVC C-10 200 mm | Material |  | 25.63 |
| TUBERIA PVC C-10 110 mm | Material |  | 12.71 |
| CODO PVC 2" | Material |  | 4.24 |
| CODO PVC DE 6" | Material |  | 6.78 |
| CODO PVC DE 350 mm | Material |  | 38.14 |
| CODO PVC DE 110 mm | Material |  | 19.49 |
| TEE PVC DE 6" | Material |  | 4.24 |
| TUBERIA PVC D=2" | Material |  | 0.63 |
| TUBERIA PVC D=1/2" | Material |  | 0.53 |
| TUBERIA PVC D=6" | Material |  | 6.73 |
| TAPA MANHOLE D=0.40 M | Material |  | 17.16 |
| JUNTA BRIDADA DE DESMONTE ø=0 60 M | Material |  | 17542.4 |
| GEOMALLA TRIAXIAL 160 | Material |  | 15 |
| GEOTEXTIL TEJIDO 200 GR/M2 | Material |  | 5.6 |
| GEOMEMBRANA HDPE e=1.0 mm | Material |  | 7.72 |
| GEOTEXTIL NO TEJIDO 200 GR/M2 | Material |  | 3.6 |
| WATER STOP 4" | Material |  | 12.72 |
| WATER STOP 6" | Material |  | 15 |
| CEMENTO PORTLAND TIPO IP (42.5 kg) | Material |  | 21.19 |
| YESO BOLSA 28 kg | Material |  | 8.47 |
| ADITIVO IMPERMEABILIZANTE | Material |  | 9.8 |
| ADITIVO FLUIDIFICANTE | Material |  | 15.6 |
| MADERA TORNILLO | Material |  | 4.24 |
| TRIPLAY DE 1.20X2.40 m X 18 mm | Material |  | 101.69 |
| TRIPLAY DE 1.20X2.40 m X 9 mm | Material |  | 83.05 |
| MADERA NACIONAL P/ENCOFRADO-CARP | Material |  | 4.24 |
| CALAMINA | Material |  | 15.25 |
| PINTURA ESMALTE SINTETICO | Material |  | 32.2 |
| PINTURA ANTICORROSIVA | Material |  | 140.68 |
| BARRENO INTEGRAL 5" X 39mm | Material |  | 341.66 |
| TUBERIA DE FIERRO GALVANIZADO DE 3/4" | Material |  | 8.65 |
| TUBERIA DE FIERRO GALVANIZADO DE 2" | Material |  | 14.88 |
| TUBERIA DE FIERRO GALVANIZADO DE 1½" | Material |  | 11.34 |
| TUBERIA DE FIERRO GALVANIZADO DE 1/2" | Material |  | 7.63 |
| VALVULA MARIPOSA DE 0.60 m DE DIAMETRO | Material |  | 31182.3 |
| VALVULA ESFERICA DE 4" | Material |  | 344.7 |
| VALVULA COMPUERTA DN 110 mm | Material |  | 381.36 |
| SOLDADURA | Material |  | 10.17 |
| DINAMITA AL 65% | Material |  | 12.45 |
| MECHA | Material |  | 0.69 |
| FULMINANTE | Material |  | 0.78 |
| CASCOS | Material | 2.12 |  |
| LENTES DE SEGURIDAD | Material | 2.75 |  |
| TAPON PARA OIDOS | Material | 0.18 |  |
| MASCARILLA PARA POLVO | Material | 1.06 |  |
| GUANTES DE CUERO | Material | 1.14 |  |
| GUANTES DE JEBE | Material | 1.15 |  |
| CHALECO DE SEGURIDAD | Material | 3.85 |  |
| ZAPATOS DE SEGURIDAD | Material | 6.88 |  |
| BOTAS DE JEBE | Material | 6.88 |  |
| OVEROL | Material | 18.54 |  |
| BOTIQUIN PARA LA OBRA | Material | 7.42 |  |
| CONOS REFLECTANTES | Material | 2.86 |  |
| CINTA DE SEGURIDAD | Material | 2.97 |  |
| MALLA DE SEGURIDAD | Material | 4.24 |  |
| SEÑALIZACION INFORMATIVA 1.00 X 2.20 m | Material | 0.53 |  |
| CAPACITACION EN SEGURIDAD Y SALUD | Material | 52.97 |  |
| PROGRAMA DE PREVENCION CONTROL Y MITIGACIONAMBIENTAL | Material | 2277.54 |  |
| PROGRAMA DE MANEJO DE RESIDUOS SOLIDOS Y EFLUENTES | Material | 1536.02 |  |
| PROGRAMA DE MEDIDA DE CONTINGENCIAS | Material | 847.46 |  |
| PLAN DE CIERRE | Material | 1059.32 |  |
| CALIDAD DEL AGUA SUPERFICIAL | Material | 190.68 |  |
| CALIDAD DE AGUA | Material | 148.31 |  |
| MONITOREO DE RUIDOS | Material | 84.75 |  |
| REACONDICIONAMIENTO DE CANTERAS BOTADERO Y CAMPAMENTO | Material | 1483.05 |  |
| REVEGETACIÓN DE ÁREA UTILIZADA COMO BOTADERO | Material | 1271.19 |  |
| PLAN DE MONITOREO ARQUEOLOGICO | Material | 529.66 |  |
| PARARRAYOS | Material | 370.77 |  |
| PERFORACION ROTOPERCUSIVA Ø 2-1/2"(PARA IMPERMEABILIZACION Y CONSOLIDACION) | Material |  | 120 |
| ENSAYO DE PERMEABILIDAD TIPO LUGEON | Material |  | 270 |
| TUBERIA HDPE CORUGADA 600 mm | Material |  | 567 |
| TUBERIA HDPE 300 mm PN 8 | Material |  | 188.66 |
| TUBERIA HDPE 110 mm PE 100 | Material |  | 60.73 |
| TUBERIA HDPE 600 mm | Material |  | 595.17 |
| CODO HDPE 110 mm PE 100 | Material |  | 42.37 |
| COMPUERTA METALICA 0.26x0.30 h=1.90 M C/VOLANTE YMARCO | Material |  | 2542.73 |
| COMPUERTA METALICA DE 0.40 x 0.35 h= 1.90 M C/VOLANTE | Material |  | 2542.73 |
| COMPUERTA METALICA DE 0.50x0.40 h=1.30M C/VOLANTE YMARCO | Material |  | 2542.37 |
| COMPUERTA METALICA DE 0.50 x 0.46 h=2.30 M C/VOLANTE | Material |  | 2542.37 |
| TARJETA METALICA 1.50 x 0.40 M e=1/4" | Material |  | 211.86 |
| TARJETA METALICA 0.80 X 0.50 M e=1/4" | Material |  | 423.73 |
| REJILLA METALICA 0.80 x 0.80m | Material |  | 296.61 |
| REJILLA METALICA 1.20m X 1.20m e=1.5 cm | Material |  | 211.86 |
| REJILLA METALICA 1.00 x 0.85 M | Material |  | 381.36 |
| TAPA METALICA 1.00 X 1.00 m e=3/8" | Material |  | 254.24 |
| TAPA METALICA 0.80 X 0.80 m e= 1/ 4" | Material |  | 251.1 |
| TAPA METALICA 1.05 X 0.60 m e= 1/ 4" | Material |  | 251.1 |
| TAPA METALICA 0.65 X 0.65 m e= 1/ 4" | Material |  | 202.2 |
| TAPA METALICA 0.60 X 0.60 m e= 1/4" | Material |  | 211.86 |
| TECKNOPORT e=1" | Material |  | 5.56 |
| TUBERIA PERFILADA PVC D=250 mm | Material |  | 32.33 |
| TUBERIA PERFILADA PVC D=350 mm | Material |  | 93.6 |
| TUBERIA PERFILADA PVC D=315 mm | Material |  | 51.88 |
| TUBERIA Ø 200MM PVC-U NTP ISO 1452 UF PN-5 INC. ANILLO | Material |  | 25.43 |
| TUBERIA Ø 250MM PVC-U NTP ISO 1452 UF PN-5 INC. ANILLO | Material |  | 40.27 |
| TUBERIA Ø 250MM PVC-U NTP ISO 1452 UF PN-7.5 INC. ANILLO | Material |  | 56.82 |
| TUBERIA Ø 315MM PVC-U NTP ISO 1452 UF PN-10 INC. ANILLO | Material |  | 117.63 |
| TUBERIA Ø 200MM PVC-U NTP ISO 1452 UF PN-10 INC. ANILLO | Material |  | 47.34 |
| TUBERIA Ø 315MM PVC-U NTP ISO 1452 UF PN-5 INC. ANILLO | Material |  | 63.44 |
| TUBERIA Ø 315MM PVC-U NTP ISO 1452 UF PN-7.5 INC. ANILLO | Material |  | 90.66 |
| TUBERIA Ø 200MM PVC-U NTP ISO 1452 UF PN-7.5 INC. ANILLO | Material |  | 35.8 |
| ESTACION TOTAL | Equipo | 120 |  |
| REGISTRADOR ELECTRONICO P/ CAUDAL VOLUMEN Y PRESION | Equipo | 60 |  |
| TUBO MEZCLADOR DE 22 HP (300 Litros) | Equipo | 35 |  |
| AGITADOR 2.5 HP (400 litros) | Equipo | 30 |  |
| HERRAMIENTAS MANUALES | Equipo | 8 |  |
| MOTOBOMBA DE 4" (12 HP) | Equipo | 17.4 |  |
| BOMBA DE INYECCION ELECTRICA 50 BARES | Equipo | 70 |  |
| COMPACTADORA VIBRATORIA TIPO PLANCHA 7 HP | Equipo | 15.29 |  |
| RODILLO LISO VIBRATORIO AUTOPROPULSADO 7- 9 ton | Equipo | 93.22 |  |
| MARTILLO NEUMATICO DE 29 kg | Equipo | 16.8 |  |
| COMPRESORA NEUMATICA 335 - 375 PCM - 93 HP | Equipo | 50 |  |
| COMPRESORA NEUMATICA 600 - 690 PCM - 196 HP | Equipo | 89.5 |  |
| CARGADOR SOBRE LLANTAS DE 160-195 HP 3.5 yd3 | Equipo | 127.12 |  |
| CARGADOR FRONTAL 200-250 HP | Equipo | 152.54 |  |
| EXCAVADORA SOBRE LLANTAS 1.20 M3 | Equipo | 194.91 |  |
| TRACTOR DE ORUGAS CAT D6D | Equipo | 203.39 |  |
| MOTONIVELADORA 125 HP | Equipo | 135.59 |  |
| CAMION VOLQUETE DE 15 m3 | Equipo | 118.64 |  |
| CAMION CISTERNA (2 500 GLNS.) | Equipo | 114.41 |  |
| CAMION GRUA | Equipo | 112 |  |
| CAMION CONCRETERO 6X4 300 HP 8M3 | Equipo | 194.92 |  |
| GRUPO ELECTROGENO DE 50 KW. | Equipo | 32 |  |
| GRUPO ELECTROGENO DE 140 HP 90 KW | Equipo | 41 |  |
| MAQUINA SOLDADORA | Equipo | 10.44 |  |
| VIBRADOR DE CONCRETO 4 HP 1.25" | Equipo | 5.92 |  |
| MEZCLADORA DE CONCRETO 11 P3 (23 HP) | Equipo | 15.05 |  |
| DOSIFICADORA DE CONCRETO 60HP 120 m3/h | Equipo | 115.74 |  |
| ANDAMIO METALICO | Equipo | 1.8 |  |
| CHANCADORA PRIMARIA SECUNDARIA 46 - 70 ton/h | Equipo | 153.48 |  |
| FAJA TRANSPORTADORA 18"X 50' 150ton/h | Equipo | 5.75 |  |
| ZARANDA VIBRATORIA DE 4"x6"x14" MOTOR ELECTRICO | Equipo | 53.1 |  |
| PUERTA METALICA | Equipo | 134.82 |  |
| VENTANA | Equipo | 81.27 |  |
| PERFORACIÓN Y DISPARO EN ROCA FIJA | Material | 19 |  |
| PERFORACIÓN Y DISPARO EN ROCA SUELTA |  | 9.53 |  |
| PIEDRA CHANCADA DE 1/2" Ó 3/4" (D cant.Prom=0.52 km) | Material | 27.23 |  |
| ARENA GRUESA (D cant.prom = 0.52 km) | Material | 43.97 |  |
| AGUA | Material | 18.98 |  |
| SELECCIÓN Y CARGUÍO DE CANTERA | Material | 5.31 |  |
| TRANSPORTE DE ROCA D MENOR 1Km | Material | 2 |  |
| ACOMODO DE ENROCADO GAVIÓN | Material | 5.65 |  |
| MATERIAL DE PRESTAMO HOMOGENEO | Material | 12.87 |  |
| MATERIAL DE PRESTAMO DE CANTERA Dmás=500mm | Material | 19.93 |  |
| TRANSPORTE DE ROCA D MENOR IGUAL 1Km |  | 6.38 |  |
| ACOMODO DE ENROCADO | Material | 5.4 |  |
| PIEDRA MEDIANA | Material | 39.97 |  |
| CARGUIO | Material | 1.44 |  |
| TRANSPORTE MATERIAL FINO PARA D MENOR A 1KM | Material | 1.89 |  |
| TRANSPORTE MATERIAL FINO PARA D MAYOR IGUAL A 1KM | Material | 2.41 |  |
| ZARANDEO DE MATERIAL DE CANTERA GRAVA D max=500mm | Material | 9.24 |  |
| EXTRACCION EN CANTERA Y APILAMIENTO | Material | 1.96 |  |

## Schedule

| ID | WBS | Task | Type | Duration | Start | Finish | Predecessors | Total slack | Free slack | Constraint | Resources | Work | Cost | Text1 | Text8 | Text2 | Text3 | Text4 | Text6 |
| --- | --- | --- | --- | --- | --- | --- | --- | --- | --- | --- | --- | --- | --- | --- | --- | --- | --- | --- | --- |
| 1 | 1 | **INSTALACION DEL SISTEMA DE SERVICIO DE AGUA DE RIEGO PUMAPAHUASIN** |  | 360d | 2018-07-02 | 2019-06-26 |  |  |  |  |  | 253779h | 8,329,112.69 |  |  |  |  |  |  |
| 2 | 1.1 | INICIO DE OBRA | milestone | 0d | 2018-07-02 | 2018-07-02 |  | 1d | 0d | start no earlier than 2018-07-02 |  |  |  |  |  |  |  |  |  |
| 3 | 1.2 | **PRESA** |  | 360d | 2018-07-02 | 2019-06-26 |  | 1d |  |  |  | 59223.5h | 6,293,058.52 | 01 | 000000000000001 |  |  |  |  |
| 4 | 1.2.1 | **OBRAS PROVISIONALES** |  | 360d | 2018-07-02 | 2019-06-26 |  | 1d |  |  |  | 5403.46h | 385,929.05 | 01.01 | 000000000000002 |  |  |  |  |
| 5 | 1.2.1.1 | SUMINISTRO ELECTRICO DE CAMPAMENTO Y OBRA |  | 360d | 2018-07-02 | 2019-06-26 | 2 | 1d | 0d | start no earlier than 2018-06-11 | GRUPO ELECTROGENO DE 50 KW. [75%] | 2160h | 69,120 | 01.01.01 | 000000000000003 | 12 | 5760 | 69120 |  |
| 6 | 1.2.1.2 | CARTEL DE OBRA 3,60 X 2.40M |  | 2d | 2018-07-02 | 2018-07-03 | 2 | 1d | 0d | start no earlier than 2018-06-11 | CEMENTO PORTLAND TIPO IP (42.5 kg) [90%]; ANDAMIO METALICO [12%]; PINTURA ESMALTE SINTETICO [43.2%]; OPERARIO; PEON [200%]; CLAVOS PARA MADERA CON CABEZA DE 3"; TRIPLAY DE 1.20X2.40 m X 9 mm [864%]; MADERA TORNILLO [7000%]; HERRAMIENTAS MANUALES [35%] | 2763.46h | 3,846.65 | 01.01.02 | 000000000000004 |  | 1923.3 | 3846.6 | 0.5 |
| 7 | 1.2.1.3 | FLETE TERRESTRE DE MATERIALES |  | 180d | 2018-07-03 | 2018-12-30 | 6 | 178d |  | start no earlier than 2018-06-11 | FLETE | 240h | 184,860 | 01.01.03 | 000000000000005 |  | 184861.16 | 184861.16 |  |
| 8 | 1.2.1.4 | FLETE RURAL DE MATERIALES |  | 180d | 2018-07-03 | 2018-12-30 | 6 | 178d |  | start no earlier than 2018-06-11 | FLETE TERRESTRE RURAL | 240h | 128,102.4 | 01.01.04 | 000000000000006 |  | 128103.5 | 128103.5 |  |
| 9 | 1.2.2 | **TRABAJOS PRELIMINARES** |  | 360d | 2018-07-02 | 2019-06-26 |  | 1d |  |  |  | 4952.6h | 243,977.43 | 01.02 | 000000000000007 |  |  |  |  |
| 10 | 1.2.2.1 | MOVILIZACION Y DESMOVILIZACION |  | 360d | 2018-07-02 | 2019-06-26 | 6SS | 1d |  | start no earlier than 2018-06-11 | MOVILIZACION Y DESMOVILIZACION | 240h | 130,576.8 | 01.02.01 | 000000000000008 |  | 130576.19 | 130576.19 |  |
| 11 | 1.2.2.2 | DESBROCE Y LIMPIEZA |  | 3d | 2018-07-03 | 2018-07-06 | 6 | 355d | 0d | finish no earlier than 2018-06-15 | PEON [3028%]; HERRAMIENTAS MANUALES [150%] | 1579.2h | 18,505.6 | 01.02.02 | 000000000000009 | 1.83 | 10112.13 | 18505.2 | 0.05 |
| 12 | 1.2.2.3 | TRAZO, NIVELACION Y REPLANTEO |  | 40d | 2018-07-03 | 2018-08-12 | 11SS | 0d |  | start no earlier than 2018-06-11 | YESO BOLSA 28 kg [5%]; ESTACION TOTAL [21%]; PEON [750%]; MADERA TORNILLO [2%]; HERRAMIENTAS MANUALES [29%] | 2586.6h | 45,678.53 | 01.02.03 | 000000000000010 | 1.83 | 24960.74 | 45678.15 | 0.02 |
| 13 | 1.2.2.4 | CAMPAMENTO |  | 40d | 2018-07-03 | 2018-08-12 | 11SS | 318d |  | start no earlier than 2018-06-11 | OPERARIO; PEON; ALAMBRE NEGRO N° 16 [8000%]; CLAVOS 2" - 4" [16000%]; TRIPLAY DE 1.20X2.40 m X 9 mm [28560%]; MADERA TORNILLO [120000%]; CALAMINA [64000%]; HERRAMIENTAS MANUALES [5%] | 546.8h | 49,216.5 | 01.02.04 | 000000000000011 | 800 | 61.52 | 49216 | 35 |
| 14 | 1.2.3 | **ACCESOS NUEVOS** |  | 70d | 2018-07-13 | 2018-09-21 |  | 0d |  |  |  | 2633.83h | 281,930.37 | 01.03 | 000000000000012 |  |  |  |  |
| 15 | 1.2.3.1 | **MEJORAMIENTO DE ACCESOS** |  | 70d | 2018-07-13 | 2018-09-21 |  | 0d |  |  |  | 2633.83h | 281,930.37 | 01.03.01 | 000000000000013 |  |  |  |  |
| 16 | 1.2.3.1.1 | EXCAVACION EN MATERIAL SUELTO |  | 65d | 2018-07-13 | 2018-09-16 | 12FS-30d | 0d |  | start no earlier than 2018-06-28 | OFICIAL [70%]; PEON [570%]; EXCAVADORA SOBRE LLANTAS 1.20 M3 [320%]; HERRAMIENTAS MANUALES [24%] | 1967.98h | 144,998.13 | 01.03.01.01 | 000000000000014 | 38359.32 | 3.78 | 144998.23 | 450 |
| 17 | 1.2.3.1.2 | EXCAVACION EN ROCA SUELTA |  | 15d | 2018-09-01 | 2018-09-16 | 16FF | 284d |  | start no earlier than 2018-06-11 | PEON [148%]; TRACTOR DE ORUGAS CAT D6D [96%]; HERRAMIENTAS MANUALES [7%]; PERFORACIÓN Y DISPARO EN ROCA SUELTA [451200%] | 335.8h | 69,498.27 | 01.03.01.02 | 000000000000015 | 4512.86 | 15.4 | 69498.04 | 320 |
| 18 | 1.2.3.1.3 | EXCAVACION EN ROCA FIJA |  | 9d | 2018-09-07 | 2018-09-16 | 16FF | 284d |  | start no earlier than 2018-06-11 | PEON [250%]; TRACTOR DE ORUGAS CAT D6D [85%]; HERRAMIENTAS MANUALES [3%]; PERFORACIÓN Y DISPARO EN ROCA FIJA [225500%] | 241.8h | 58,058.47 | 01.03.01.03 | 000000000000016 | 2256.43 | 25.73 | 58057.94 | 280 |
| 19 | 1.2.3.1.4 | RELLENO DE MATERIAL PROPIO |  | 5d | 2018-09-17 | 2018-09-21 | 16 | 279d |  | start no earlier than 2018-06-11 | PEON [80%]; RODILLO LISO VIBRATORIO AUTOPROPULSADO 7- 9 ton [20%]; TRACTOR DE ORUGAS CAT D6D [70%]; MOTONIVELADORA 125 HP [45%]; HERRAMIENTAS MANUALES [12%] | 88.25h | 9,375.5 | 01.03.01.04 | 000000000000017 | 1820.5 | 5.15 | 9375.58 | 720 |
| 20 | 1.2.4 | **TRATAMIENTO DE LA FUNDACION** |  | 79d | 2018-07-13 | 2018-09-30 |  | 0d |  |  |  | 11139.6h | 706,359.66 | 01.04 | 000000000000018 |  |  |  |  |
| 21 | 1.2.4.1 | **MOVIMIENTO DE TIERRAS** |  | 3d | 2018-07-13 | 2018-07-16 |  | 0d |  |  |  | 340.64h | 12,400.96 | 01.04.01 | 000000000000019 |  |  |  |  |
| 22 | 1.2.4.1.1 | EXCAVACION EN MATERIAL SUELTO |  | 1d | 2018-07-13 | 2018-07-14 | 16SS | 0d |  | start no earlier than 2018-06-11 | OFICIAL [1%]; PEON [9.6%]; EXCAVADORA SOBRE LLANTAS 1.20 M3 [9.6%] | 1.64h | 163.35 | 01.04.01.01 | 000000000000020 | 43.2 | 3.78 | 163.3 | 450 |
| 23 | 1.2.4.1.2 | CONCRETO FC=140 KG/CM2 |  | 2d | 2018-07-14 | 2018-07-16 | 22 | 0d |  | start no earlier than 2018-06-11 | CEMENTO PORTLAND TIPO IP (42.5 kg) [21600%]; ADITIVO IMPERMEABILIZANTE [864%]; OPERARIO [600%]; OFICIAL [300%]; PEON [1000%]; VIBRADOR DE CONCRETO 4 HP 1.25"; MEZCLADORA DE CONCRETO 11 P3 (23 HP); HERRAMIENTAS MANUALES [50%]; AGUA [821%]; ARENA GRUESA (D cant.prom = 0.52 km) [2203%]; PIEDRA CHANCADA DE 1/2" Ó 3/4" (D cant.Prom=0.52 km) [3110%] | 339h | 12,237.61 | 01.04.01.02 | 000000000000021 | 43.2 | 283.32 | 12239.42 | 15 |
| 24 | 1.2.4.2 | **INYECCIONES DE IMPERMEABILIZACION** |  | 71d | 2018-07-16 | 2018-09-25 |  | 0d |  |  |  | 9394.4h | 604,362.99 | 01.04.02 | 000000000000022 |  |  |  |  |
| 25 | 1.2.4.2.1 | PERFORACION ROTOPERCUSIVA |  | 5d | 2018-07-30 | 2018-08-04 | 23SS+16d | 0d |  | start no earlier than 2018-06-11 | PERFORACION ROTOPERCUSIVA Ø 2-1/2"(PARA IMPERMEABILIZACION Y CONSOLIDACION) [158696%] |  | 190,435.2 | 01.04.02.01 | 000000000000023 | 1586.96 | 120 | 190435.2 |  |
| 26 | 1.2.4.2.2 | INYECCION DE AGUA - CEMENTO |  | 45d | 2018-08-04 | 2018-09-18 | 25 | 0d |  | start no earlier than 2018-06-11 | CEMENTO PORTLAND TIPO IP (42.5 kg) [442725%]; OPERARIO [400%]; OFICIAL [300%]; PEON [800%]; REGISTRADOR ELECTRONICO P/ CAUDAL VOLUMEN Y PRESION [250%]; TUBO MEZCLADOR DE 22 HP (300 Litros) [250%]; AGITADOR 2.5 HP (400 litros) [250%]; BOMBA DE INYECCION ELECTRICA 50 BARES [360%]; ADITIVO FLUIDIFICANTE [44272.5%] | 9394.4h | 396,766.59 | 01.04.02.02 | 000000000000024 | 177.09 | 2240.48 | 396766.6 |  |
| 27 | 1.2.4.2.3 | ENSAYO DE PERMEABILIDAD TIPO LUGEON |  | 7d | 2018-09-18 | 2018-09-25 | 26 | 0d |  | start no earlier than 2018-06-11 | ENSAYO DE PERMEABILIDAD TIPO LUGEON [2000%] |  | 5,400 | 01.04.02.03 | 000000000000025 | 20 | 270 | 5400 |  |
| 28 | 1.2.4.2.4 | TRASLADO DE EQUIPOS ENTRE PUNTOS DE PERFORACION |  | 7d | 2018-07-16 | 2018-07-23 | 23 | 48d |  | start no earlier than 2018-06-11 | TRASLADO DE EQUIPO DE PERFORACION [8100%] |  | 11,761.2 | 01.04.02.04 | 000000000000026 | 81 | 145.2 | 11761.2 |  |

| ID | WBS | Task | Duration | Start | Finish | Predecessors | Total slack | Free slack | Constraint | Resources | Work | Cost | Text1 | Text8 | Text2 | Text3 | Text4 | Text6 |
| --- | --- | --- | --- | --- | --- | --- | --- | --- | --- | --- | --- | --- | --- | --- | --- | --- | --- | --- |
| 29 | 1.2.4.3 | **TRATAMIENTO DE LA CONSOLIDACION** | 20d | 2018-09-10 | 2018-09-30 |  | 0d |  |  |  | 1404.57h | 89,595.71 | 01.04.03 | 000000000000027 |  |  |  |  |
| 30 | 1.2.4.3.1 | GEOMALLA TRIAXIAL 160 | 20d | 2018-09-10 | 2018-09-30 | 27FS-15d, 28 | 0d |  | start no earlier than 2018-06-11 | OPERARIO [280%]; PEON [550%]; GEOMALLA TRIAXIAL 160 [440707%]; HERRAMIENTAS MANUALES [50%] | 1404.57h | 89,595.71 | 01.04.03.01 | 000000000000028 | 4407.07 | 20.33 | 89595.73 | 80 |
| 31 | 1.2.5 | **CONSTRUCCIÓN DE PRESA** | 236d | 2018-09-15 | 2019-05-09 |  | 0d |  |  |  | 31601.7h | 4,140,337.42 | 01.05 | 000000000000029 |  |  |  |  |
| 32 | 1.2.5.1 | **CONTROL ALTIMETRICO Y PLANIMETRICO** | 12.75d | 2018-10-10 | 2018-10-23 |  |  |  |  |  | 206h | 3,997.72 | 01.05.01 | 000000000000030 |  |  |  |  |
| 33 | 1.2.5.1.1 | CONTROL ALTIMETRICO Y PLANIMETRICO | 8d | 2018-09-15 | 2018-09-23 | 30FS-15d | 0d |  | start no earlier than 2018-06-11 | YESO BOLSA 28 kg [40%]; ESTACION TOTAL [12.5%]; PEON [330%]; MADERA TORNILLO [16%]; HERRAMIENTAS MANUALES [20%] | 206h | 3,997.72 | 01.05.01.01 | 000000000000031 |  | 499.7 | 3997.6 |  |
| 34 | 1.2.5.2 | **MOVIMIENTO DE TIERRAS** | 70d | 2018-09-15 | 2018-11-24 |  | 14d |  |  |  | 3806.88h | 486,246.91 | 01.05.02 | 000000000000032 |  |  |  |  |
| 35 | 1.2.5.2.1 | EXCAVACION EN MATERIAL SUELTO | 55d | 2018-09-15 | 2018-11-09 | 33SS | 14d | 0d | start no earlier than 2018-06-11 | OFICIAL [30%]; PEON [150%]; EXCAVADORA SOBRE LLANTAS 1.20 M3 [150%]; HERRAMIENTAS MANUALES [20%] | 1516.5h | 141,330.32 | 01.05.02.01 | 000000000000033 | 37388.47 | 3.78 | 141328.42 | 450 |
| 36 | 1.2.5.2.2 | EXCAVACION EN ROCA SUELTA | 8d | 2018-11-01 | 2018-11-09 | 35FF | 230d |  | start no earlier than 2018-06-11 | PEON [405%]; TRACTOR DE ORUGAS CAT D6D [175%]; HERRAMIENTAS MANUALES [15%]; PERFORACIÓN Y DISPARO EN ROCA SUELTA [435900%] | 308h | 67,136.75 | 01.05.02.02 | 000000000000034 | 4359.59 | 15.4 | 67137.69 | 320 |
| 37 | 1.2.5.2.3 | EXCAVACION EN ROCA FIJA | 12d | 2018-10-29 | 2018-11-09 | 35FF | 14d | 0d | start no earlier than 2018-06-11 | PEON [320%]; TRACTOR DE ORUGAS CAT D6D [125%]; HERRAMIENTAS MANUALES [25%]; PERFORACIÓN Y DISPARO EN ROCA FIJA [435900%] | 456.2h | 112,172.25 | 01.05.02.03 | 000000000000035 | 4359.59 | 25.73 | 112172.25 | 280 |
| 38 | 1.2.5.2.4 | ELIMINACION DE MATERIAL EXCEDENTE | 70d | 2018-09-15 | 2018-11-24 | 35FS-55d | 215d |  | start no earlier than 2018-06-11 | OFICIAL [55%]; CARGADOR FRONTAL 200-250 HP; CAMION VOLQUETE DE 15 m3 [112%] | 1526.18h | 165,607.6 | 01.05.02.04 | 000000000000036 | 43927.85 | 3.77 | 165607.99 | 450 |
| 39 | 1.2.5.3 | **CONCRETO EN PRESA** | 175d | 2018-11-09 | 2019-05-03 |  | 14d |  |  |  | 18377.2h | 3,060,200.37 | 01.05.03 | 000000000000037 |  |  |  |  |
| 40 | 1.2.5.3.1 | RELLENO EN GAVION TIPO CAJA (A1) | 15d | 2019-04-18 | 2019-05-03 | 43 | 55d | 0d | start no earlier than 2018-06-11 | PERFORACIÓN Y DISPARO EN ROCA FIJA [12300%]; SELECCIÓN Y CARGUÍO DE CANTERA [12500%]; TRANSPORTE DE ROCA D MENOR 1Km [12300%]; ACOMODO DE ENROCADO GAVIÓN [12500%] |  | 3,953 | 01.05.03.01 | 000000000000038 | 127.5 | 31 | 3952.5 |  |
| 41 | 1.2.5.3.2 | RELLENO HOMOGENO (A2) | 145d | 2018-11-09 | 2019-04-03 | 37 | 14d | 0d | start no earlier than 2018-06-11 | OFICIAL [120%]; PEON [150%]; RODILLO LISO VIBRATORIO AUTOPROPULSADO 7- 9 ton [600%]; TRACTOR DE ORUGAS CAT D6D [400%]; MOTONIVELADORA 125 HP [270%]; HERRAMIENTAS MANUALES [10%]; AGUA; MATERIAL DE PRESTAMO HOMOGENEO | 18377.2h | 2,905,025.56 | 01.05.03.02 | 000000000000039 | 148442.8 | 19.57 | 2905025.6 | 780 |
| 42 | 1.2.5.3.3 | PANTALLA GAVION TIPO COLCHON (C1) | 30d | 2019-03-15 | 2019-04-14 | 41FS-19d | 14d | 0d | start no earlier than 2018-06-11 | PERFORACIÓN Y DISPARO EN ROCA FIJA [180050%]; SELECCIÓN Y CARGUÍO DE CANTERA [180050%]; TRANSPORTE DE ROCA D MENOR 1Km [179500%]; ACOMODO DE ENROCADO GAVIÓN [184500%] |  | 57,784.4 | 01.05.03.03 | 000000000000040 | 1863.95 | 31 | 57782.45 |  |
| 43 | 1.2.5.3.4 | ENROCADO DE PROTECCION (D1) | 25d | 2019-03-25 | 2019-04-18 | 42SS+9d | 55d | 0d | start no earlier than 2018-06-11 | PERFORACIÓN Y DISPARO EN ROCA FIJA [300000%]; ACOMODO DE ENROCADO GAVIÓN [300000%]; SELECCIÓN Y CARGUÍO DE CANTERA [254000%]; TRANSPORTE DE ROCA D MENOR 1Km [300000%] |  | 93,437.4 | 01.05.03.04 | 000000000000041 | 3038.63 | 30.75 | 93437.87 |  |
| 44 | 1.2.5.4 | **FILTRO EN PRESA** | 7d | 2018-12-10 | 2018-12-16 |  | 155d |  |  |  | 549.7h | 102,130.12 | 01.05.04 | 000000000000042 |  |  |  |  |
| 45 | 1.2.5.4.1 | FILTRO HORIZONTAL, MATERIAL GRANULAR | 3d | 2018-12-10 | 2018-12-12 | 41SS+30d | 155d | 0d | start no earlier than 2018-06-11 | OFICIAL [300%]; PEON [500%]; RODILLO LISO VIBRATORIO AUTOPROPULSADO 7- 9 ton; TRACTOR DE ORUGAS CAT D6D; MOTONIVELADORA 125 HP; HERRAMIENTAS MANUALES [30%]; AGUA [15000%]; MATERIAL DE PRESTAMO DE CANTERA Dmás=500mm [130000%] | 270.1h | 42,720.62 | 01.05.04.01 | 000000000000043 | 1517.1 | 28.16 | 42721.54 | 780 |
| 46 | 1.2.5.4.2 | FILTRO CHIMINEA, MATERIAL GRANULAR | 4d | 2018-12-12 | 2018-12-16 | 45 | 193d |  | start no earlier than 2018-06-11 | OFICIAL [200%]; PEON [400%]; RODILLO LISO VIBRATORIO AUTOPROPULSADO 7- 9 ton [80%]; TRACTOR DE ORUGAS CAT D6D; MOTONIVELADORA 125 HP; HERRAMIENTAS MANUALES [15%]; AGUA [20000%]; MATERIAL DE PRESTAMO DE CANTERA Dmás=500mm [200000%] | 279.6h | 59,409.5 | 01.05.04.02 | 000000000000044 | 2109.71 | 28.16 | 59409.43 | 780 |
| 47 | 1.2.5.5 | **OBRAS VARIAS** | 151d | 2018-12-10 | 2019-05-09 |  | 49d |  |  |  | 8661.87h | 487,762.3 | 01.05.05 | 000000000000045 |  |  |  |  |
| 48 | 1.2.5.5.1 | GAVION TIPO CAJA 5x5x1 m | 8d | 2019-02-27 | 2019-03-07 | 40SS-50d | 112d |  | start no earlier than 2018-06-11 | OPERARIO; PEON [250%]; GAVION TIPO CAJA DE 5.0 x 1 x 1 m (2.7 mm) [5100%]; HERRAMIENTAS MANUALES | 289.65h | 16,098.19 | 01.05.05.01 | 000000000000046 | 51 | 315.65 | 16098.15 | 10 |
| 49 | 1.2.5.5.2 | GAVION TIPO COLCHON 5x2x0.30 m | 30d | 2019-02-08 | 2019-03-10 | 42SS-35d | 49d | 0d | start no earlier than 2018-06-11 | OPERARIO [450%]; PEON [770%]; GAVION TIPO COLCHON 5x2x0.30 (2.7 mm) [62100%]; HERRAMIENTAS MANUALES | 3166.8h | 207,277.12 | 01.05.05.02 | 000000000000047 | 621 | 333.78 | 207277.38 | 10 |
| 50 | 1.2.5.5.3 | GEOTEXTIL TEJIDO 200 gr / m2 | 30d | 2019-03-10 | 2019-04-09 | 49 | 49d | 0d | start no earlier than 2018-06-11 | OPERARIO [240%]; PEON [240%]; GEOTEXTIL TEJIDO 200 GR/M2; HERRAMIENTAS MANUALES [60%] | 1273h | 104,270 | 01.05.05.03 | 000000000000048 | 14706.9 | 7.09 | 104271.92 | 200 |
| 51 | 1.2.5.5.4 | GEOMEMBRANA HDPE E=1.00 mm | 30d | 2019-04-09 | 2019-05-09 | 50 | 49d |  | start no earlier than 2018-06-11 | OPERARIO [95%]; OFICIAL [95%]; PEON [165%]; GEOMEMBRANA HDPE e=1.0 mm [735345%]; HERRAMIENTAS MANUALES | 1093.5h | 73,460.29 | 01.05.05.04 | 000000000000049 | 7353.45 | 9.99 | 73460.97 | 250 |
| 52 | 1.2.5.5.5 | GEOTEXTIL NO TEJIDO 200 gr / m2 | 45d | 2018-12-10 | 2019-01-23 | 45SS | 155d |  | start no earlier than 2018-06-11 | OPERARIO [75%]; PEON [72%]; GEOTEXTIL NO TEJIDO 200 GR/M2 [655341%]; HERRAMIENTAS MANUALES [5%] | 546h | 33,356.38 | 01.05.05.05 | 000000000000050 | 6553.41 | 5.09 | 33356.86 | 200 |
| 53 | 1.2.5.5.6 | TUBERIA PVC 200 mm | 3d | 2019-01-13 | 2019-01-16 | 54 | 162d |  | start no earlier than 2018-06-11 | OPERARIO [2%]; PEON [3%]; TUBERIA PVC C-10 200 mm [4500%]; HERRAMIENTAS MANUALES [3%] | 1.92h | 1,180.24 | 01.05.05.06 | 000000000000051 | 45 | 26.24 | 1180.8 | 500 |
| 54 | 1.2.5.5.7 | RELLENO ARCILLA (PIE TALUD) | 35d | 2018-12-10 | 2019-01-13 | 41SS+30d | 162d | 0d | start no earlier than 2018-06-11 | OFICIAL [335%]; PEON [390%]; HERRAMIENTAS MANUALES; MATERIAL DE PRESTAMO HOMOGENEO [134400%] | 2291h | 52,120.08 | 01.05.05.07 | 000000000000052 | 1344 | 38.78 | 52120.32 |  |

| ID | WBS | Task | Duration | Start | Finish | Predecessors | Total slack | Free slack | Constraint | Resources | Work | Cost | Text1 | Text8 | Text2 | Text3 | Text4 | Text6 |
| --- | --- | --- | --- | --- | --- | --- | --- | --- | --- | --- | --- | --- | --- | --- | --- | --- | --- | --- |
| 55 | 1.2.6 | **ALIVIADERO** | 16d | 2018-09-15 | 2018-10-01 |  | 0d |  |  |  | 803.21h | 106,409.14 | 01.06 | 000000000000053 |  |  |  |  |
| 56 | 1.2.6.1 | **MOVIMIENTO DE TIERRAS** | 9d | 2018-09-15 | 2018-09-24 |  | 0d |  |  |  | 70.93h | 4,964.41 | 01.06.01 | 000000000000054 |  |  |  |  |
| 57 | 1.2.6.1.1 | EXCAVACION EN MATERIAL SUELTO | 2d | 2018-09-15 | 2018-09-17 | 33SS | 0d |  | start no earlier than 2018-06-11 | OFICIAL [5%]; PEON [6%]; EXCAVADORA SOBRE LLANTAS 1.20 M3 [21%]; HERRAMIENTAS MANUALES [15%] | 7.22h | 700.06 | 01.06.01.01 | 000000000000055 | 185.25 | 3.78 | 700.25 | 450 |
| 58 | 1.2.6.1.2 | EXCAVACION EN ROCA SUELTA | 2d | 2018-09-15 | 2018-09-17 | 57FF | 283d |  | start no earlier than 2018-06-11 | PEON [10%]; TRACTOR DE ORUGAS CAT D6D [10%]; HERRAMIENTAS MANUALES [5%]; PERFORACIÓN Y DISPARO EN ROCA SUELTA [6175%] | 4.75h | 950.85 | 01.06.01.02 | 000000000000056 | 61.75 | 15.4 | 950.95 | 320 |
| 59 | 1.2.6.1.3 | EXCAVACION EN ROCA FIJA | 2d | 2018-09-15 | 2018-09-17 | 57FF | 0d |  | start no earlier than 2018-06-11 | PEON [10%]; TRACTOR DE ORUGAS CAT D6D [10%]; HERRAMIENTAS MANUALES [50%]; PERFORACIÓN Y DISPARO EN ROCA FIJA [6182%] | 11.2h | 1,588.55 | 01.06.01.03 | 000000000000057 | 61.75 | 25.73 | 1588.83 | 280 |
| 60 | 1.2.6.1.4 | CAMA DE APOYO (MATERIAL ZARANDEADO) | 5d | 2018-09-17 | 2018-09-22 | 59 | 0d |  | start no earlier than 2018-06-11 | PEON [85%]; HERRAMIENTAS MANUALES [5%] | 36h | 537.56 | 01.06.01.04 | 000000000000058 | 17 | 31.6 | 537.2 |  |
| 61 | 1.2.6.1.5 | RELLENO ENROCADO RIP - RAP | 2d | 2018-09-22 | 2018-09-24 | 60 | 276d |  | start no earlier than 2018-06-11 | PERFORACIÓN Y DISPARO EN ROCA FIJA [64%]; ACOMODO DE ENROCADO GAVIÓN [76%]; SELECCIÓN Y CARGUÍO DE CANTERA; TRANSPORTE DE ROCA D MENOR 1Km |  | 23.76 | 01.06.01.05 | 000000000000059 | 0.64 | 37.13 | 23.76 | 2.5 |
| 62 | 1.2.6.1.6 | ELIMINACION DE MATERIAL EXCEDENTE | 2d | 2018-09-17 | 2018-09-19 | 59 | 281d |  | start no earlier than 2018-06-11 | OFICIAL [20%]; CARGADOR FRONTAL 200-250 HP [15%]; CAMION VOLQUETE DE 15 m3 [40%] | 11.76h | 1,163.64 | 01.06.01.06 | 000000000000060 | 308.75 | 3.77 | 1163.99 | 450 |
| 63 | 1.2.6.2 | **CONCRETO** | 8d | 2018-09-22 | 2018-09-30 |  | 0d |  |  |  | 313.28h | 2,673.57 | 01.06.02 | 000000000000061 |  |  |  |  |
| 64 | 1.2.6.2.1 | SOLADO DE CONCRETO FC=100 KG/CM2 | 2d | 2018-09-22 | 2018-09-24 | 60 | 0d |  | start no earlier than 2018-06-11 | CEMENTO PORTLAND TIPO IP (42.5 kg) [95%]; OPERARIO [1%]; OFICIAL [1%]; PEON [1%]; VIBRADOR DE CONCRETO 4 HP 1.25" [1%]; HERRAMIENTAS MANUALES [1%]; PIEDRA CHANCADA DE 1/2" Ó 3/4" (D cant.Prom=0.52 km); ARENA GRUESA (D cant.prom = 0.52 km); AGUA; MEZCLADORA DE CONCRETO 11 P3 (23 HP) [1%] | 16.16h | 33.31 | 01.06.02.01 | 000000000000062 | 0.16 | 207.06 | 33.13 | 16 |
| 65 | 1.2.6.2.2 | CONCRETO FC=210 KG/CM2 | 2d | 2018-09-28 | 2018-09-30 | 67 | 270d |  | start no earlier than 2018-06-11 | CEMENTO PORTLAND TIPO IP (42.5 kg) [791%]; ADITIVO IMPERMEABILIZANTE [791%]; OPERARIO [60%]; OFICIAL [30%]; PEON; CARGADOR SOBRE LLANTAS DE 160-195 HP 3.5 yd3 [10%]; CAMION CONCRETERO 6X4 300 HP 8M3 [20%]; VIBRADOR DE CONCRETO 4 HP 1.25" [10%]; DOSIFICADORA DE CONCRETO 60HP 120 m3/h [15%]; HERRAMIENTAS MANUALES [30%]; PIEDRA CHANCADA DE 1/2" Ó 3/4" (D cant.Prom=0.52 km) [791%]; ARENA GRUESA (D cant.prom = 0.52 km) [791%]; AGUA [791%] | 297.12h | 2,640.26 | 01.06.02.02 | 000000000000063 | 7.91 | 333.75 | 2639.96 | 120 |
| 66 | 1.2.6.3 | **ENCOFRADO** | 2d | 2018-09-26 | 2018-09-28 |  | 0d |  |  |  | 196h | 990.05 | 01.06.03 | 000000000000064 |  |  |  |  |
| 67 | 1.2.6.3.1 | ENCOFRADO Y DESENCOFRADO | 2d | 2018-09-26 | 2018-09-28 | 69 | 0d |  | start no earlier than 2018-06-11 | OPERARIO; OFICIAL; PEON; ALAMBRE NEGRO N° 8 [200%]; CLAVOS 2" - 4" [300%]; MADERA NACIONAL P/ENCOFRADO-CARP [350%]; TRIPLAY DE 1.20X2.40 m X 18 mm [45%]; HERRAMIENTAS MANUALES [50%] | 196h | 990.05 | 01.06.03.01 | 000000000000065 | 19.48 | 50.85 | 990.56 | 15 |
| 68 | 1.2.6.4 | **ACERO** | 2d | 2018-09-24 | 2018-09-26 |  | 0d |  |  |  | 150.4h | 118.07 | 01.06.04 | 000000000000066 |  |  |  |  |
| 69 | 1.2.6.4.1 | ACERO DE REFUERZO GRADO 60 | 2d | 2018-09-24 | 2018-09-26 | 64 | 0d |  | start no earlier than 2018-06-11 | OPERARIO [10%]; PEON [10%]; ACERO CORRUGADO fy = 4200 kg/cm2 GRADO 60 [900%]; HERRAMIENTAS MANUALES [20%] | 150.4h | 118.07 | 01.06.04.01 | 000000000000067 | 23.5 |  | 117.5 | 250 |
| 70 | 1.2.6.5 | **OBRAS VARIAS** | 5d | 2018-09-26 | 2018-10-01 |  | 0d |  |  |  | 72.6h | 97,663.04 | 01.06.05 | 000000000000068 |  |  |  |  |
| 71 | 1.2.6.5.1 | SUMIN. E INSTALACION TUBERIA HDPE CORRUGADA 600mm | 5d | 2018-09-26 | 2018-10-01 | 67SS | 0d |  | start no earlier than 2018-06-11 | OPERARIO [85%]; PEON [85%]; TUBERIA HDPE CORUGADA 600 mm [17000%]; HERRAMIENTAS MANUALES [30%] | 72.6h | 97,663.04 | 01.06.05.01 | 000000000000069 | 170 | 574.49 | 97663.3 | 40 |
| 72 | 1.2.7 | **SISTEMA DE CAPTACION CONTROL Y SALIDA** | 78d | 2018-10-01 | 2018-12-18 |  | 0d |  |  |  | 2689.16h | 428,115.45 | 01.07 | 000000000000070 |  |  |  |  |
| 73 | 1.2.7.1 | **MOVIMIENTO DE TIERRAS** | 42d | 2018-10-01 | 2018-11-12 |  | 0d |  |  |  | 48.58h | 4,765.27 | 01.07.01 | 000000000000071 |  |  |  |  |
| 74 | 1.2.7.1.1 | EXCAVACION EN MATERIAL SUELTO | 2d | 2018-10-01 | 2018-10-03 | 71 | 0d |  | start no earlier than 2018-06-11 | OFICIAL [6.4%]; PEON [63.7%]; EXCAVADORA SOBRE LLANTAS 1.20 M3 [63.7%]; HERRAMIENTAS MANUALES | 23.1h | 2,165.48 | 01.07.01.01 | 000000000000072 | 572.93 | 3.78 | 2165.68 | 450 |
| 75 | 1.2.7.1.2 | RELLENO ENROCADO RIP - RAP | 5d | 2018-11-07 | 2018-11-12 | 79FF | 227d |  | start no earlier than 2018-06-11 | PERFORACIÓN Y DISPARO EN ROCA FIJA [1138%]; ACOMODO DE ENROCADO [1110%]; SELECCIÓN Y CARGUÍO DE CANTERA [1200%]; TRANSPORTE DE ROCA D MENOR 1Km [1200%]; TRANSPORTE DE ROCA D MENOR IGUAL 1Km [1200%] |  | 440.44 | 01.07.01.02 | 000000000000073 | 11.86 | 37.13 | 440.36 | 2.5 |
| 76 | 1.2.7.1.3 | ELIMINACION DE MATERIAL EXCEDENTE | 2d | 2018-10-03 | 2018-10-05 | 74 | 265d |  | start no earlier than 2018-06-11 | OFICIAL [63.7%]; CARGADOR FRONTAL 200-250 HP [31.9%]; CAMION VOLQUETE DE 15 m3 [63.7%] | 25.48h | 2,159.35 | 01.07.01.03 | 000000000000074 | 572.93 | 3.77 | 2159.95 | 450 |
| 77 | 1.2.7.2 | **RELLENO DEL CUERPO DE LA PRESA DE CONCRETO** | 40d | 2018-10-03 | 2018-11-12 |  | 0d |  |  |  | 197.43h | 52,171.41 | 01.07.02 | 000000000000075 |  |  |  |  |
| 78 | 1.2.7.2.1 | SOLADO DE CONCRETO FC=100 KG/CM2 | 1d | 2018-10-03 | 2018-10-04 | 74 | 0d |  | start no earlier than 2018-06-11 | CEMENTO PORTLAND TIPO IP (42.5 kg) [2445%]; OPERARIO [111.1%]; OFICIAL [65%]; PEON; VIBRADOR DE CONCRETO 4 HP 1.25" [35%]; MEZCLADORA DE CONCRETO 11 P3 (23 HP) [35%]; HERRAMIENTAS MANUALES [50%]; PIEDRA CHANCADA DE 1/2" Ó 3/4" (D cant.Prom=0.52 km) [700%]; ARENA GRUESA (D cant.prom = 0.52 km) [700%]; AGUA [700%] | 34.89h | 1,687.65 | 01.07.02.01 | 000000000000076 | 8.15 | 207.06 | 1687.54 | 16 |
| 79 | 1.2.7.2.2 | CONCRETO FC=210 KG/CM2 | 2d | 2018-11-10 | 2018-11-12 | 81 | 191d | 0d | start no earlier than 2018-06-11 | CEMENTO PORTLAND TIPO IP (42.5 kg) [147176%]; ADITIVO IMPERMEABILIZANTE [3025.2%]; OPERARIO; OFICIAL [200%]; PEON [250%]; CARGADOR SOBRE LLANTAS DE 160-195 HP 3.5 yd3; CAMION CONCRETERO 6X4 300 HP 8M3 [180%]; VIBRADOR DE CONCRETO 4 HP 1.25" [180%]; DOSIFICADORA DE CONCRETO 60HP 120 m3/h [63.1%]; HERRAMIENTAS MANUALES; PIEDRA CHANCADA DE 1/2" Ó 3/4" (D cant.Prom=0.52 km) [10000%]; ARENA GRUESA (D cant.prom = 0.52 km) [10000%]; AGUA [10000%] | 162.54h | 50,483.75 | 01.07.02.02 | 000000000000077 | 151.26 | 333.75 | 50483.03 | 120 |

| ID | WBS | Task | Duration | Start | Finish | Predecessors | Total slack | Free slack | Constraint | Resources | Work | Cost | Text1 | Text8 | Text2 | Text3 | Text4 | Text6 |
| --- | --- | --- | --- | --- | --- | --- | --- | --- | --- | --- | --- | --- | --- | --- | --- | --- | --- | --- |
| 80 | 1.2.7.3 | **ENCOFRADO** | 25d | 2018-10-16 | 2018-11-10 |  | 191d |  |  |  | 1030.09h | 20,636.61 | 01.07.03 | 000000000000078 |  |  |  |  |
| 81 | 1.2.7.3.1 | ENCOFRADO Y DESENCOFRADO | 25d | 2018-10-16 | 2018-11-10 | 83FS-23d | 191d | 0d | start no earlier than 2018-06-11 | OPERARIO [96.6%]; OFICIAL [96.6%]; PEON [193.3%]; ALAMBRE NEGRO N° 8 [4058.4%]; CLAVOS 2" - 4" [6087.6%]; MADERA NACIONAL P/ENCOFRADO-CARP [91922.8%]; TRIPLAY DE 1.20X2.40 m X 18 mm [1014.6%]; HERRAMIENTAS MANUALES [130%] | 1030.09h | 20,636.61 | 01.07.03.01 | 000000000000079 | 405.84 | 50.85 | 20636.96 | 15 |
| 82 | 1.2.7.4 | **ACERO** | 35d | 2018-10-04 | 2018-11-08 |  | 191d |  |  |  | 943.75h | 55,259.07 | 01.07.04 | 000000000000080 |  |  |  |  |
| 83 | 1.2.7.4.1 | ACERO DE REFUERZO GRADO 60 | 35d | 2018-10-04 | 2018-11-08 | 78 | 191d | 0d | start no earlier than 2018-06-11 | OPERARIO [98.2%]; PEON [98.2%]; ACERO CORRUGADO fy = 4200 kg/cm2 GRADO 60; HERRAMIENTAS MANUALES [140%] | 943.75h | 55,259.07 | 01.07.04.01 | 000000000000081 | 11051.88 |  | 55259.4 | 250 |
| 84 | 1.2.7.5 | **INSTALACION DE EQUIPO HIDROMECANICO** | 36d | 2018-11-12 | 2018-12-18 |  | 191d |  |  |  | 23.26h | 182,420.68 | 01.07.05 | 000000000000082 |  |  |  |  |
| 85 | 1.2.7.5.1 | **PORTAL DE SALIDA** | 36d | 2018-11-12 | 2018-12-18 |  | 191d |  |  |  | 23.26h | 182,420.68 | 01.07.05.01 | 000000000000083 |  |  |  |  |
| 86 | 1.2.7.5.1.1 | BLINDAJE DE ACERO e=1/4" | 2d | 2018-11-12 | 2018-11-14 | 79 | 191d | 0d | start no earlier than 2018-06-11 | BLINDAJE METALICO CON PLANCHA DE ACERO 4.16 x 2.86m e=1/4" [171237%] |  | 21,216.26 | 01.07.05.01.01 | 000000000000084 | 1712.37 | 12.39 | 21216.26 |  |
| 87 | 1.2.7.5.1.2 | VALVULA DE MARIPOSA Ø=0.60 M | 2d | 2018-12-16 | 2018-12-18 | 91 | 191d |  | start no earlier than 2018-06-11 | VALVULA MARIPOSA DE 0.60 m DE DIAMETRO [200%] |  | 62,364.52 | 01.07.05.01.02 | 000000000000085 |  | 31182.26 | 62364.52 |  |
| 88 | 1.2.7.5.1.3 | TUBERIA DE HIERRO DUCTIL Ø=0.60M | 1d | 2018-11-12 | 2018-11-13 | 86SS | 191d | 0d | start no earlier than 2018-06-11 | OPERARIO [90.7%]; PEON [181.3%]; TUBERIA HDPE 300 mm PN 8 [680%]; HERRAMIENTAS MANUALES [50%] | 23.26h | 1,669.89 | 01.07.05.01.03 | 000000000000086 | 6.8 | 245.45 | 1669.06 | 15 |
| 89 | 1.2.7.5.1.4 | TAPA MANHOLE Øint= 0.40 M | 2d | 2018-11-12 | 2018-11-14 | 88SS | 191d | 0d | start no earlier than 2018-06-11 | TAPA MANHOLE D=0.40 M [35775%] |  | 6,138.99 | 01.07.05.01.04 | 000000000000087 | 357.75 | 17.16 | 6138.99 | 25 |
| 90 | 1.2.7.5.1.5 | JUNTA BRIDADA DE DESMONTE Ø=0,60 M | 2d | 2018-11-14 | 2018-11-16 | 89 | 191d | 0d | start no earlier than 2018-06-11 | JUNTA BRIDADA DE DESMONTE ø=0 60 M [200%] |  | 35,084.74 | 01.07.05.01.05 | 000000000000088 |  | 17542.37 | 35084.74 | 25 |
| 91 | 1.2.7.5.1.6 | PANTALLA DE ACERO E=1/4" | 30d | 2018-11-16 | 2018-12-16 | 90 | 191d | 0d | start no earlier than 2018-06-11 | PANTALLA DE ACERO E=1/4" [319693%] |  | 55,946.28 | 01.07.05.01.06 | 000000000000089 | 3196.93 | 17.5 | 55946.28 | 25 |
| 92 | 1.2.7.6 | **TRASLADO Y MONTAJE DE EQUIPOS** | 2d | 2018-11-12 | 2018-11-14 |  | 216d |  |  |  | 134.4h | 5,884.3 | 01.07.06 | 000000000000090 |  |  |  |  |
| 93 | 1.2.7.6.1 | MONTAJE DE EQUIPOS HIDROMECANICOS | 2d | 2018-11-12 | 2018-11-14 | 86SS | 216d | 0d | start no earlier than 2018-06-11 | OPERARIO [400%]; PEON [200%]; MAQUINA SOLDADORA [110%]; CAMION GRUA; SOLDADURA [20000%]; HERRAMIENTAS MANUALES [30%] | 134.4h | 5,884.3 | 01.07.06.01 | 000000000000091 |  | 5884.28 | 5884.28 | 0.5 |
| 94 | 1.2.7.7 | **OBRAS VARIAS** | 13d | 2018-11-10 | 2018-11-23 |  | 216d |  |  |  | 311.66h | 106,978.12 | 01.07.07 | 000000000000092 |  |  |  |  |
| 95 | 1.2.7.7.1 | PUERTA METALICA | 5d | 2018-11-10 | 2018-11-15 | 93FS-4d | 216d | 0d | start no earlier than 2018-06-11 | PUERTA METALICA [25%] | 9.67h | 1,303.71 | 01.07.07.01 | 000000000000093 | 9.67 | 134.82 | 1303.71 |  |
| 96 | 1.2.7.7.2 | VENTANA | 5d | 2018-11-15 | 2018-11-20 | 95 | 216d | 0d | start no earlier than 2018-06-11 | VENTANA [45%] | 17.1h | 1,389.72 | 01.07.07.02 | 000000000000094 | 17.08 | 81.27 | 1388.09 |  |
| 97 | 1.2.7.7.3 | BARRAS DE ANCLAJE Ø =1" (INC. PERFORACION Y GROUTING) | 3d | 2018-11-15 | 2018-11-18 | 96SS | 216d | 0d | start no earlier than 2018-06-11 | OPERARIO [5%]; PEON [7%]; ACERO CORRUGADO fy = 4200 kg/cm2 GRADO 60 [5180%]; HERRAMIENTAS MANUALES [7%] | 4.38h | 259.03 | 01.07.07.03 | 000000000000095 | 51.8 |  | 259 | 250 |
| 98 | 1.2.7.7.4 | ESCALERA DE GATO | 1d | 2018-11-18 | 2018-11-19 | 97 | 216d | 0d | start no earlier than 2018-06-11 | PINTURA ESMALTE SINTETICO [10%]; PINTURA ANTICORROSIVA [10%]; OPERARIO [80%]; PEON [160%]; MAQUINA SOLDADORA [40%]; ACERO 5/8" [2124%]; SOLDADURA [79.2%]; HERRAMIENTAS MANUALES [20%] | 24.47h | 518.98 | 01.07.07.04 | 000000000000096 |  | 129.75 | 519 |  |
| 99 | 1.2.7.7.5 | CONCRETO FC=175 KG/CM2 | 2d | 2018-11-18 | 2018-11-20 | 98SS | 216d | 0d | start no earlier than 2018-06-11 | CEMENTO PORTLAND TIPO IP (42.5 kg) [1836%]; ADITIVO IMPERMEABILIZANTE [30%]; OPERARIO [37%]; OFICIAL [37%]; PEON [38%]; VIBRADOR DE CONCRETO 4 HP 1.25" [20.4%]; MEZCLADORA DE CONCRETO 11 P3 (23 HP) [20.4%]; PIEDRA CHANCADA DE 1/2" Ó 3/4" (D cant.Prom=0.52 km) [200%]; ARENA GRUESA (D cant.prom = 0.52 km) [200%]; AGUA [200%]; HERRAMIENTAS MANUALES [4%] | 30.3h | 972.8 | 01.07.07.05 | 000000000000097 | 2.04 | 476.51 | 972.08 | 10 |
| 100 | 1.2.7.7.6 | JUNTAS DE DILATACION DE CONCRETO | 5d | 2018-11-18 | 2018-11-23 | 99SS | 216d | 0d | start no earlier than 2018-06-11 | PEON [87.5%]; TECKNOPORT e=1" [17499%]; HERRAMIENTAS MANUALES [5%] | 37h | 1,525.81 | 01.07.07.06 | 000000000000098 | 174.99 | 8.72 | 1525.91 | 40 |
| 101 | 1.2.7.7.7 | TUBERIA PVC D=2" | 1d | 2018-11-18 | 2018-11-19 | 100SS | 220d |  | start no earlier than 2018-06-11 | OPERARIO [12%]; PEON [6%]; TUBERIA PVC D=2" [600%]; HERRAMIENTAS MANUALES [2%] | 1.6h | 32.6 | 01.07.07.07 | 000000000000099 |  | 5.36 | 32.16 | 50 |
| 102 | 1.2.7.7.8 | SUMINISTRO E INSTALACION DE PARARRAYOS | 1d | 2018-11-19 | 2018-11-19 | 100SS | 220d |  | start no earlier than 2018-06-11 | OPERARIO; PEON; PARARRAYOS; HERRAMIENTAS MANUALES [4%] | 24.36h | 3,259.92 | 01.07.07.08 | 000000000000100 |  | 3259.98 | 3259.98 |  |
| 103 | 1.2.7.7.9 | SUMIN. E INSTALACION TUBERIA HDPE 600mm | 5d | 2018-11-18 | 2018-11-23 | 100SS | 216d | 0d | start no earlier than 2018-06-11 | OPERARIO [80.5%]; PEON [80.5%]; TUBERIA HDPE 600 mm [16100%]; HERRAMIENTAS MANUALES [11%] | 68.8h | 97,028.36 | 01.07.07.09 | 000000000000101 | 161 | 602.66 | 97028.26 | 40 |
| 104 | 1.2.7.7.10 | CODOS HDPE 11.25° DE 600mm | 1d | 2018-11-18 | 2018-11-19 | 103SS | 219d | 0d | start no earlier than 2018-06-11 | OPERARIO; PEON; CODO HDPE 110 mm PE 100 [200%]; HERRAMIENTAS MANUALES [15%] | 17.1h | 384.42 | 01.07.07.10 | 000000000000102 |  | 192.17 | 384.34 |  |
| 105 | 1.2.7.7.11 | DADOS DE ANCLAJE ( 1.50 X 1.50 X 0.30 ) | 1d | 2018-11-19 | 2018-11-20 | 104 | 219d |  | start no earlier than 2018-06-11 | CEMENTO PORTLAND TIPO IP (42.5 kg) [900%]; ADITIVO IMPERMEABILIZANTE [20%]; OPERARIO [2%]; OFICIAL [2%]; PEON [15%]; VIBRADOR DE CONCRETO 4 HP 1.25" [15%]; MEZCLADORA DE CONCRETO 11 P3 (23 HP) [5.7%]; HERRAMIENTAS MANUALES [2%]; PIEDRA CHANCADA DE 1/2" Ó 3/4" (D cant.Prom=0.52 km); ARENA GRUESA (D cant.prom = 0.52 km); AGUA | 76.88h | 302.77 | 01.07.07.11 | 000000000000103 | 0.68 | 445.03 | 302.62 | 12 |

| ID | WBS | Task | Duration | Start | Finish | Predecessors | Total slack | Free slack | Constraint | Resources | Work | Cost | Text1 | Text8 | Text2 | Text3 | Text4 | Text6 |
| --- | --- | --- | --- | --- | --- | --- | --- | --- | --- | --- | --- | --- | --- | --- | --- | --- | --- | --- |
| 106 | 1.3 | **CANAL TRASVASE** | 174d | 2018-10-04 | 2019-03-27 |  | 0d |  |  |  | 15721.5h | 628,542.19 | 02 | 000000000000104 |  |  |  |  |
| 107 | 1.3.1 | **CANAL DE CONDUCCION** | 112d | 2018-10-04 | 2019-01-24 |  | 0d |  |  |  | 7745.98h | 310,869.11 | 02.01 | 000000000000105 |  |  |  |  |
| 108 | 1.3.1.1 | **TRABAJOS PRELIMINARES** | 7d | 2018-10-04 | 2018-10-11 |  | 0d |  |  |  | 280.51h | 6,594.5 | 02.01.01 | 000000000000106 |  |  |  |  |
| 109 | 1.3.1.1.1 | TRAZO, NIVELACION Y REPLANTEO | 7d | 2018-10-04 | 2018-10-11 | 78 | 0d |  | start no earlier than 2018-06-11 | YESO BOLSA 28 kg [16485%]; ESTACION TOTAL [11.8%]; PEON [282.6%]; MADERA TORNILLO [6594%]; HERRAMIENTAS MANUALES [10%] | 171.25h | 4,945.99 | 02.01.01.01 | 000000000000107 | 3297 | 1.5 | 4945.5 | 500 |
| 110 | 1.3.1.1.2 | DESBROCE Y LIMPIEZA | 7d | 2018-10-04 | 2018-10-11 | 109SS | 0d |  | start no earlier than 2018-06-11 | PEON [188.4%]; HERRAMIENTAS MANUALES [7%] | 109.26h | 1,648.51 | 02.01.01.02 | 000000000000108 | 3297 | 0.5 | 1648.5 | 500 |
| 111 | 1.3.1.2 | **MOVIMIENTO DE TIERRAS** | 105d | 2018-10-11 | 2019-01-24 |  | 0d |  |  |  | 5996.92h | 171,607.27 | 02.01.02 | 000000000000109 |  |  |  |  |
| 112 | 1.3.1.2.1 | EXCAVACION EN MATERIAL SUELTO | 12d | 2018-10-11 | 2018-10-23 | 110 | 0d |  | start no earlier than 2018-06-11 | OFICIAL [7%]; PEON [67%]; EXCAVADORA SOBRE LLANTAS 1.20 M3 [68%]; HERRAMIENTAS MANUALES [4%] | 140.55h | 13,858.74 | 02.01.02.01 | 000000000000110 | 3666.33 | 3.78 | 13858.73 | 450 |
| 113 | 1.3.1.2.2 | EXCAVACION EN ROCA SUELTA | 6d | 2018-10-17 | 2018-10-23 | 112FF | 247d |  | start no earlier than 2018-06-11 | PEON [371.3%]; TRACTOR DE ORUGAS CAT D6D [89.9%]; HERRAMIENTAS MANUALES [5%]; PERFORACIÓN Y DISPARO EN ROCA SUELTA [160000%] | 226.24h | 26,572.58 | 02.01.02.02 | 000000000000111 | 1725.46 | 15.4 | 26572.08 | 320 |
| 114 | 1.3.1.2.3 | EXCAVACION EN ROCA FIJA | 4d | 2018-10-19 | 2018-10-23 | 112FF | 227d | 0d | start no earlier than 2018-06-11 | PEON [416.8%]; TRACTOR DE ORUGAS CAT D6D [96.3%]; HERRAMIENTAS MANUALES [5%]; PERFORACIÓN Y DISPARO EN ROCA FIJA [102100%] | 165.17h | 27,719.26 | 02.01.02.03 | 000000000000112 | 1077.26 | 25.73 | 27717.9 | 280 |
| 115 | 1.3.1.2.4 | RELLENO Y COMPACTADO DE MATERIAL PROPIO | 1d | 2018-10-19 | 2018-10-20 | 112FF-3d | 0d |  | start no earlier than 2018-06-11 | PEON [87.5%]; TRACTOR DE ORUGAS CAT D6D [87.5%]; HERRAMIENTAS MANUALES [8%] | 14.63h | 1,535.36 | 02.01.02.04 | 000000000000113 | 349.8 | 4.39 | 1535.62 | 400 |
| 116 | 1.3.1.2.5 | REFINE Y NIVELACION DE ZANJAS | 45d | 2018-10-20 | 2018-12-04 | 115 | 0d |  | start no earlier than 2018-06-11 | PEON [185%]; HERRAMIENTAS MANUALES [6%] | 691.2h | 10,418.04 | 02.01.02.05 | 000000000000114 | 3297 | 3.16 | 10418.52 | 40 |
| 117 | 1.3.1.2.6 | CAMA DE APOYO (MATERIAL ZARANDEADO) | 30d | 2018-11-21 | 2018-12-21 | 116FS-13d | 0d |  | start no earlier than 2018-06-11 | PEON [137%]; HERRAMIENTAS MANUALES [8%] | 349.5h | 5,209.39 | 02.01.02.06 | 000000000000115 | 164.85 | 31.6 | 5209.26 |  |
| 118 | 1.3.1.2.7 | RELLENO Y COMPACTADO DE MATERIAL SELECCIONADO | 40d | 2018-12-10 | 2019-01-19 | 117FS-11d | 154d | 0d | start no earlier than 2018-06-11 | OPERARIO [40%]; PEON [390%]; COMPACTADORA VIBRATORIA TIPO PLANCHA 7 HP [390%]; HERRAMIENTAS MANUALES [10%] | 2664.16h | 41,344.32 | 02.01.02.07 | 000000000000116 | 1088.01 | 38 | 41344.38 |  |
| 119 | 1.3.1.2.8 | RELLENO DE MATERIAL PROPIO ZARANDEADO | 35d | 2018-12-20 | 2019-01-24 | 118SS+10d | 154d |  | start no earlier than 2018-06-11 | PEON [494%]; HERRAMIENTAS MANUALES [28%] | 1463.8h | 21,879.24 | 02.01.02.08 | 000000000000117 | 692.37 | 31.6 | 21878.89 |  |
| 120 | 1.3.1.2.9 | ELIMINACION DE MATERIAL EXCEDENTE | 20d | 2018-10-23 | 2018-11-12 | 114 | 227d |  | start no earlier than 2018-06-11 | OFICIAL [75%]; CARGADOR FRONTAL 200-250 HP [34%]; CAMION VOLQUETE DE 15 m3 [67%] | 281.66h | 23,070.34 | 02.01.02.09 | 000000000000118 | 6119.52 | 3.77 | 23070.59 | 450 |
| 121 | 1.3.1.3 | **SUMINISTRO DE TUBERIA LINEA DE CONDUCCION** | 15d | 2019-01-04 | 2019-01-19 |  | 159d |  |  |  | 1407.1h | 131,286.41 | 02.01.03 | 000000000000119 |  |  |  |  |
| 122 | 1.3.1.3.1 | SUMIN. E INSTALACION TUBERIA PERFILADA 250 mm | 15d | 2019-01-04 | 2019-01-19 | 118FF | 159d |  | start no earlier than 2018-06-11 | OPERARIO [550%]; PEON [550%]; TUBERIA PERFILADA PVC D=250 mm [329700%]; HERRAMIENTAS MANUALES [65%] | 1407.1h | 131,286.41 | 02.01.03.01 | 000000000000120 | 3297 | 39.82 | 131286.54 | 40 |
| 123 | 1.3.1.4 | **CONCRETO SIMPLE** | 1d | 2018-10-20 | 2018-10-21 |  | 249d |  |  |  | 61.45h | 1,380.93 | 02.01.04 | 000000000000121 |  |  |  |  |
| 124 | 1.3.1.4.1 | CONCRETO CICLOPEO FC=140 KG/CM2 + 70% PM | 1d | 2018-10-20 | 2018-10-21 | 115 | 249d |  | start no earlier than 2018-06-11 | CEMENTO PORTLAND TIPO IP (42.5 kg) [1990%]; ADITIVO IMPERMEABILIZANTE [87%]; OPERARIO [150%]; OFICIAL [117.4%]; PEON [234.6%]; VIBRADOR DE CONCRETO 4 HP 1.25" [53.1%]; MEZCLADORA DE CONCRETO 11 P3 (23 HP) [26.5%]; HERRAMIENTAS MANUALES; PIEDRA CHANCADA DE 1/2" Ó 3/4" (D cant.Prom=0.52 km); ARENA GRUESA (D cant.prom = 0.52 km); AGUA; PIEDRA MEDIANA | 61.45h | 1,380.93 | 02.01.04.01 | 000000000000122 | 3.98 | 346.77 | 1380.14 | 15 |
| 125 | 1.3.2 | **OBRAS DE ARTE** | 96d | 2018-12-21 | 2019-03-27 |  | 0d |  |  |  | 7975.56h | 317,673.08 | 02.02 | 000000000000123 |  |  |  |  |
| 126 | 1.3.2.1 | **BOCATOMA** | 48d | 2018-12-21 | 2019-02-07 |  | 0d |  |  |  | 5048.29h | 172,477.76 | 02.02.01 | 000000000000124 |  |  |  |  |
| 127 | 1.3.2.1.1 | **TRABAJOS PRELIMINARES** | 2d | 2018-12-21 | 2018-12-23 |  | 0d |  |  |  | 11.15h | 318.11 | 02.02.01.01 | 000000000000125 |  |  |  |  |
| 128 | 1.3.2.1.1.1 | DESBROCE Y LIMPIEZA | 1d | 2018-12-21 | 2018-12-22 | 117 | 0d |  | start no earlier than 2018-06-11 | PEON [64.2%]; HERRAMIENTAS MANUALES [6%] | 5.34h | 80.39 | 02.02.01.01.01 | 000000000000126 | 160.5 | 0.5 | 80.25 | 1000 |
| 129 | 1.3.2.1.1.2 | TRAZO, NIVELES Y REPLANTEO | 1d | 2018-12-22 | 2018-12-23 | 128 | 0d |  | start no earlier than 2018-06-11 | YESO BOLSA 28 kg [802.5%]; ESTACION TOTAL [8%]; PEON [64.2%]; MADERA TORNILLO [321%]; HERRAMIENTAS MANUALES [1%] | 5.82h | 237.73 | 02.02.01.01.02 | 000000000000127 | 160.5 | 1.48 | 237.54 | 250 |

| ID | WBS | Task | Duration | Start | Finish | Predecessors | Total slack | Free slack | Constraint | Resources | Work | Cost | Text1 | Text8 | Text2 | Text3 | Text4 | Text6 |
| --- | --- | --- | --- | --- | --- | --- | --- | --- | --- | --- | --- | --- | --- | --- | --- | --- | --- | --- |
| 130 | 1.3.2.1.2 | **MOVIMIENTO DE TIERRAS** | 6d | 2018-12-24 | 2018-12-29 |  | 0d |  |  |  | 123.09h | 5,584.08 | 02.02.01.02 | 000000000000128 |  |  |  |  |
| 131 | 1.3.2.1.2.1 | EXCAVACION EN MATERIAL SUELTO | 1d | 2018-12-24 | 2018-12-24 | 129 | 0d |  | start no earlier than 2018-06-11 | OFICIAL [9.1%]; PEON [90.3%]; EXCAVADORA SOBRE LLANTAS 1.20 M3 [90.3%]; HERRAMIENTAS MANUALES [1%] | 15.53h | 1,534.39 | 02.02.01.02.01 | 000000000000129 | 405.92 | 3.78 | 1534.38 | 450 |
| 132 | 1.3.2.1.2.2 | RELLENO ENROCADO RIP - RAP | 3d | 2018-12-24 | 2018-12-27 | 131 | 182d | 0d | start no earlier than 2018-06-11 | PERFORACIÓN Y DISPARO EN ROCA FIJA [2500%]; ACOMODO DE ENROCADO [2500%]; SELECCIÓN Y CARGUÍO DE CANTERA [2500%]; TRANSPORTE DE ROCA D MENOR 1Km [2400%]; TRANSPORTE DE ROCA D MENOR IGUAL 1Km [2200%] |  | 931.11 | 02.02.01.02.02 | 000000000000130 | 25.15 | 37.13 | 933.82 | 2.5 |
| 133 | 1.3.2.1.2.3 | RELLENO GRANULAR | 1d | 2018-12-24 | 2018-12-25 | 132SS | 184d |  | start no earlier than 2018-06-11 | CARGUIO [495%]; TRANSPORTE MATERIAL FINO PARA D MENOR A 1KM [495%]; TRANSPORTE MATERIAL FINO PARA D MAYOR IGUAL A 1KM [495%]; ZARANDEO DE MATERIAL DE CANTERA GRAVA D max=500mm [495%]; EXTRACCION EN CANTERA Y APILAMIENTO [495%] |  | 83.85 | 02.02.01.02.03 | 000000000000131 | 4.95 | 16.94 | 83.85 |  |
| 134 | 1.3.2.1.2.4 | COMPACTACION DE TERRENO | 4d | 2018-12-24 | 2018-12-28 | 131 | 0d |  | start no earlier than 2018-06-11 | OPERARIO [89.2%]; PEON [89.2%]; COMPACTADORA VIBRATORIA TIPO PLANCHA 7 HP [89.2%]; HERRAMIENTAS MANUALES [12%] | 89.51h | 1,505.13 | 02.02.01.02.04 | 000000000000132 | 160.5 | 9.38 | 1505.49 | 45 |
| 135 | 1.3.2.1.2.5 | ELIMINACION DE MATERIAL EXCEDENTE | 1d | 2018-12-28 | 2018-12-29 | 134 | 180d |  | start no earlier than 2018-06-11 | OFICIAL [90.3%]; CARGADOR FRONTAL 200-250 HP [45.2%]; CAMION VOLQUETE DE 15 m3 [90.3%] | 18.05h | 1,529.6 | 02.02.01.02.05 | 000000000000133 | 405.92 | 3.77 | 1530.32 | 450 |
| 136 | 1.3.2.1.3 | **CONCRETO SIMPLE** | 21d | 2018-12-28 | 2019-01-18 |  | 0d |  |  |  | 1355.56h | 38,757.06 | 02.02.01.03 | 000000000000134 |  |  |  |  |
| 137 | 1.3.2.1.3.1 | CONCRETO CICLOPEO FC=175 KG/CM2 + 30% PM | 6d | 2019-01-12 | 2019-01-18 | 138 | 0d |  | start no earlier than 2018-06-11 | CEMENTO PORTLAND TIPO IP (42.5 kg) [48539.3%]; ADITIVO IMPERMEABILIZANTE [1645.4%]; OPERARIO [360%]; OFICIAL [380%]; PEON [775%]; VIBRADOR DE CONCRETO 4 HP 1.25" [182.8%]; MEZCLADORA DE CONCRETO 11 P3 (23 HP) [91.4%]; PIEDRA CHANCADA DE 1/2" Ó 3/4" (D cant.Prom=0.52 km) [4100%]; ARENA GRUESA (D cant.prom = 0.52 km) [2900%]; AGUA [1500%]; PIEDRA MEDIANA [2400%]; HERRAMIENTAS MANUALES [23%] | 864.43h | 27,753.74 | 02.02.01.03.01 | 000000000000135 | 82.27 | 337.35 | 27753.78 | 15 |
| 138 | 1.3.2.1.3.2 | ENCOFRADO Y DESENCOFRADO | 15d | 2018-12-28 | 2019-01-12 | 134 | 0d |  | start no earlier than 2018-06-11 | OPERARIO [96.2%]; OFICIAL [96.2%]; PEON [192.4%]; ALAMBRE NEGRO N° 8 [2163.9%]; CLAVOS 2" - 4" [3245.8%]; MADERA NACIONAL P/ENCOFRADO-CARP [49012.3%]; TRIPLAY DE 1.20X2.40 m X 18 mm [541%]; HERRAMIENTAS MANUALES [25%] | 491.12h | 11,003.33 | 02.02.01.03.02 | 000000000000136 | 216.39 | 50.85 | 11003.43 | 15 |
| 139 | 1.3.2.1.4 | **CONCRETO ARMADO** | 39d | 2018-12-28 | 2019-02-05 |  | 140d |  |  |  | 3054.64h | 105,842.58 | 02.02.01.04 | 000000000000137 |  |  |  |  |
| 140 | 1.3.2.1.4.1 | SOLADO DE CONCRETO FC=100 KG/CM2 | 1d | 2018-12-28 | 2018-12-29 | 134 | 140d | 0d | start no earlier than 2018-06-11 | CEMENTO PORTLAND TIPO IP (42.5 kg) [2322%]; OPERARIO [104%]; OFICIAL; PEON [300%]; VIBRADOR DE CONCRETO 4 HP 1.25" [48.4%]; MEZCLADORA DE CONCRETO 11 P3 (23 HP) [48.4%]; PIEDRA CHANCADA DE 1/2" Ó 3/4" (D cant.Prom=0.52 km) [630%]; ARENA GRUESA (D cant.prom = 0.52 km) [390%]; AGUA; HERRAMIENTAS MANUALES [20%] | 47.5h | 1,602.59 | 02.02.01.04.01 | 000000000000138 | 7.74 | 207.06 | 1602.64 | 16 |
| 141 | 1.3.2.1.4.2 | ACERO DE REFUERZO GRADO 60 | 29d | 2018-12-29 | 2019-01-27 | 140 | 140d | 0d | start no earlier than 2018-06-11 | OPERARIO [99%]; PEON [99%]; ACERO CORRUGADO fy = 4200 kg/cm2 GRADO 60 [721032%]; HERRAMIENTAS MANUALES [13%] | 488.01h | 36,051.68 | 02.02.01.04.02 | 000000000000139 | 7210.32 |  | 36051.6 | 250 |
| 142 | 1.3.2.1.4.3 | ENCOFRADO Y DESENCOFRADO | 30d | 2019-01-02 | 2019-02-01 | 141FS-25d | 140d | 0d | start no earlier than 2018-06-11 | OPERARIO [140%]; OFICIAL [130%]; PEON [250%]; ALAMBRE NEGRO N° 8 [5791.1%]; CLAVOS 2" - 4" [8686.6%]; MADERA NACIONAL P/ENCOFRADO-CARP [131168%]; TRIPLAY DE 1.20X2.40 m X 18 mm [1447.8%]; HERRAMIENTAS MANUALES [37%] | 1315.23h | 29,447.76 | 02.02.01.04.03 | 000000000000140 | 579.11 | 50.85 | 29447.74 | 15 |
| 143 | 1.3.2.1.4.4 | CONCRETO FC=175 KG/CM2 | 4d | 2019-02-01 | 2019-02-05 | 142 | 140d | 0d | start no earlier than 2018-06-11 | CEMENTO PORTLAND TIPO IP (42.5 kg) [73170%]; ADITIVO IMPERMEABILIZANTE [1626%]; OPERARIO [380%]; OFICIAL [900%]; PEON [1800%]; VIBRADOR DE CONCRETO 4 HP 1.25" [90.3%]; MEZCLADORA DE CONCRETO 11 P3 (23 HP) [90.3%]; PIEDRA CHANCADA DE 1/2" Ó 3/4" (D cant.Prom=0.52 km) [6500%]; ARENA GRUESA (D cant.prom = 0.52 km) [6000%]; AGUA [2500%]; HERRAMIENTAS MANUALES [500%] | 1203.9h | 38,740.55 | 02.02.01.04.04 | 000000000000141 | 81.3 | 476.51 | 38740.26 | 10 |
| 144 | 1.3.2.1.5 | **CARPINTERIA METALICA** | 1d | 2019-02-01 | 2019-02-02 |  | 140d |  |  |  | 42.65h | 5,811.14 | 02.02.01.05 | 000000000000142 |  |  |  |  |
| 145 | 1.3.2.1.5.1 | COMPUERTA CANAL DE LIMPIA DE 1.00 x 0.75 ,h=2.10 M, C/VOLANTE | 1d | 2019-02-01 | 2019-02-02 | 143SS | 140d | 0d | start no earlier than 2018-06-11 | OPERARIO; PEON [200%]; COMPUERTA METALICA 0.26x0.30 h=1.90 M C/VOLANTE YMARCO; HERRAMIENTAS MANUALES [20%] | 25.55h | 2,968.73 | 02.02.01.05.01 | 000000000000143 |  | 2968.74 | 2968.74 |  |
| 146 | 1.3.2.1.5.2 | COMPUERTA DE V. CAPTACION DE 0.40 x 0.35 , h= 1.90 M, C/VOLANTE | 1d | 2019-02-01 | 2019-02-02 | 145SS | 140d | 0d | start no earlier than 2018-06-11 | OPERARIO; PEON; COMPUERTA METALICA DE 0.40 x 0.35 h= 1.90 M C/VOLANTE; HERRAMIENTAS MANUALES [20%] | 17.1h | 2,842.41 | 02.02.01.05.02 | 000000000000144 |  | 2842.34 | 2842.34 |  |
| 147 | 1.3.2.1.6 | **OBRAS VARIAS** | 5d | 2019-02-02 | 2019-02-07 |  | 140d |  |  |  | 461.2h | 16,164.78 | 02.02.01.06 | 000000000000145 |  |  |  |  |
| 148 | 1.3.2.1.6.1 | BARANDA METALICA F°G°, Ø=2" | 5d | 2019-02-02 | 2019-02-07 | 146 | 140d |  | start no earlier than 2018-06-11 | PINTURA ESMALTE SINTETICO [1441.9%]; PINTURA ANTICORROSIVA [1441.9%]; OPERARIO [400%]; PEON [420%]; MAQUINA SOLDADORA [285%]; SOLDADURA [9012%]; TUBERIA DE FIERRO GALVANIZADO DE 2" [18024%]; TUBERIA DE FIERRO GALVANIZADO DE 1½" [18024%]; HERRAMIENTAS MANUALES [50%] | 438.3h | 15,041.22 | 02.02.01.06.01 | 000000000000146 | 180.24 | 83.45 | 15041.03 | 10 |
| 149 | 1.3.2.1.6.2 | JUNTA WATER STOP DE 4" | 2d | 2019-02-04 | 2019-02-05 | 143FF | 142d |  | start no earlier than 2018-06-11 | OPERARIO [70%]; PEON [70%]; WATER STOP 4" [5600%]; HERRAMIENTAS MANUALES [6%] | 22.9h | 1,123.55 | 02.02.01.06.02 | 000000000000147 | 56 | 20.06 | 1123.36 | 40 |
| 150 | 1.3.2.2 | **DESARENADOR** | 10d | 2019-01-18 | 2019-01-28 |  | 0d |  |  |  | 442.2h | 16,420.38 | 02.02.02 | 000000000000148 |  |  |  |  |
| 151 | 1.3.2.2.1 | EXCAVACION EN ROCA SUELTA | 1d | 2019-01-18 | 2019-01-19 | 137 | 0d |  | start no earlier than 2018-06-11 | PEON [14%]; TRACTOR DE ORUGAS CAT D6D [6.7%]; HERRAMIENTAS MANUALES [1%]; PERFORACIÓN Y DISPARO EN ROCA SUELTA [2165%] | 1.57h | 331.23 | 02.02.02.01 | 000000000000149 | 21.5 | 15.4 | 331.1 | 320 |
| 152 | 1.3.2.2.2 | ELIMINACION DE MATERIAL EXCEDENTE | 1d | 2019-01-19 | 2019-01-20 | 151 | 158d |  | start no earlier than 2018-06-11 | OFICIAL [4.8%]; CARGADOR FRONTAL 200-250 HP [2.4%]; CAMION VOLQUETE DE 15 m3 [4.8%] | 0.96h | 81.12 | 02.02.02.02 | 000000000000150 | 21.5 | 3.77 | 81.06 | 450 |
| 153 | 1.3.2.2.3 | SOLADO DE CONCRETO FC=100 KG/CM2 | 1d | 2019-01-19 | 2019-01-20 | 151 | 0d |  | start no earlier than 2018-06-11 | CEMENTO PORTLAND TIPO IP (42.5 kg) [1353%]; OPERARIO [50%]; OFICIAL [55%]; PEON [180%]; VIBRADOR DE CONCRETO 4 HP 1.25" [28.2%]; MEZCLADORA DE CONCRETO 11 P3 (23 HP) [28.2%]; HERRAMIENTAS MANUALES [6%]; PIEDRA CHANCADA DE 1/2" Ó 3/4" (D cant.Prom=0.52 km) [400%]; ARENA GRUESA (D cant.prom = 0.52 km) [200%]; AGUA | 27.79h | 933.62 | 02.02.02.03 | 000000000000151 | 4.51 | 207.06 | 933.84 | 16 |
| 154 | 1.3.2.2.4 | CONCRETO FC=175 KG/CM2 | 2d | 2019-01-26 | 2019-01-28 | 156 | 150d | 0d | start no earlier than 2018-06-11 | CEMENTO PORTLAND TIPO IP (42.5 kg) [10530%]; ADITIVO IMPERMEABILIZANTE [234%]; OPERARIO [110%]; OFICIAL [235%]; PEON [600%]; VIBRADOR DE CONCRETO 4 HP 1.25" [58.5%]; MEZCLADORA DE CONCRETO 11 P3 (23 HP) [58.5%]; PIEDRA CHANCADA DE 1/2" Ó 3/4" (D cant.Prom=0.52 km) [800%]; ARENA GRUESA (D cant.prom = 0.52 km) [500%]; AGUA [400%]; HERRAMIENTAS MANUALES [98%] | 185.92h | 5,575.42 | 02.02.02.04 | 000000000000152 | 11.7 | 476.51 | 5575.17 | 10 |
| 155 | 1.3.2.2.5 | ENCOFRADO Y DESENCOFRADO | 4d | 2019-01-20 | 2019-01-24 | 153 | 0d |  | start no earlier than 2018-06-11 | OPERARIO [98.1%]; OFICIAL [98.1%]; PEON [196.2%]; ALAMBRE NEGRO N° 8 [588.7%]; CLAVOS 2" - 4" [883%]; MADERA NACIONAL P/ENCOFRADO-CARP [13334.1%]; TRIPLAY DE 1.20X2.40 m X 18 mm [147.2%]; HERRAMIENTAS MANUALES [30%] | 134.35h | 2,993.57 | 02.02.02.05 | 000000000000153 | 58.87 | 50.85 | 2993.54 | 15 |
| 156 | 1.3.2.2.6 | ACERO DE REFUERZO GRADO 60 | 2d | 2019-01-24 | 2019-01-26 | 155 | 150d | 0d | start no earlier than 2018-06-11 | OPERARIO [94.7%]; PEON [94.7%]; ACERO CORRUGADO fy = 4200 kg/cm2 GRADO 60 [47332%]; HERRAMIENTAS MANUALES [10%] | 31.84h | 2,366.47 | 02.02.02.06 | 000000000000154 | 473.32 |  | 2366.6 | 250 |
| 157 | 1.3.2.2.7 | JUNTA WATER STOP DE 6" | 1d | 2019-01-28 | 2019-01-28 | 154FF | 150d |  | start no earlier than 2018-06-11 | OPERARIO [1.6%]; PEON [1.6%]; WATER STOP 6" [160%]; HERRAMIENTAS MANUALES [1%] | 0.28h | 28.81 | 02.02.02.07 | 000000000000155 | 1.6 | 18 | 28.8 | 100 |
| 158 | 1.3.2.2.8 | COMPUERTA METALICA DE 0.50 x 0.40 , h=1.31 M, C/VOLANTE | 1d | 2019-01-24 | 2019-01-25 | 155 | 0d |  | start no earlier than 2018-06-11 | OPERARIO; PEON; COMPUERTA METALICA DE 0.50x0.40 h=1.30M C/VOLANTE YMARCO; HERRAMIENTAS MANUALES [1%] | 17h | 2,841.25 | 02.02.02.08 | 000000000000156 |  | 2841.98 | 2841.98 |  |
| 159 | 1.3.2.2.9 | TARJETA METALICA PLANCHA DE 1.50 X 0.40 M e=1/4" | 1d | 2019-01-25 | 2019-01-26 | 158 | 0d |  | start no earlier than 2018-06-11 | OPERARIO; PEON; TARJETA METALICA 1.50 x 0.40 M e=1/4"; HERRAMIENTAS MANUALES [13%] | 17.09h | 511.46 | 02.02.02.09 | 000000000000157 |  | 511.47 | 511.47 |  |
| 160 | 1.3.2.2.10 | ESCALERA DE GATO 1/2" | 1d | 2019-01-26 | 2019-01-27 | 159 | 0d |  | start no earlier than 2018-06-11 | PINTURA ESMALTE SINTETICO [6%]; PINTURA ANTICORROSIVA [6%]; OPERARIO [24%]; OFICIAL [24%]; PEON [24%]; MAQUINA SOLDADORA [24%]; SOLDADURA [47.5%]; TUBERIA DE FIERRO GALVANIZADO DE 1/2" [240%]; HERRAMIENTAS MANUALES [5%] | 8.32h | 161.21 | 02.02.02.10 | 000000000000158 | 2.4 | 67.18 | 161.23 | 10 |
| 161 | 1.3.2.2.11 | REJILLA METALICA 0.80 x 0.80 M | 1d | 2019-01-27 | 2019-01-28 | 160 | 0d |  | start no earlier than 2018-06-11 | OPERARIO; PEON; REJILLA METALICA 0.80 x 0.80m; HERRAMIENTAS MANUALES [10%] | 17.09h | 596.21 | 02.02.02.11 | 000000000000159 |  | 596.22 | 596.22 |  |

| ID | WBS | Task | Duration | Start | Finish | Predecessors | Total slack | Free slack | Constraint | Resources | Work | Cost | Text1 | Text8 | Text2 | Text3 | Text4 | Text6 |
| --- | --- | --- | --- | --- | --- | --- | --- | --- | --- | --- | --- | --- | --- | --- | --- | --- | --- | --- |
| 162 | 1.3.2.3 | **SIFON** | 39d | 2019-01-28 | 2019-03-08 |  | 0d |  |  |  | 1535.33h | 100,607.34 | 02.02.03 | 000000000000160 |  |  |  |  |
| 163 | 1.3.2.3.1 | **MOVIMIENTO DE TIERRAS** | 2d | 2019-01-28 | 2019-01-30 |  | 0d |  |  |  | 2.38h | 216.95 | 02.02.03.01 | 000000000000161 |  |  |  |  |
| 164 | 1.3.2.3.1.1 | EXCAVACION EN MATERIAL SUELTO | 1d | 2019-01-28 | 2019-01-29 | 161 | 0d |  | start no earlier than 2018-06-11 | OFICIAL [0.6%]; PEON [6.4%]; EXCAVADORA SOBRE LLANTAS 1.20 M3 [6.4%]; HERRAMIENTAS MANUALES [1%] | 1.1h | 108.6 | 02.02.03.01.01 | 000000000000162 | 28.72 | 3.78 | 108.56 | 450 |
| 165 | 1.3.2.3.1.2 | ELIMINACION DE MATERIAL EXCEDENTE | 1d | 2019-01-29 | 2019-01-30 | 164 | 148d |  | start no earlier than 2018-06-11 | OFICIAL [6.4%]; CARGADOR FRONTAL 200-250 HP [3.2%]; CAMION VOLQUETE DE 15 m3 [6.4%] | 1.28h | 108.35 | 02.02.03.01.02 | 000000000000163 | 28.72 | 3.77 | 108.27 | 450 |
| 166 | 1.3.2.3.2 | **CAMARA DE INGRESO A SIFON** | 20d | 2019-01-29 | 2019-02-18 |  | 0d |  |  |  | 496.72h | 22,865.94 | 02.02.03.02 | 000000000000164 |  |  |  |  |
| 167 | 1.3.2.3.2.1 | SOLADO DE CONCRETO FC=100 KG/CM2 | 1d | 2019-01-29 | 2019-01-30 | 164 | 0d |  | start no earlier than 2018-06-11 | CEMENTO PORTLAND TIPO IP (42.5 kg) [348%]; OPERARIO [14%]; OFICIAL [13%]; PEON [45%]; VIBRADOR DE CONCRETO 4 HP 1.25" [7.2%]; MEZCLADORA DE CONCRETO 11 P3 (23 HP) [7.2%]; PIEDRA CHANCADA DE 1/2" Ó 3/4" (D cant.Prom=0.52 km); ARENA GRUESA (D cant.prom = 0.52 km); AGUA; HERRAMIENTAS MANUALES [1%] | 4.66h | 240.43 | 02.02.03.02.01 | 000000000000165 | 1.16 | 207.06 | 240.19 | 16 |
| 168 | 1.3.2.3.2.2 | CONCRETO FC=210 KG/CM2 | 1d | 2019-02-17 | 2019-02-18 | 169 | 111d | 0d | start no earlier than 2018-06-11 | CEMENTO PORTLAND TIPO IP (42.5 kg) [7095%]; ADITIVO IMPERMEABILIZANTE [129%]; OPERARIO [261%]; OFICIAL [262%]; PEON [676.3%]; VIBRADOR DE CONCRETO 4 HP 1.25" [129%]; MEZCLADORA DE CONCRETO 11 P3 (23 HP) [64.5%]; HERRAMIENTAS MANUALES [4%]; PIEDRA CHANCADA DE 1/2" Ó 3/4" (D cant.Prom=0.52 km) [500%]; ARENA GRUESA (D cant.prom = 0.52 km) [300%]; AGUA | 112.29h | 3,574.81 | 02.02.03.02.02 | 000000000000166 | 6.45 | 554.24 | 3574.85 | 10 |
| 169 | 1.3.2.3.2.3 | CONCRETO FC=175 KG/CM2 | 1d | 2019-02-16 | 2019-02-17 | 170 | 111d | 0d | start no earlier than 2018-06-11 | CEMENTO PORTLAND TIPO IP (42.5 kg) [1584%]; ADITIVO IMPERMEABILIZANTE [35.2%]; OPERARIO [34%]; OFICIAL [71.8%]; PEON [182%]; VIBRADOR DE CONCRETO 4 HP 1.25" [17.6%]; MEZCLADORA DE CONCRETO 11 P3 (23 HP) [17.6%]; PIEDRA CHANCADA DE 1/2" Ó 3/4" (D cant.Prom=0.52 km); ARENA GRUESA (D cant.prom = 0.52 km); AGUA; HERRAMIENTAS MANUALES [5%] | 26.02h | 838.65 | 02.02.03.02.03 | 000000000000167 | 1.76 | 476.51 | 838.66 | 10 |
| 170 | 1.3.2.3.2.4 | CONCRETO FC=140 KG/CM2 | 1d | 2019-02-15 | 2019-02-16 | 171 | 111d | 0d | start no earlier than 2018-06-11 | CEMENTO PORTLAND TIPO IP (42.5 kg) [1660%]; ADITIVO IMPERMEABILIZANTE [64%]; OPERARIO [50%]; OFICIAL [80%]; PEON [189%]; VIBRADOR DE CONCRETO 4 HP 1.25" [22%]; MEZCLADORA DE CONCRETO 11 P3 (23 HP) [22%]; HERRAMIENTAS MANUALES [10%]; PIEDRA CHANCADA DE 1/2" Ó 3/4" (D cant.Prom=0.52 km) [300%]; ARENA GRUESA (D cant.prom = 0.52 km); AGUA | 35.04h | 971.69 | 02.02.03.02.04 | 000000000000168 | 3.32 | 292.69 | 971.73 | 15 |
| 171 | 1.3.2.3.2.5 | CONCRETO CICLOPEO FC=140 KG/CM2 + 30% PM | 1d | 2019-02-14 | 2019-02-15 | 172 | 111d | 0d | start no earlier than 2018-06-11 | CEMENTO PORTLAND TIPO IP (42.5 kg) [1340%]; ADITIVO IMPERMEABILIZANTE [60%]; OPERARIO [65%]; OFICIAL [60%]; PEON [110%]; VIBRADOR DE CONCRETO 4 HP 1.25" [29.8%]; MEZCLADORA DE CONCRETO 11 P3 (23 HP) [14.9%]; PIEDRA CHANCADA DE 1/2" Ó 3/4" (D cant.Prom=0.52 km); ARENA GRUESA (D cant.prom = 0.52 km); AGUA; PIEDRA MEDIANA; HERRAMIENTAS MANUALES | 27.23h | 779.35 | 02.02.03.02.05 | 000000000000169 | 2.68 | 290.82 | 779.4 | 18 |
| 172 | 1.3.2.3.2.6 | ENCOFRADO Y DESENCOFRADO | 3d | 2019-02-11 | 2019-02-14 | 173 | 0d |  | start no earlier than 2018-06-11 | OPERARIO [98%]; OFICIAL [98%]; PEON [196%]; ALAMBRE NEGRO N° 8 [441%]; CLAVOS 2" - 4" [661.5%]; MADERA NACIONAL P/ENCOFRADO-CARP [9988.6%]; TRIPLAY DE 1.20X2.40 m X 18 mm [110.2%]; HERRAMIENTAS MANUALES [25%] | 100.08h | 2,242.37 | 02.02.03.02.06 | 000000000000170 | 44.1 | 50.85 | 2242.49 | 15 |
| 173 | 1.3.2.3.2.7 | ACERO DE REFUERZO GRADO 60 | 12d | 2019-01-30 | 2019-02-11 | 167 | 0d |  | start no earlier than 2018-06-11 | OPERARIO [94.8%]; PEON [94.8%]; ACERO CORRUGADO fy = 4200 kg/cm2 GRADO 60 [284375%]; HERRAMIENTAS MANUALES [10%] | 191.4h | 14,218.65 | 02.02.03.02.07 | 000000000000171 | 2843.75 |  | 14218.75 | 250 |
| 174 | 1.3.2.3.3 | **CAMARA DE SALIDA DEL SIFON** | 5d | 2019-02-18 | 2019-02-23 |  | 111d |  |  |  | 188.68h | 5,256.33 | 02.02.03.03 | 000000000000172 |  |  |  |  |
| 175 | 1.3.2.3.3.1 | SOLADO DE CONCRETO FC=100 KG/CM2 | 1d | 2019-02-18 | 2019-02-19 | 168 | 111d | 0d | start no earlier than 2018-06-11 | CEMENTO PORTLAND TIPO IP (42.5 kg) [291%]; OPERARIO [7%]; OFICIAL [5%]; PEON [15%]; VIBRADOR DE CONCRETO 4 HP 1.25" [6.1%]; MEZCLADORA DE CONCRETO 11 P3 (23 HP) [6.1%]; HERRAMIENTAS MANUALES [1%]; PIEDRA CHANCADA DE 1/2" Ó 3/4" (D cant.Prom=0.52 km); ARENA GRUESA (D cant.prom = 0.52 km); AGUA | 3.23h | 200.07 | 02.02.03.03.01 | 000000000000173 | 0.97 | 207.06 | 200.85 | 16 |
| 176 | 1.3.2.3.3.2 | CONCRETO FC=210 KG/CM2 | 1d | 2019-02-22 | 2019-02-23 | 177 | 111d | 0d | start no earlier than 2018-06-11 | CEMENTO PORTLAND TIPO IP (42.5 kg) [6116%]; ADITIVO IMPERMEABILIZANTE [111.2%]; OPERARIO [225%]; OFICIAL [226.8%]; PEON [583%]; VIBRADOR DE CONCRETO 4 HP 1.25" [111.2%]; MEZCLADORA DE CONCRETO 11 P3 (23 HP) [55.6%]; HERRAMIENTAS MANUALES [4%]; PIEDRA CHANCADA DE 1/2" Ó 3/4" (D cant.Prom=0.52 km) [400%]; ARENA GRUESA (D cant.prom = 0.52 km) [200%]; AGUA [200%] | 97.29h | 3,081.22 | 02.02.03.03.02 | 000000000000174 | 5.56 | 554.24 | 3081.57 | 10 |
| 177 | 1.3.2.3.3.3 | ENCOFRADO Y DESENCOFRADO | 3d | 2019-02-19 | 2019-02-22 | 175 | 111d | 0d | start no earlier than 2018-06-11 | OPERARIO [86.3%]; OFICIAL [86.3%]; PEON [172.6%]; ALAMBRE NEGRO N° 8 [388.4%]; CLAVOS 2" - 4" [582.6%]; MADERA NACIONAL P/ENCOFRADO-CARP [8797.3%]; TRIPLAY DE 1.20X2.40 m X 18 mm [97.1%]; HERRAMIENTAS MANUALES [20%] | 88.16h | 1,975.04 | 02.02.03.03.03 | 000000000000175 | 38.84 | 50.85 | 1975.01 | 15 |
| 178 | 1.3.2.3.4 | **DADOS DE ANCLAJE** | 5d | 2019-02-23 | 2019-02-28 |  | 111d |  |  |  | 517.31h | 15,747.15 | 02.02.03.04 | 000000000000176 |  |  |  |  |
| 179 | 1.3.2.3.4.1 | SOLADO DE CONCRETO FC=100 KG/CM2 | 1d | 2019-02-23 | 2019-02-24 | 176 | 111d | 0d | start no earlier than 2018-06-11 | CEMENTO PORTLAND TIPO IP (42.5 kg) [615%]; OPERARIO [26%]; OFICIAL [26%]; PEON [83%]; VIBRADOR DE CONCRETO 4 HP 1.25" [12.8%]; MEZCLADORA DE CONCRETO 11 P3 (23 HP) [12.8%]; PIEDRA CHANCADA DE 1/2" Ó 3/4" (D cant.Prom=0.52 km); ARENA GRUESA (D cant.prom = 0.52 km); AGUA; HERRAMIENTAS MANUALES [1%] | 12.96h | 424.12 | 02.02.03.04.01 | 000000000000177 | 2.05 | 207.06 | 424.47 | 16 |
| 180 | 1.3.2.3.4.2 | CONCRETO FC=210 KG/CM2 | 3d | 2019-02-25 | 2019-02-28 | 181 | 111d | 0d | start no earlier than 2018-06-11 | CEMENTO PORTLAND TIPO IP (42.5 kg) [29172%]; ADITIVO IMPERMEABILIZANTE [530.4%]; OPERARIO [363.6%]; OFICIAL [360.6%]; PEON [926.9%]; VIBRADOR DE CONCRETO 4 HP 1.25" [176.8%]; MEZCLADORA DE CONCRETO 11 P3 (23 HP) [88.4%]; HERRAMIENTAS MANUALES [60%]; PIEDRA CHANCADA DE 1/2" Ó 3/4" (D cant.Prom=0.52 km) [1800%]; ARENA GRUESA (D cant.prom = 0.52 km) [1000%]; AGUA [500%] | 476.48h | 14,698.63 | 02.02.03.04.02 | 000000000000178 | 26.52 | 554.24 | 14698.44 | 10 |
| 181 | 1.3.2.3.4.3 | ENCOFRADO Y DESENCOFRADO | 1d | 2019-02-24 | 2019-02-25 | 179 | 111d | 0d | start no earlier than 2018-06-11 | OPERARIO [81.9%]; OFICIAL [81.9%]; PEON [163.7%]; ALAMBRE NEGRO N° 8 [122.8%]; CLAVOS 2" - 4" [184.2%]; MADERA NACIONAL P/ENCOFRADO-CARP [2781.4%]; TRIPLAY DE 1.20X2.40 m X 18 mm [30.7%]; HERRAMIENTAS MANUALES [20%] | 27.87h | 624.4 | 02.02.03.04.03 | 000000000000179 | 12.28 | 50.85 | 624.44 | 15 |
| 182 | 1.3.2.3.5 | **TUBERIA** | 8d | 2019-02-28 | 2019-03-08 |  | 111d |  |  |  | 139.32h | 50,245.58 | 02.02.03.05 | 000000000000180 |  |  |  |  |
| 183 | 1.3.2.3.5.1 | SUMIN. E INSTALACION TUBERIA HDPE 300 mm PN 8 | 8d | 2019-02-28 | 2019-03-08 | 180 | 111d |  | start no earlier than 2018-06-11 | OPERARIO [73%]; PEON [145%]; TUBERIA HDPE 300 mm PN 8 [25360%] | 139.32h | 50,245.58 | 02.02.03.05.01 | 000000000000181 | 253.6 | 198.13 | 50245.77 | 45 |
| 184 | 1.3.2.3.6 | **VARIOS** | 13d | 2019-02-14 | 2019-02-27 |  | 0d |  |  |  | 190.92h | 6,275.39 | 02.02.03.06 | 000000000000182 |  |  |  |  |
| 185 | 1.3.2.3.6.1 | JUNTA WATER STOP DE 6" | 1d | 2019-02-14 | 2019-02-15 | 172 | 0d |  | start no earlier than 2018-06-11 | OPERARIO [7.8%]; PEON [7.8%]; WATER STOP 6" [780%]; HERRAMIENTAS MANUALES [1%] | 1.34h | 140.41 | 02.02.03.06.01 | 000000000000183 | 7.8 | 18 | 140.4 | 100 |
| 186 | 1.3.2.3.6.2 | REJILLA METALICA 1.20 X 1.20 M | 1d | 2019-02-15 | 2019-02-16 | 185 | 0d |  | start no earlier than 2018-06-11 | OPERARIO; PEON; REJILLA METALICA 1.20m X 1.20m e=1.5 cm; HERRAMIENTAS MANUALES [15%] | 17.1h | 511.54 | 02.02.03.06.02 | 000000000000184 |  | 511.47 | 511.47 |  |
| 187 | 1.3.2.3.6.3 | BARANDA METALICA F°G°, Ø=2" | 5d | 2019-02-16 | 2019-02-21 | 186 | 0d |  | start no earlier than 2018-06-11 | PINTURA ESMALTE SINTETICO [396%]; PINTURA ANTICORROSIVA [396%]; OPERARIO [70%]; PEON [60%]; MAQUINA SOLDADORA [217.5%]; SOLDADURA [2475%]; TUBERIA DE FIERRO GALVANIZADO DE 2" [4950%]; TUBERIA DE FIERRO GALVANIZADO DE 1½" [4950%]; HERRAMIENTAS MANUALES [10%] | 142.91h | 4,130.53 | 02.02.03.06.03 | 000000000000185 | 49.5 | 83.45 | 4130.78 | 10 |
| 188 | 1.3.2.3.6.4 | TUBERIA PVC D=2" | 1d | 2019-02-21 | 2019-02-22 | 187 | 0d |  | start no earlier than 2018-06-11 | OPERARIO [3.6%]; PEON [1.8%]; TUBERIA PVC D=2" [180%]; HERRAMIENTAS MANUALES [1%] | 0.47h | 9.69 | 02.02.03.06.04 | 000000000000186 | 1.8 | 5.36 | 9.65 | 50 |
| 189 | 1.3.2.3.6.5 | CODOS DE PVC DE 2" | 1d | 2019-02-22 | 2019-02-23 | 188 | 0d |  | start no earlier than 2018-06-11 | OPERARIO [8%]; PEON [4%]; CODO PVC 2" [200%]; HERRAMIENTAS MANUALES [1%] | 1.02h | 27.32 | 02.02.03.06.05 | 000000000000187 |  | 13.7 | 27.4 | 25 |
| 190 | 1.3.2.3.6.6 | TAPA METALICA 1.00 x 1.00 e=3/8" | 1d | 2019-02-23 | 2019-02-24 | 189 | 0d |  | start no earlier than 2018-06-11 | OPERARIO; PEON; TAPA METALICA 1.00 X 1.00 m e=3/8"; HERRAMIENTAS MANUALES [13%] | 17.09h | 553.84 | 02.02.03.06.06 | 000000000000188 |  | 553.85 | 553.85 |  |
| 191 | 1.3.2.3.6.7 | SUMIN. E INSTALACION TUBERIA HDPE 110 mm PE 100 | 1d | 2019-02-24 | 2019-02-25 | 190 | 0d |  | start no earlier than 2018-06-11 | OPERARIO [10.4%]; PEON [10.4%]; TUBERIA HDPE 110 mm PE 100 [470%]; HERRAMIENTAS MANUALES [1%] | 1.76h | 316.54 | 02.02.03.06.07 | 000000000000189 | 4.7 | 67.39 | 316.73 | 45 |
| 192 | 1.3.2.3.6.8 | VALVULA COMPUERTA DN 110 mm | 1d | 2019-02-25 | 2019-02-26 | 191 | 0d |  | start no earlier than 2018-06-11 | OPERARIO [50%]; PEON [50%]; VALVULA COMPUERTA DN 110 mm; HERRAMIENTAS MANUALES [8%] | 8.55h | 531.2 | 02.02.03.06.08 | 000000000000190 |  | 531.16 | 531.16 |  |
| 193 | 1.3.2.3.6.9 | CODOS HDPE 110 mm PE 100 | 1d | 2019-02-26 | 2019-02-27 | 192 | 0d |  | start no earlier than 2018-06-11 | OPERARIO [4%]; PEON [4%]; CODO HDPE 110 mm PE 100; HERRAMIENTAS MANUALES [1%] | 0.68h | 54.33 | 02.02.03.06.09 | 000000000000191 |  | 54.36 | 54.36 | 25 |

| ID | WBS | Task | Duration | Start | Finish | Predecessors | Total slack | Free slack | Constraint | Resources | Work | Cost | Text1 | Text8 | Text2 | Text3 | Text4 | Text6 |
| --- | --- | --- | --- | --- | --- | --- | --- | --- | --- | --- | --- | --- | --- | --- | --- | --- | --- | --- |
| 194 | 1.3.2.4 | **CAJA DE INSPECCION (08 UND)** | 28d | 2019-02-27 | 2019-03-27 |  | 0d |  |  |  | 949.73h | 28,167.61 | 02.02.04 | 000000000000192 |  |  |  |  |
| 195 | 1.3.2.4.1 | **MOVIMIENTO DE TIERRAS** | 2d | 2019-02-27 | 2019-03-01 |  | 0d |  |  |  | 7h | 963.19 | 02.02.04.01 | 000000000000193 |  |  |  |  |
| 196 | 1.3.2.4.1.1 | EXCAVACION EN ROCA SUELTA | 1d | 2019-02-27 | 2019-02-28 | 193 | 0d |  | start no earlier than 2018-06-11 | PEON [41%]; TRACTOR DE ORUGAS CAT D6D [15.4%]; HERRAMIENTAS MANUALES [1%]; PERFORACIÓN Y DISPARO EN ROCA SUELTA [4800%] | 4.59h | 758.83 | 02.02.04.01.01 | 000000000000194 | 49.25 | 15.4 | 758.45 | 320 |
| 197 | 1.3.2.4.1.2 | ELIMINACION DE MATERIAL EXCEDENTE | 1d | 2019-02-28 | 2019-03-01 | 196 | 118d |  | start no earlier than 2018-06-11 | OFICIAL [12.1%]; CARGADOR FRONTAL 200-250 HP [6%]; CAMION VOLQUETE DE 15 m3 [12.1%] | 2.41h | 204.36 | 02.02.04.01.02 | 000000000000195 | 54.17 | 3.77 | 204.22 | 450 |
| 198 | 1.3.2.4.2 | **CONCRETO SIMPLE** | 1d | 2019-02-28 | 2019-03-01 |  | 0d |  |  |  | 18.67h | 536.82 | 02.02.04.02 | 000000000000196 |  |  |  |  |
| 199 | 1.3.2.4.2.1 | SOLADO DE CONCRETO FC=100 KG/CM2 | 1d | 2019-02-28 | 2019-03-01 | 196 | 0d |  | start no earlier than 2018-06-11 | CEMENTO PORTLAND TIPO IP (42.5 kg) [777%]; OPERARIO [35.3%]; OFICIAL [34.4%]; PEON [109.8%]; VIBRADOR DE CONCRETO 4 HP 1.25" [16.2%]; MEZCLADORA DE CONCRETO 11 P3 (23 HP) [16.2%]; HERRAMIENTAS MANUALES [25%]; PIEDRA CHANCADA DE 1/2" Ó 3/4" (D cant.Prom=0.52 km); ARENA GRUESA (D cant.prom = 0.52 km); AGUA | 18.67h | 536.82 | 02.02.04.02.01 | 000000000000197 | 2.59 | 207.06 | 536.29 | 16 |
| 200 | 1.3.2.4.3 | **CONCRETO ARMADO** | 24d | 2019-03-01 | 2019-03-25 |  | 0d |  |  |  | 872.29h | 25,528.53 | 02.02.04.03 | 000000000000198 |  |  |  |  |
| 201 | 1.3.2.4.3.1 | CONCRETO FC=175 KG/CM2 | 3d | 2019-03-22 | 2019-03-25 | 202 | 92d | 0d | start no earlier than 2018-06-11 | CEMENTO PORTLAND TIPO IP (42.5 kg) [18459%]; ADITIVO IMPERMEABILIZANTE [410.2%]; OPERARIO [144.5%]; OFICIAL [278.9%]; PEON [716.7%]; VIBRADOR DE CONCRETO 4 HP 1.25" [68.4%]; MEZCLADORA DE CONCRETO 11 P3 (23 HP) [68.4%]; PIEDRA CHANCADA DE 1/2" Ó 3/4" (D cant.Prom=0.52 km) [1400%]; ARENA GRUESA (D cant.prom = 0.52 km) [1000%]; AGUA [300%]; HERRAMIENTAS MANUALES [50%] | 317.89h | 9,773.28 | 02.02.04.03.01 | 000000000000199 | 20.51 | 476.51 | 9773.22 | 10 |
| 202 | 1.3.2.4.3.2 | ENCOFRADO Y DESENCOFRADO | 15d | 2019-03-07 | 2019-03-22 | 203 | 0d |  | start no earlier than 2018-06-11 | OPERARIO [94.5%]; OFICIAL [94.5%]; PEON [189%]; ALAMBRE NEGRO N° 8 [2126.4%]; CLAVOS 2" - 4" [3189.6%]; MADERA NACIONAL P/ENCOFRADO-CARP [48163%]; TRIPLAY DE 1.20X2.40 m X 18 mm [531.6%]; HERRAMIENTAS MANUALES [10%] | 482.62h | 10,812.74 | 02.02.04.03.02 | 000000000000200 | 212.64 | 50.85 | 10812.74 | 15 |
| 203 | 1.3.2.4.3.3 | ACERO DE REFUERZO GRADO 60 | 6d | 2019-03-01 | 2019-03-07 | 199 | 0d |  | start no earlier than 2018-06-11 | OPERARIO [58%]; PEON [68%]; ACERO CORRUGADO fy = 4200 kg/cm2 GRADO 60 [98851%]; HERRAMIENTAS MANUALES [24%] | 71.78h | 4,942.52 | 02.02.04.03.03 | 000000000000201 | 988.51 |  | 4942.55 | 250 |
| 204 | 1.3.2.4.4 | **VARIOS** | 6d | 2019-03-21 | 2019-03-27 |  | 0d |  |  |  | 51.76h | 1,139.06 | 02.02.04.04 | 000000000000202 |  |  |  |  |
| 205 | 1.3.2.4.4.1 | ESCALERA DE GATO 3/4" | 2d | 2019-03-25 | 2019-03-27 | 201 | 92d |  | start no earlier than 2018-06-11 | PINTURA ESMALTE SINTETICO [49.8%]; PINTURA ANTICORROSIVA [49.8%]; OPERARIO [66.4%]; OFICIAL [66.4%]; PEON [66.4%]; MAQUINA SOLDADORA [66.4%]; SOLDADURA [394.4%]; TUBERIA DE FIERRO GALVANIZADO DE 3/4" [1992%]; HERRAMIENTAS MANUALES [23%] | 46.06h | 1,005.27 | 02.02.04.04.01 | 000000000000203 | 19.92 | 50.46 | 1005.16 | 15 |
| 206 | 1.3.2.4.4.2 | TUBERIA PVC DE 2" | 1d | 2019-03-21 | 2019-03-22 | 202FF | 0d |  | start no earlier than 2018-06-11 | OPERARIO [8%]; PEON [8%]; TUBERIA PVC D=2" [200%]; HERRAMIENTAS MANUALES [1%] | 1.37h | 25.25 | 02.02.04.04.02 | 000000000000204 |  | 12.62 | 25.24 | 25 |
| 207 | 1.3.2.4.4.3 | CODOS DE PVC DE 2" | 1d | 2019-03-22 | 2019-03-23 | 206 | 0d |  | start no earlier than 2018-06-11 | OPERARIO [24%]; PEON [12%]; CODO PVC 2" [600%]; HERRAMIENTAS MANUALES [1%] | 2.97h | 81.24 | 02.02.04.04.03 | 000000000000205 |  | 13.7 | 82.2 | 25 |
| 208 | 1.3.2.4.4.4 | TUBERIA PVC D=1/2" | 1d | 2019-03-23 | 2019-03-24 | 207 | 0d |  | start no earlier than 2018-06-11 | OPERARIO [8%]; PEON [8%]; TUBERIA PVC D=1/2" [640%]; HERRAMIENTAS MANUALES [1%] | 1.36h | 27.3 | 02.02.04.04.04 | 000000000000206 | 6.4 | 4.27 | 27.33 | 80 |
| 209 | 1.4 | **CANAL DE APROXIMACION** | 43d | 2019-03-24 | 2019-05-06 |  | 0d |  |  |  | 2662.79h | 97,006.86 | 03 | 000000000000207 |  |  |  |  |
| 210 | 1.4.1 | **CANAL DE CONDUCCION** | 17d | 2019-03-24 | 2019-04-10 |  | 0d |  |  |  | 1781.26h | 65,798.3 | 03.01 | 000000000000208 |  |  |  |  |
| 211 | 1.4.1.1 | **TRABAJOS PRELIMINARES** | 2d | 2019-03-24 | 2019-03-26 |  | 0d |  |  |  | 34.68h | 521.1 | 03.01.01 | 000000000000209 |  |  |  |  |
| 212 | 1.4.1.1.1 | TRAZO, NIVELACION Y REPLANTEO | 1d | 2019-03-24 | 2019-03-25 | 208 | 0d |  | start no earlier than 2018-06-11 | YESO BOLSA 28 kg [1303%]; ESTACION TOTAL [6.5%]; PEON [156.4%]; MADERA TORNILLO [521.2%]; HERRAMIENTAS MANUALES [1%] | 26.05h | 390.85 | 03.01.01.01 | 000000000000210 | 260.6 | 1.5 | 390.9 | 500 |
| 213 | 1.4.1.1.2 | DESBROCE Y LIMPIEZA | 1d | 2019-03-25 | 2019-03-26 | 212 | 0d |  | start no earlier than 2018-06-11 | PEON [104.2%]; HERRAMIENTAS MANUALES [2%] | 8.63h | 130.24 | 03.01.01.02 | 000000000000211 | 260.6 | 0.5 | 130.3 | 500 |
| 214 | 1.4.1.2 | **MOVIMIENTO DE TIERRAS** | 9d | 2019-03-26 | 2019-04-04 |  | 0d |  |  |  | 378.82h | 11,728.1 | 03.01.02 | 000000000000212 |  |  |  |  |
| 215 | 1.4.1.2.1 | EXCAVACION EN MATERIAL SUELTO | 1d | 2019-03-26 | 2019-03-27 | 213 | 0d |  | start no earlier than 2018-06-11 | OFICIAL [2.4%]; PEON [24.2%]; EXCAVADORA SOBRE LLANTAS 1.20 M3 [24.2%]; HERRAMIENTAS MANUALES [1%] | 4.14h | 410.55 | 03.01.02.01 | 000000000000213 | 108.64 | 3.78 | 410.66 | 450 |
| 216 | 1.4.1.2.2 | EXCAVACION EN ROCA SUELTA | 1d | 2019-03-26 | 2019-03-27 | 215FF | 92d |  | start no earlier than 2018-06-11 | PEON [187%]; TRACTOR DE ORUGAS CAT D6D [45.3%]; HERRAMIENTAS MANUALES [1%]; PERFORACIÓN Y DISPARO EN ROCA SUELTA [13300%] | 18.65h | 2,229.95 | 03.01.02.02 | 000000000000214 | 144.85 | 15.4 | 2230.69 | 320 |
| 217 | 1.4.1.2.3 | EXCAVACION EN ROCA FIJA | 1d | 2019-03-26 | 2019-03-27 | 215FF | 0d |  | start no earlier than 2018-06-11 | PEON [168.1%]; TRACTOR DE ORUGAS CAT D6D [38.8%]; HERRAMIENTAS MANUALES [1%]; PERFORACIÓN Y DISPARO EN ROCA FIJA [10300%] | 16.62h | 2,795.75 | 03.01.02.03 | 000000000000215 | 108.64 | 25.73 | 2795.31 | 280 |
| 218 | 1.4.1.2.4 | RELLENO Y COMPACTADO DE MATERIAL PROPIO | 1d | 2019-03-27 | 2019-03-28 | 217 | 0d |  | start no earlier than 2018-06-11 | PEON [0.5%]; TRACTOR DE ORUGAS CAT D6D [0.5%]; HERRAMIENTAS MANUALES [1%] | 0.11h | 9.52 | 03.01.02.04 | 000000000000216 | 2.14 | 4.39 | 9.39 | 400 |
| 219 | 1.4.1.2.5 | REFINE Y NIVELACION DE ZANJAS | 3d | 2019-03-28 | 2019-03-31 | 218 | 84d | 0d | start no earlier than 2018-06-11 | PEON [218%]; HERRAMIENTAS MANUALES [12%] | 55.05h | 823.62 | 03.01.02.05 | 000000000000217 | 260.6 | 3.16 | 823.5 | 40 |
| 220 | 1.4.1.2.6 | CAMA DE APOYO (MATERIAL ZARANDEADO) | 3d | 2019-03-28 | 2019-03-31 | 219FS-3d | 84d | 0d | start no earlier than 2018-06-11 | PEON [73.2%]; HERRAMIENTAS MANUALES [4%] | 18.54h | 277.36 | 03.01.02.06 | 000000000000218 | 8.79 | 31.6 | 277.76 |  |
| 221 | 1.4.1.2.7 | RELLENO Y COMPACTADO DE MATERIAL SELECCIONADO | 7d | 2019-03-28 | 2019-04-04 | 220FS-3d | 84d | 0d | start no earlier than 2018-06-11 | OPERARIO [18%]; PEON [165%]; COMPACTADORA VIBRATORIA TIPO PLANCHA 7 HP [167%]; HERRAMIENTAS MANUALES [9%] | 201.38h | 3,102.26 | 03.01.02.07 | 000000000000219 | 81.64 | 38 | 3102.32 |  |
| 222 | 1.4.1.2.8 | RELLENO DE MATERIAL PROPIO ZARANDEADO | 6d | 2019-03-28 | 2019-04-03 | 221SS | 84d | 0d | start no earlier than 2018-06-11 | PEON [95.2%]; HERRAMIENTAS MANUALES [6%] | 48.32h | 722.14 | 03.01.02.08 | 000000000000220 | 22.86 | 31.6 | 722.38 |  |
| 223 | 1.4.1.2.9 | ELIMINACION DE MATERIAL EXCEDENTE | 1d | 2019-04-03 | 2019-04-04 | 222 | 84d |  | start no earlier than 2018-06-11 | OFICIAL [80.1%]; CARGADOR FRONTAL 200-250 HP [40%]; CAMION VOLQUETE DE 15 m3 [80.1%] | 16.01h | 1,356.95 | 03.01.02.09 | 000000000000221 | 359.98 | 3.77 | 1357.12 | 450 |

| ID | WBS | Task | Duration | Start | Finish | Predecessors | Total slack | Constraint | Resources | Work | Cost | Text1 | Text8 | Text2 | Text3 | Text4 | Text6 |
| --- | --- | --- | --- | --- | --- | --- | --- | --- | --- | --- | --- | --- | --- | --- | --- | --- | --- |
| 224 | 1.4.1.3 | **SUMINISTRO DE TUBERIA LINEA DE CONDUCCION** | 4d | 2019-04-01 | 2019-04-04 |  | 84d |  |  | 53.66h | 12,696.88 | 03.01.03 | 000000000000222 |  |  |  |  |
| 225 | 1.4.1.3.1 | SUMIN. E INSTALACION TUBERIA PERFILADA 350 mm | 4d | 2019-04-01 | 2019-04-04 | 221FF | 84d | start no earlier than 2018-06-11 | OPERARIO [78.5%]; PEON [78.5%]; TUBERIA PERFILADA PVC D=350 mm [12560%]; HERRAMIENTAS MANUALES [11%] | 53.66h | 12,696.88 | 03.01.03.01 | 000000000000223 | 125.6 | 101.09 | 12696.9 | 40 |
| 226 | 1.4.1.4 | **CONCRETO** | 13d | 2019-03-28 | 2019-04-10 |  | 0d |  |  | 1314.1h | 40,852.22 | 03.01.04 | 000000000000224 |  |  |  |  |
| 227 | 1.4.1.4.1 | SOLADO DE CONCRETO FC=100 KG/CM2 | 1d | 2019-03-28 | 2019-03-29 | 218 | 0d | start no earlier than 2018-06-11 | CEMENTO PORTLAND TIPO IP (42.5 kg) [3645%]; OPERARIO [165.6%]; OFICIAL [161.5%]; PEON [515.1%]; VIBRADOR DE CONCRETO 4 HP 1.25" [75.9%]; MEZCLADORA DE CONCRETO 11 P3 (23 HP) [75.9%]; HERRAMIENTAS MANUALES [10%]; PIEDRA CHANCADA DE 1/2" Ó 3/4" (D cant.Prom=0.52 km) [800%]; ARENA GRUESA (D cant.prom = 0.52 km) [500%]; AGUA [200%] | 81.03h | 2,515.73 | 03.01.04.01 | 000000000000225 | 12.15 | 207.06 | 2515.78 | 16 |
| 228 | 1.4.1.4.2 | CONCRETO FC=175 KG/CM2 | 3d | 2019-04-07 | 2019-04-10 | 229 | 0d | start no earlier than 2018-06-11 | CEMENTO PORTLAND TIPO IP (42.5 kg) [30987%]; ADITIVO IMPERMEABILIZANTE [688.6%]; OPERARIO [227%]; OFICIAL [470%]; PEON [1150%]; VIBRADOR DE CONCRETO 4 HP 1.25" [86.1%]; MEZCLADORA DE CONCRETO 11 P3 (23 HP) [86.1%]; PIEDRA CHANCADA DE 1/2" Ó 3/4" (D cant.Prom=0.52 km) [2500%]; ARENA GRUESA (D cant.prom = 0.52 km) [1800%]; AGUA [945%]; HERRAMIENTAS MANUALES [200%] | 532.6h | 16,403.52 | 03.01.04.02 | 000000000000226 | 34.43 | 476.51 | 16406.24 | 10 |
| 229 | 1.4.1.4.3 | ENCOFRADO Y DESENCOFRADO | 8d | 2019-03-30 | 2019-04-07 | 230FS-7d | 0d | start no earlier than 2018-06-11 | OPERARIO [210%]; OFICIAL [220%]; PEON [425%]; ALAMBRE NEGRO N° 8 [2565%]; CLAVOS 2" - 4" [3847.5%]; MADERA NACIONAL P/ENCOFRADO-CARP [58097.2%]; TRIPLAY DE 1.20X2.40 m X 18 mm [641.2%]; HERRAMIENTAS MANUALES [50%] | 580.69h | 13,043.05 | 03.01.04.03 | 000000000000227 | 256.5 | 50.85 | 13043.03 | 15 |
| 230 | 1.4.1.4.4 | ACERO DE REFUERZO GRADO 60 | 8d | 2019-03-29 | 2019-04-06 | 227 | 0d | start no earlier than 2018-06-11 | OPERARIO [88.9%]; PEON [88.9%]; ACERO CORRUGADO fy = 4200 kg/cm2 GRADO 60 [177780%]; HERRAMIENTAS MANUALES [25%] | 119.78h | 8,889.92 | 03.01.04.04 | 000000000000228 | 1777.8 |  | 8889 | 250 |
| 231 | 1.4.2 | **OBRAS DE ARTE** | 26d | 2019-04-10 | 2019-05-06 |  | 0d |  |  | 881.53h | 31,208.56 | 03.02 | 000000000000229 |  |  |  |  |
| 232 | 1.4.2.1 | **DESARENADOR** | 19d | 2019-04-10 | 2019-04-29 |  | 0d |  |  | 705.44h | 26,230.18 | 03.02.01 | 000000000000230 |  |  |  |  |
| 233 | 1.4.2.1.1 | EXCAVACION EN ROCA SUELTA | 1d | 2019-04-10 | 2019-04-11 | 228 | 0d | start no earlier than 2018-06-11 | PEON [35%]; TRACTOR DE ORUGAS CAT D6D [13.2%]; HERRAMIENTAS MANUALES [1%]; PERFORACIÓN Y DISPARO EN ROCA SUELTA [4100%] | 4.03h | 650.54 | 03.02.01.01 | 000000000000231 | 42.25 | 15.4 | 650.65 | 320 |
| 234 | 1.4.2.1.2 | ELIMINACION DE MATERIAL EXCEDENTE | 1d | 2019-04-11 | 2019-04-12 | 233 | 76d | start no earlier than 2018-06-11 | OFICIAL [9.4%]; CARGADOR FRONTAL 200-250 HP [4.7%]; CAMION VOLQUETE DE 15 m3 [9.4%] | 1.88h | 159.4 | 03.02.01.02 | 000000000000232 | 42.25 | 3.77 | 159.28 | 450 |
| 235 | 1.4.2.1.3 | SOLADO DE CONCRETO FC=100 KG/CM2 | 1d | 2019-04-11 | 2019-04-12 | 233 | 0d | start no earlier than 2018-06-11 | CEMENTO PORTLAND TIPO IP (42.5 kg) [1695%]; OPERARIO [77%]; OFICIAL [75.1%]; PEON [211%]; VIBRADOR DE CONCRETO 4 HP 1.25" [35.3%]; MEZCLADORA DE CONCRETO 11 P3 (23 HP) [35.3%]; HERRAMIENTAS MANUALES [10%]; PIEDRA CHANCADA DE 1/2" Ó 3/4" (D cant.Prom=0.52 km) [400%]; ARENA GRUESA (D cant.prom = 0.52 km) [300%]; AGUA | 35.12h | 1,169.65 | 03.02.01.03 | 000000000000233 | 5.65 | 207.06 | 1169.89 | 16 |
| 236 | 1.4.2.1.4 | CONCRETO CICLOPEO FC=175 KG/CM2 + 30% PM | 1d | 2019-04-24 | 2019-04-25 | 237FF | 63d | start no earlier than 2018-06-11 | CEMENTO PORTLAND TIPO IP (42.5 kg) [1274.4%]; ADITIVO IMPERMEABILIZANTE [43.2%]; OPERARIO [59.3%]; OFICIAL [60.7%]; PEON [123.5%]; VIBRADOR DE CONCRETO 4 HP 1.25" [28.8%]; MEZCLADORA DE CONCRETO 11 P3 (23 HP) [14.4%]; HERRAMIENTAS MANUALES [1%]; PIEDRA CHANCADA DE 1/2" Ó 3/4" (D cant.Prom=0.52 km); ARENA GRUESA (D cant.prom = 0.52 km) [77%]; AGUA [40%]; PIEDRA MEDIANA [60%] | 22.79h | 728.42 | 03.02.01.04 | 000000000000234 | 2.16 | 337.35 | 728.68 | 15 |
| 237 | 1.4.2.1.5 | CONCRETO FC=175 KG/CM2 | 2d | 2019-04-23 | 2019-04-25 | 238 | 0d | start no earlier than 2018-06-11 | CEMENTO PORTLAND TIPO IP (42.5 kg) [17703%]; ADITIVO IMPERMEABILIZANTE [393.4%]; OPERARIO [205%]; OFICIAL [395%]; PEON [1000%]; VIBRADOR DE CONCRETO 4 HP 1.25" [98.3%]; MEZCLADORA DE CONCRETO 11 P3 (23 HP) [98.3%]; HERRAMIENTAS MANUALES; PIEDRA CHANCADA DE 1/2" Ó 3/4" (D cant.Prom=0.52 km) [1416%]; ARENA GRUESA (D cant.prom = 0.52 km) [1000%]; AGUA [374%] | 303.97h | 9,372.52 | 03.02.01.05 | 000000000000235 | 19.67 | 476.51 | 9372.95 | 10 |
| 238 | 1.4.2.1.6 | ENCOFRADO Y DESENCOFRADO | 8d | 2019-04-15 | 2019-04-23 | 239 | 0d | start no earlier than 2018-06-11 | OPERARIO [90.1%]; OFICIAL [90.1%]; PEON [180.2%]; ALAMBRE NEGRO N° 8 [1081.2%]; CLAVOS 2" - 4" [1621.8%]; MADERA NACIONAL P/ENCOFRADO-CARP [24489.2%]; TRIPLAY DE 1.20X2.40 m X 18 mm [270.3%]; HERRAMIENTAS MANUALES [50%] | 245.35h | 5,497.54 | 03.02.01.06 | 000000000000236 | 108.12 | 50.85 | 5497.9 | 15 |
| 239 | 1.4.2.1.7 | ACERO DE REFUERZO GRADO 60 | 3d | 2019-04-12 | 2019-04-15 | 235 | 0d | start no earlier than 2018-06-11 | OPERARIO [97.6%]; PEON [97.6%]; ACERO CORRUGADO fy = 4200 kg/cm2 GRADO 60 [73229%]; HERRAMIENTAS MANUALES [25%] | 49.26h | 3,661.18 | 03.02.01.07 | 000000000000237 | 732.29 |  | 3661.45 | 250 |
| 240 | 1.4.2.1.8 | JUNTA WATER STOP DE 6" | 1d | 2019-04-22 | 2019-04-23 | 238FF | 65d | start no earlier than 2018-06-11 | OPERARIO [1.6%]; PEON [1.6%]; WATER STOP 6" [160%]; HERRAMIENTAS MANUALES [1%] | 0.28h | 28.81 | 03.02.01.08 | 000000000000238 | 1.6 | 18 | 28.8 | 100 |
| 241 | 1.4.2.1.9 | COMPUERTA METALICA DE 0.50 x 0.46 , h=2.30 M, C/VOLANTE | 1d | 2019-04-25 | 2019-04-26 | 237 | 0d | start no earlier than 2018-06-11 | OPERARIO; PEON; COMPUERTA METALICA DE 0.50 x 0.46 h=2.30 M C/VOLANTE; HERRAMIENTAS MANUALES [4%] | 17h | 2,841.25 | 03.02.01.09 | 000000000000239 |  | 2841.98 | 2841.98 |  |
| 242 | 1.4.2.1.10 | TARJETA METALICA PLANCHA DE 0.80 X 0.50 M e=1/4" | 1d | 2019-04-26 | 2019-04-27 | 241 | 0d | start no earlier than 2018-06-11 | OPERARIO [0.4%]; PEON [0.4%]; TARJETA METALICA 0.80 X 0.50 M e=1/4" [300%]; HERRAMIENTAS MANUALES [1%] | 0.08h | 1,272.51 | 03.02.01.10 | 000000000000240 |  | 1272.36 | 1272.36 | 250 |
| 243 | 1.4.2.1.11 | ESCALERA DE GATO 1/2" | 1d | 2019-04-27 | 2019-04-28 | 242 | 0d | start no earlier than 2018-06-11 | PINTURA ESMALTE SINTETICO [6.2%]; PINTURA ANTICORROSIVA [6.2%]; OPERARIO [25%]; OFICIAL [25%]; PEON [25%]; MAQUINA SOLDADORA [25%]; SOLDADURA [49.5%]; TUBERIA DE FIERRO GALVANIZADO DE 1/2" [250%]; HERRAMIENTAS MANUALES [10%] | 8.65h | 167.79 | 03.02.01.11 | 000000000000241 | 2.5 | 67.18 | 167.95 | 10 |
| 244 | 1.4.2.1.12 | REJILLA METALICA 1.00 x 0.85 M | 1d | 2019-04-28 | 2019-04-29 | 243 | 0d | start no earlier than 2018-06-11 | OPERARIO; PEON; REJILLA METALICA 1.00 x 0.85 M; HERRAMIENTAS MANUALES [13%] | 17.04h | 680.56 | 03.02.01.12 | 000000000000242 |  | 680.97 | 680.97 |  |
| 245 | 1.4.2.2 | **CAMARA DE DISTRIBUCION (01 UND)** | 7d | 2019-04-29 | 2019-05-06 |  | 0d |  |  | 176.09h | 4,978.38 | 03.02.02 | 000000000000243 |  |  |  |  |
| 246 | 1.4.2.2.1 | **MOVIMIENTO DE TIERRAS** | 7d | 2019-04-29 | 2019-05-06 |  | 0d |  |  | 24.39h | 390.34 | 03.02.02.01 | 000000000000244 |  |  |  |  |
| 247 | 1.4.2.2.1.1 | EXCAVACION EN ROCA SUELTA | 1d | 2019-04-29 | 2019-04-30 | 244 | 0d | start no earlier than 2018-06-11 | PEON [1.2%]; TRACTOR DE ORUGAS CAT D6D [0.3%]; HERRAMIENTAS MANUALES [1%]; PERFORACIÓN Y DISPARO EN ROCA SUELTA [76%] | 0.2h | 13.89 | 03.02.02.01.01 | 000000000000245 | 0.9 | 15.4 | 13.86 | 320 |
| 248 | 1.4.2.2.1.2 | ELIMINACION DE MATERIAL EXCEDENTE | 1d | 2019-04-30 | 2019-05-01 | 247 | 57d | start no earlier than 2018-06-11 | OFICIAL [0.2%]; CARGADOR FRONTAL 200-250 HP [0.1%]; CAMION VOLQUETE DE 15 m3 [0.2%] | 0.04h | 3.73 | 03.02.02.01.02 | 000000000000246 | 0.99 | 3.77 | 3.73 | 450 |
| 249 | 1.4.2.2.1.3 | RELLENO Y COMPACTADO DE MATERIAL SELECCIONADO | 1d | 2019-05-06 | 2019-05-06 | 254 | 52d | start no earlier than 2018-06-11 | OPERARIO [15%]; PEON [150%]; COMPACTADORA VIBRATORIA TIPO PLANCHA 7 HP [130%]; HERRAMIENTAS MANUALES [10%] | 24.15h | 372.72 | 03.02.02.01.03 | 000000000000247 | 9.8 | 38 | 372.4 |  |

| ID | WBS | Task | Duration | Start | Finish | Predecessors | Total slack | Free slack | Constraint | Resources | Work | Cost | Text1 | Text8 | Text2 | Text3 | Text4 | Text6 |
| --- | --- | --- | --- | --- | --- | --- | --- | --- | --- | --- | --- | --- | --- | --- | --- | --- | --- | --- |
| 250 | 1.4.2.2.2 | **CONCRETO SIMPLE** | 1d | 2019-04-30 | 2019-05-01 |  | 0d |  |  |  | 4.17h | 135.58 | 03.02.02.02 | 000000000000248 |  |  |  |  |
| 251 | 1.4.2.2.2.1 | SOLADO DE CONCRETO FC=100 KG/CM2 | 1d | 2019-04-30 | 2019-05-01 | 247 | 0d |  | start no earlier than 2018-06-11 | CEMENTO PORTLAND TIPO IP (42.5 kg) [180%]; OPERARIO [8.2%]; OFICIAL [8%]; PEON [25.4%]; VIBRADOR DE CONCRETO 4 HP 1.25" [3.8%]; MEZCLADORA DE CONCRETO 11 P3 (23 HP) [3.8%]; PIEDRA CHANCADA DE 1/2" Ó 3/4" (D cant.Prom=0.52 km) [40%]; ARENA GRUESA (D cant.prom = 0.52 km) [28%]; AGUA [12%]; HERRAMIENTAS MANUALES [1%] | 3.86h | 124.35 | 03.02.02.02.01 | 000000000000249 | 0.6 | 207.06 | 124.24 | 16 |
| 252 | 1.4.2.2.2.2 | CONCRETO FC=100 KG/CM2 | 1d | 2019-04-30 | 2019-05-01 | 251SS | 57d |  | start no earlier than 2018-06-11 | CEMENTO PORTLAND TIPO IP (42.5 kg) [18%]; OPERARIO [0.7%]; OFICIAL [0.6%]; PEON [2.1%]; VIBRADOR DE CONCRETO 4 HP 1.25" [0.3%]; MEZCLADORA DE CONCRETO 11 P3 (23 HP) [0.3%]; PIEDRA CHANCADA DE 1/2" Ó 3/4" (D cant.Prom=0.52 km) [4%]; ARENA GRUESA (D cant.prom = 0.52 km) [3%]; AGUA [1%]; HERRAMIENTAS MANUALES [1%] | 0.31h | 11.23 | 03.02.02.02.02 | 000000000000250 | 0.06 | 187.65 | 11.26 | 20 |
| 253 | 1.4.2.2.3 | **CONCRETO ARMADO** | 4d | 2019-05-01 | 2019-05-05 |  | 0d |  |  |  | 127.44h | 3,772.92 | 03.02.02.03 | 000000000000251 |  |  |  |  |
| 254 | 1.4.2.2.3.1 | CONCRETO FC=175 KG/CM2 | 1d | 2019-05-04 | 2019-05-05 | 256 | 52d | 0d | start no earlier than 2018-06-11 | CEMENTO PORTLAND TIPO IP (42.5 kg) [2979%]; ADITIVO IMPERMEABILIZANTE [66.2%]; OPERARIO [68%]; OFICIAL [134%]; PEON [343%]; VIBRADOR DE CONCRETO 4 HP 1.25" [33.1%]; MEZCLADORA DE CONCRETO 11 P3 (23 HP) [33.1%]; PIEDRA CHANCADA DE 1/2" Ó 3/4" (D cant.Prom=0.52 km) [238%]; ARENA GRUESA (D cant.prom = 0.52 km) [167%]; AGUA [63%]; HERRAMIENTAS MANUALES [25%] | 50.9h | 1,577.41 | 03.02.02.03.01 | 000000000000252 | 3.31 | 476.51 | 1577.25 | 10 |
| 255 | 1.4.2.2.3.2 | ACERO DE REFUERZO GRADO 60 | 1d | 2019-05-01 | 2019-05-02 | 251 | 0d |  | start no earlier than 2018-06-11 | OPERARIO [55%]; PEON [55%]; ACERO CORRUGADO fy = 4200 kg/cm2 GRADO 60 [13744%]; HERRAMIENTAS MANUALES [6%] | 9.25h | 687.16 | 03.02.02.03.02 | 000000000000253 | 137.44 |  | 687.2 | 250 |
| 256 | 1.4.2.2.3.3 | ENCOFRADO Y DESENCOFRADO | 2d | 2019-05-02 | 2019-05-04 | 255 | 0d |  | start no earlier than 2018-06-11 | OPERARIO [98.9%]; OFICIAL [98.9%]; PEON [197.8%]; ALAMBRE NEGRO N° 8 [296.7%]; CLAVOS 2" - 4" [445.1%]; MADERA NACIONAL P/ENCOFRADO-CARP [6720.3%]; TRIPLAY DE 1.20X2.40 m X 18 mm [74.2%]; HERRAMIENTAS MANUALES [25%] | 67.3h | 1,508.35 | 03.02.02.03.03 | 000000000000254 | 29.67 | 50.85 | 1508.72 | 15 |
| 257 | 1.4.2.2.4 | **VARIOS** | 2d | 2019-05-03 | 2019-05-05 |  | 0d |  |  |  | 20.09h | 679.54 | 03.02.02.04 | 000000000000255 |  |  |  |  |
| 258 | 1.4.2.2.4.1 | TAPA METALICA 1.00 x 1.00 e=3/8" | 1d | 2019-05-04 | 2019-05-05 | 254FF | 53d |  | start no earlier than 2018-06-11 | OPERARIO; PEON; TAPA METALICA 1.00 X 1.00 m e=3/8"; HERRAMIENTAS MANUALES [13%] | 17.09h | 553.84 | 03.02.02.04.01 | 000000000000256 |  | 553.85 | 553.85 |  |
| 259 | 1.4.2.2.4.2 | CODOS DE PVC DE 6" | 1d | 2019-05-03 | 2019-05-04 | 256FF | 0d |  | start no earlier than 2018-06-11 | OPERARIO [5%]; PEON [2.5%]; CODO PVC DE 6"; HERRAMIENTAS MANUALES [1%] | 0.68h | 18.9 | 03.02.02.04.02 | 000000000000257 |  | 18.6 | 18.6 | 20 |
| 260 | 1.4.2.2.4.3 | TUBERIA PVC DE 6" | 1d | 2019-05-03 | 2019-05-04 | 259SS | 0d |  | start no earlier than 2018-06-11 | OPERARIO [7.6%]; PEON [7.6%]; TUBERIA PVC D=6" [340%]; HERRAMIENTAS MANUALES [1%] | 1.29h | 45.5 | 03.02.02.04.03 | 000000000000258 | 3.4 | 13.39 | 45.53 | 45 |
| 261 | 1.4.2.2.4.4 | TEE DE PVC DE 6" | 1d | 2019-05-03 | 2019-05-04 | 260SS | 0d |  | start no earlier than 2018-06-11 | OPERARIO [4%]; PEON [2%]; TEE PVC DE 6"; HERRAMIENTAS MANUALES [1%] | 0.52h | 13.74 | 03.02.02.04.04 | 000000000000259 |  | 13.7 | 13.7 | 25 |
| 262 | 1.4.2.2.4.5 | CODOS PVC DE 350 mm | 1d | 2019-05-03 | 2019-05-04 | 261SS | 0d |  | start no earlier than 2018-06-11 | OPERARIO [4%]; PEON [2%]; CODO PVC DE 350 mm; HERRAMIENTAS MANUALES [1%] | 0.51h | 47.56 | 03.02.02.04.05 | 000000000000260 |  | 47.6 | 47.6 | 25 |
| 263 | 1.5 | **CANAL LATERAL A** | 246d | 2018-09-23 | 2019-05-27 |  | 31d |  |  |  | 145690h | 644,742.23 | 04 | 000000000000261 |  |  |  |  |
| 264 | 1.5.1 | **CANAL DE CONDUCCION** | 56d | 2018-09-23 | 2018-11-18 |  | 190d |  |  |  | 140798h | 518,903.35 | 04.01 | 000000000000262 |  |  |  |  |
| 265 | 1.5.1.1 | **TRABAJOS PRELIMINARES** | 8d | 2018-09-23 | 2018-10-01 |  | 190d |  |  |  | 343.88h | 7,721.09 | 04.01.01 | 000000000000263 |  |  |  |  |
| 266 | 1.5.1.1.1 | TRAZO, NIVELACION Y REPLANTEO | 4d | 2018-09-23 | 2018-09-27 | 33 | 190d | 0d | start no earlier than 2018-06-11 | YESO BOLSA 28 kg [19300%]; ESTACION TOTAL [18%]; PEON [620%]; MADERA TORNILLO [7720%]; HERRAMIENTAS MANUALES [30%] | 215.86h | 5,790.29 | 04.01.01.01 | 000000000000264 | 3860 | 1.5 | 5790 | 500 |
| 267 | 1.5.1.1.2 | DESBROCE Y LIMPIEZA | 8d | 2018-09-24 | 2018-10-01 | 266SS | 190d | 0d | start no earlier than 2018-06-11 | PEON [193%]; HERRAMIENTAS MANUALES [10%] | 128.02h | 1,930.8 | 04.01.01.02 | 000000000000265 | 3860 | 0.5 | 1930 | 500 |
| 268 | 1.5.1.2 | **MOVIMIENTO DE TIERRAS** | 51d | 2018-09-28 | 2018-11-18 |  | 190d |  |  |  | 9142.21h | 251,424.15 | 04.01.02 | 000000000000266 |  |  |  |  |
| 269 | 1.5.1.2.1 | EXCAVACION EN MATERIAL SUELTO | 7d | 2018-10-01 | 2018-10-08 | 267 | 190d | 0d | start no earlier than 2018-06-11 | OFICIAL [8.9%]; PEON [87.9%]; EXCAVADORA SOBRE LLANTAS 1.20 M3 [87.9%]; HERRAMIENTAS MANUALES [3%] | 105.78h | 10,449.96 | 04.01.02.01 | 000000000000267 | 2764.51 | 3.78 | 10449.85 | 450 |
| 270 | 1.5.1.2.2 | EXCAVACION EN ROCA SUELTA | 4d | 2018-10-04 | 2018-10-08 | 269FF | 262d |  | start no earlier than 2018-06-11 | PEON [210%]; TRACTOR DE ORUGAS CAT D6D [97.6%]; HERRAMIENTAS MANUALES [10%]; PERFORACIÓN Y DISPARO EN ROCA SUELTA [124000%] | 102.74h | 19,244.59 | 04.01.02.02 | 000000000000268 | 1249.63 | 15.4 | 19244.3 | 320 |
| 271 | 1.5.1.2.3 | EXCAVACION EN ROCA FIJA | 10d | 2018-09-28 | 2018-10-08 | 269FF | 190d | 0d | start no earlier than 2018-06-11 | PEON; TRACTOR DE ORUGAS CAT D6D [99%]; HERRAMIENTAS MANUALES [15%]; PERFORACIÓN Y DISPARO EN ROCA FIJA [268300%] | 186.6h | 68,992.29 | 04.01.02.03 | 000000000000269 | 2681.42 | 25.73 | 68992.94 | 280 |
| 272 | 1.5.1.2.4 | RELLENO Y COMPACTADO DE MATERIAL PROPIO | 15d | 2018-09-28 | 2018-10-13 | 271FS-10d | 190d | 0d | start no earlier than 2018-06-11 | PEON [8%]; TRACTOR DE ORUGAS CAT D6D [7%]; HERRAMIENTAS MANUALES [2%] | 20.01h | 1,795.62 | 04.01.02.04 | 000000000000270 | 408.97 | 4.39 | 1795.38 | 400 |
| 273 | 1.5.1.2.5 | REFINE Y NIVELACION DE ZANJAS | 19d | 2018-09-28 | 2018-10-17 | 272FS-15d | 190d | 0d | start no earlier than 2018-06-11 | PEON [500%]; HERRAMIENTAS MANUALES [45%] | 827.4h | 12,197.6 | 04.01.02.05 | 000000000000271 | 3860 | 3.16 | 12197.6 | 40 |
| 274 | 1.5.1.2.6 | CAMA DE APOYO (MATERIAL ZARANDEADO) | 15d | 2018-10-03 | 2018-10-18 | 273SS+5d | 190d | 0d | start no earlier than 2018-06-11 | PEON [450%]; HERRAMIENTAS MANUALES [25%] | 571h | 8,538.94 | 04.01.02.06 | 000000000000272 | 270.2 | 31.6 | 8538.32 |  |
| 275 | 1.5.1.2.7 | RELLENO Y COMPACTADO DE MATERIAL SELECCIONADO | 45d | 2018-10-03 | 2018-11-17 | 274SS | 190d | 0d | start no earlier than 2018-06-11 | OPERARIO [57%]; PEON [555%]; COMPACTADORA VIBRATORIA TIPO PLANCHA 7 HP [555%]; HERRAMIENTAS MANUALES [70%] | 4446.2h | 67,472.04 | 04.01.02.07 | 000000000000273 | 1775.6 | 38 | 67472.8 |  |
| 276 | 1.5.1.2.8 | RELLENO DE MATERIAL PROPIO ZARANDEADO | 45d | 2018-10-04 | 2018-11-18 | 275SS+1d | 221d |  | start no earlier than 2018-06-11 | PEON [685%]; HERRAMIENTAS MANUALES [42%] | 2616.5h | 39,032.44 | 04.01.02.08 | 000000000000274 | 1235.2 | 31.6 | 39032.32 |  |
| 277 | 1.5.1.2.9 | ELIMINACION DE MATERIAL EXCEDENTE | 20d | 2018-10-13 | 2018-11-02 | 272 | 237d |  | start no earlier than 2018-06-11 | OFICIAL [60%]; CARGADOR FRONTAL 200-250 HP [35%]; CAMION VOLQUETE DE 15 m3 [70%] | 265.98h | 23,700.67 | 04.01.02.09 | 000000000000275 | 6286.58 | 3.77 | 23700.41 | 450 |

| ID | WBS | Task | Duration | Start | Finish | Predecessors | Total slack | Free slack | Constraint | Resources | Work | Cost | Text1 | Text8 | Text2 | Text3 | Text4 | Text6 |
| --- | --- | --- | --- | --- | --- | --- | --- | --- | --- | --- | --- | --- | --- | --- | --- | --- | --- | --- |
| 278 | 1.5.1.3 | **SUMINISTRO DE TUBERIA LINEA DE CONDUCCION** | 22d | 2018-10-18 | 2018-11-09 |  | 190d |  |  |  | 131311h | 259,758.11 | 04.01.03 | 000000000000276 |  |  |  |  |
| 279 | 1.5.1.3.1 | SUMIN. E INSTALACIÓN TUBERIA PERFILADA 315 mm | 8d | 2018-10-18 | 2018-10-26 | 275SS+15d | 190d | 0d |  | OPERARIO [93%]; PEON [94%]; HERRAMIENTAS MANUALES [6%]; TUBERIA PERFILADA PVC D=315 mm [156168%] | 100072h | 83,229.92 |  |  |  |  |  |  |
| 280 | 1.5.1.3.2 | SUMIN. E INSTALACION TUBERIA PVC NTP 1452 PN-5 DE Ø 200mm | 1d | 2018-10-26 | 2018-10-27 | 279 | 190d | 0d | start no earlier than 2018-06-11 | OPERARIO [46.4%]; PEON [46.4%]; TUBERIA Ø 200MM PVC-U NTP ISO 1452 UF PN-5 INC. ANILLO [12169.5%]; HERRAMIENTAS MANUALES [2%] | 7.77h | 3,232.36 | 04.01.03.02 | 000000000000278 | 115.9 | 27.89 | 3232.45 | 250 |
| 281 | 1.5.1.3.3 | SUMIN. E INSTALACION TUBERIA PVC NTP 1452 PN-5 DE Ø 250mm | 4d | 2018-10-27 | 2018-10-31 | 280 | 190d | 0d | start no earlier than 2018-06-11 | OPERARIO [76.8%]; PEON [76.8%]; TUBERIA Ø 250MM PVC-U NTP ISO 1452 UF PN-5 INC. ANILLO [70868.7%]; HERRAMIENTAS MANUALES [10%] | 52.79h | 29,461.31 | 04.01.03.03 | 000000000000279 | 674.94 | 43.65 | 29461.13 | 220 |
| 282 | 1.5.1.3.4 | SUMIN. E INSTALACION TUBERIA PVC NTP 1452 PN-7.5 DE Ø 250mm | 4d | 2018-10-31 | 2018-11-04 | 281 | 190d | 0d | start no earlier than 2018-06-11 | OPERARIO [95.6%]; PEON [95.6%]; TUBERIA Ø 250MM PVC-U NTP ISO 1452 UF PN-7.5 INC. ANILLO [88291.4%]; HERRAMIENTAS MANUALES [10%] | 66.02h | 51,318.44 | 04.01.03.04 | 000000000000280 | 840.87 | 61.03 | 51318.3 | 220 |
| 283 | 1.5.1.3.5 | SUMIN. E INSTALACION TUBERIA PVC NTP 1452 PN-10 DE Ø 315mm | 5d | 2018-11-05 | 2018-11-09 | 282 | 190d | 0d |  | OPERARIO [82%]; PEON [82%]; HERRAMIENTAS MANUALES [10%]; TUBERIA Ø 315MM PVC-U NTP ISO 1452 UF PN-10 INC. ANILLO [77609%] | 31113.2h | 92,516.07 |  |  |  |  |  |  |
| 284 | 1.5.2 | **OBRAS DE ARTE** | 23d | 2019-05-04 | 2019-05-27 |  | 0d |  |  |  | 4892.39h | 125,838.89 | 04.02 | 000000000000282 |  |  |  |  |
| 285 | 1.5.2.1 | **CAMARA ROMPEPRESION - TOMA LATERAL (10 UND)** | 23d | 2019-05-04 | 2019-05-27 |  | 0d |  |  |  | 2291.96h | 46,225.71 | 04.02.01 | 000000000000283 |  |  |  |  |
| 286 | 1.5.2.1.1 | **MOVIMIENTO DE TIERRAS** | 23d | 2019-05-04 | 2019-05-27 |  | 0d |  |  |  | 80.14h | 2,116.26 | 04.02.01.01 | 000000000000284 |  |  |  |  |
| 287 | 1.5.2.1.1.1 | EXCAVACION EN ROCA SUELTA | 1d | 2019-05-04 | 2019-05-05 | 262 | 0d |  | start no earlier than 2018-06-11 | PEON [30%]; TRACTOR DE ORUGAS CAT D6D [16%]; HERRAMIENTAS MANUALES [1%]; PERFORACIÓN Y DISPARO EN ROCA SUELTA [5000%] | 3.7h | 771.86 | 04.02.01.01.01 | 000000000000285 | 50.1 | 15.4 | 771.54 | 320 |
| 288 | 1.5.2.1.1.2 | ELIMINACION DE MATERIAL EXCEDENTE | 1d | 2019-05-06 | 2019-05-06 | 287 | 52d |  | start no earlier than 2018-06-11 | OFICIAL [12.3%]; CARGADOR FRONTAL 200-250 HP [6.1%]; CAMION VOLQUETE DE 15 m3 [12.3%] | 2.45h | 207.88 | 04.02.01.01.02 | 000000000000286 | 55.1 | 3.77 | 207.73 | 450 |
| 289 | 1.5.2.1.1.3 | RELLENO Y COMPACTADO DE MATERIAL SELECCIONADO | 5d | 2019-05-22 | 2019-05-27 | 293 | 31d |  | start no earlier than 2018-06-11 | OPERARIO [8.5%]; PEON [85.5%]; COMPACTADORA VIBRATORIA TIPO PLANCHA 7 HP [85.5%]; HERRAMIENTAS MANUALES [5%] | 73.99h | 1,136.52 | 04.02.01.01.03 | 000000000000287 | 29.91 | 38 | 1136.58 |  |
| 290 | 1.5.2.1.2 | **CONCRETO SIMPLE** | 1d | 2019-05-05 | 2019-05-06 |  | 0d |  |  |  | 24.71h | 809.14 | 04.02.01.02 | 000000000000288 |  |  |  |  |
| 291 | 1.5.2.1.2.1 | SOLADO DE CONCRETO FC=100 KG/CM2 | 1d | 2019-05-05 | 2019-05-06 | 287 | 0d |  | start no earlier than 2018-06-11 | CEMENTO PORTLAND TIPO IP (42.5 kg) [1173%]; OPERARIO [50%]; OFICIAL [50%]; PEON [150%]; VIBRADOR DE CONCRETO 4 HP 1.25" [24.4%]; MEZCLADORA DE CONCRETO 11 P3 (23 HP) [24.4%]; HERRAMIENTAS MANUALES [10%]; PIEDRA CHANCADA DE 1/2" Ó 3/4" (D cant.Prom=0.52 km) [280%]; ARENA GRUESA (D cant.prom = 0.52 km) [190%]; AGUA [90%] | 24.71h | 809.14 | 04.02.01.02.01 | 000000000000289 | 3.91 | 207.06 | 809.6 | 16 |
| 292 | 1.5.2.1.3 | **CONCRETO ARMADO** | 16d | 2019-05-06 | 2019-05-22 |  | 0d |  |  |  | 878.65h | 25,645.51 | 04.02.01.03 | 000000000000290 |  |  |  |  |
| 293 | 1.5.2.1.3.1 | CONCRETO FC=175 KG/CM2 | 3d | 2019-05-19 | 2019-05-22 | 296 | 31d | 0d | start no earlier than 2018-06-11 | CEMENTO PORTLAND TIPO IP (42.5 kg) [19098%]; ADITIVO IMPERMEABILIZANTE [424.4%]; OPERARIO [149.5%]; OFICIAL [288.6%]; PEON [741.5%]; VIBRADOR DE CONCRETO 4 HP 1.25" [70.7%]; MEZCLADORA DE CONCRETO 11 P3 (23 HP) [70.7%]; HERRAMIENTAS MANUALES [30%]; PIEDRA CHANCADA DE 1/2" Ó 3/4" (D cant.Prom=0.52 km) [1520%]; ARENA GRUESA (D cant.prom = 0.52 km) [990%]; AGUA [400%] | 326.72h | 10,111.14 | 04.02.01.03.01 | 000000000000291 | 21.22 | 476.51 | 10111.54 | 10 |
| 294 | 1.5.2.1.3.2 | CONCRETO FC=210 KG/CM2 | 1d | 2019-05-19 | 2019-05-20 | 293SS | 38d |  | start no earlier than 2018-06-11 | CEMENTO PORTLAND TIPO IP (42.5 kg) [792%]; ADITIVO IMPERMEABILIZANTE [14.4%]; OPERARIO [29.6%]; OFICIAL [29.4%]; PEON [75.5%]; VIBRADOR DE CONCRETO 4 HP 1.25" [14.4%]; MEZCLADORA DE CONCRETO 11 P3 (23 HP) [7.2%]; HERRAMIENTAS MANUALES [3%]; PIEDRA CHANCADA DE 1/2" Ó 3/4" (D cant.Prom=0.52 km) [51%]; ARENA GRUESA (D cant.prom = 0.52 km) [33%]; AGUA [14%] | 12.69h | 399.86 | 04.02.01.03.02 | 000000000000292 | 0.72 | 554.24 | 399.05 | 10 |
| 295 | 1.5.2.1.3.3 | ACERO DE REFUERZO GRADO 60 | 4d | 2019-05-06 | 2019-05-10 | 291 | 0d |  | start no earlier than 2018-06-11 | OPERARIO [94.8%]; PEON [94.8%]; ACERO CORRUGADO fy = 4200 kg/cm2 GRADO 60 [94752%]; HERRAMIENTAS MANUALES [10%] | 63.74h | 4,737.31 | 04.02.01.03.03 | 000000000000293 | 947.52 |  | 4737.6 | 250 |
| 296 | 1.5.2.1.3.4 | ENCOFRADO Y DESENCOFRADO | 12d | 2019-05-07 | 2019-05-19 | 295FS-3d | 0d |  | start no earlier than 2018-06-11 | OPERARIO [110%]; OFICIAL [110%]; PEON [225%]; ALAMBRE NEGRO N° 8 [2044.7%]; CLAVOS 2" - 4" [3067.1%]; MADERA NACIONAL P/ENCOFRADO-CARP [46312.4%]; TRIPLAY DE 1.20X2.40 m X 18 mm [511.2%]; HERRAMIENTAS MANUALES [50%] | 475.5h | 10,397.2 | 04.02.01.03.04 | 000000000000294 | 204.47 | 50.85 | 10397.3 | 15 |
| 297 | 1.5.2.1.4 | **VARIOS** | 6d | 2019-05-07 | 2019-05-13 |  | 0d |  |  |  | 1308.46h | 17,654.79 | 04.02.01.04 | 000000000000295 |  |  |  |  |
| 298 | 1.5.2.1.4.1 | TAPA METALICA 0.80 X 0.80 m e=1/4" | 3d | 2019-05-07 | 2019-05-10 | 296SS | 45d | 0d | start no earlier than 2018-06-11 | OPERARIO [170%]; PEON [172%]; TAPA METALICA 0.80 X 0.80 m e= 1/ 4" [1000%]; HERRAMIENTAS MANUALES [3%] | 323.08h | 4,009.85 | 04.02.01.04.01 | 000000000000296 | 10 | 400.9 | 4009 |  |
| 299 | 1.5.2.1.4.2 | TAPA METALICA 1.05 X 0.60 m e=1/4" | 3d | 2019-05-10 | 2019-05-13 | 298 | 45d |  | start no earlier than 2018-06-11 | OPERARIO [170%]; PEON [172%]; TAPA METALICA 1.05 X 0.60 m e= 1/ 4" [1000%]; HERRAMIENTAS MANUALES [3%] | 83.08h | 4,009.85 | 04.02.01.04.02 | 000000000000297 | 10 | 400.9 | 4009 |  |
| 300 | 1.5.2.1.4.3 | TUBERIA PVC 110 mm | 1d | 2019-05-07 | 2019-05-08 | 296SS | 0d |  | start no earlier than 2018-06-11 | OPERARIO [97.8%]; PEON [97.8%]; TUBERIA PVC C-10 110 mm [4400%]; HERRAMIENTAS MANUALES [10%] | 16.75h | 852.49 | 04.02.01.04.03 | 000000000000298 | 44 | 19.37 | 852.28 | 45 |
| 301 | 1.5.2.1.4.4 | CODOS PVC DE 110 mm | 1d | 2019-05-07 | 2019-05-08 | 300SS | 0d |  | start no earlier than 2018-06-11 | OPERARIO; PEON; CODO PVC DE 110 mm [2000%]; HERRAMIENTAS MANUALES [10%] | 177.15h | 689.88 | 04.02.01.04.04 | 000000000000299 | 20 | 34.48 | 689.6 | 20 |
| 302 | 1.5.2.1.4.5 | VALVULA DE BOLA 4" C/R | 4d | 2019-05-08 | 2019-05-12 | 301 | 0d |  | start no earlier than 2018-06-11 | OPERARIO; PEON; VALVULA ESFERICA DE 4" [2000%]; HERRAMIENTAS MANUALES [15%] | 708.4h | 8,092.72 | 04.02.01.04.05 | 000000000000300 | 20 | 404.62 | 8092.4 |  |

| ID | WBS | Task | Duration | Start | Finish | Predecessors | Total slack | Free slack | Constraint | Resources | Work | Cost | Text1 | Text8 | Text2 | Text3 | Text4 | Text6 |
| --- | --- | --- | --- | --- | --- | --- | --- | --- | --- | --- | --- | --- | --- | --- | --- | --- | --- | --- |
| 303 | 1.5.2.2 | **TOMAS LATERALES (04 UND)** | 15d | 2019-05-13 | 2019-05-27 |  | 0d |  |  |  | 2600.43h | 79,613.17 | 04.02.02 | 000000000000301 |  |  |  |  |
| 304 | 1.5.2.2.1 | **MOVIMIENTO DE TIERRAS** | 15d | 2019-05-13 | 2019-05-27 |  | 0d |  |  |  | 88.56h | 3,438 | 04.02.02.01 | 000000000000302 |  |  |  |  |
| 305 | 1.5.2.2.1.1 | EXCAVACION EN ROCA SUELTA | 1d | 2019-05-13 | 2019-05-13 | 302 | 0d |  | start no earlier than 2018-06-11 | PEON [80%]; TRACTOR DE ORUGAS CAT D6D [37.5%]; PERFORACIÓN Y DISPARO EN ROCA SUELTA [12000%]; HERRAMIENTAS MANUALES [1%] | 9.23h | 1,848.75 | 04.02.02.01.01 | 000000000000303 | 120 | 15.4 | 1848 | 320 |
| 306 | 1.5.2.2.1.2 | ELIMINACION DE MATERIAL EXCEDENTE | 1d | 2019-05-13 | 2019-05-14 | 305 | 0d |  | start no earlier than 2018-06-11 | OFICIAL [26.7%]; CARGADOR FRONTAL 200-250 HP [13.3%]; CAMION VOLQUETE DE 15 m3 [26.7%] | 5.34h | 452.73 | 04.02.02.01.02 | 000000000000304 | 120 | 3.77 | 452.4 | 450 |
| 307 | 1.5.2.2.1.3 | RELLENO Y COMPACTADO DE MATERIAL SELECCIONADO | 5d | 2019-05-22 | 2019-05-27 | 311 | 31d |  | start no earlier than 2018-06-11 | OPERARIO [8.5%]; PEON [85.5%]; COMPACTADORA VIBRATORIA TIPO PLANCHA 7 HP [85.5%]; HERRAMIENTAS MANUALES [7%] | 73.99h | 1,136.52 | 04.02.02.01.03 | 000000000000305 | 29.91 | 38 | 1136.58 |  |
| 308 | 1.5.2.2.2 | **CONCRETO SIMPLE** | 1d | 2019-05-14 | 2019-05-15 |  | 0d |  |  |  | 51.21h | 1,656.28 | 04.02.02.02 | 000000000000306 |  |  |  |  |
| 309 | 1.5.2.2.2.1 | SOLADO DE CONCRETO FC=100 KG/CM2 | 1d | 2019-05-14 | 2019-05-15 | 306 | 0d |  | start no earlier than 2018-06-11 | CEMENTO PORTLAND TIPO IP (42.5 kg) [2400%]; OPERARIO [109.1%]; OFICIAL [106.4%]; PEON [339.2%]; VIBRADOR DE CONCRETO 4 HP 1.25" [50%]; MEZCLADORA DE CONCRETO 11 P3 (23 HP) [50%]; HERRAMIENTAS MANUALES [2%]; PIEDRA CHANCADA DE 1/2" Ó 3/4" (D cant.Prom=0.52 km) [560%]; ARENA GRUESA (D cant.prom = 0.52 km) [360%]; AGUA [170%] | 51.21h | 1,656.28 | 04.02.02.02.01 | 000000000000307 |  | 207.06 | 1656.48 | 16 |
| 310 | 1.5.2.2.3 | **CONCRETO ARMADO** | 7d | 2019-05-15 | 2019-05-22 |  | 0d |  |  |  | 2341.17h | 69,330.17 | 04.02.02.03 | 000000000000308 |  |  |  |  |
| 311 | 1.5.2.2.3.1 | CONCRETO FC=175 KG/CM2 | 1d | 2019-05-21 | 2019-05-22 | 312 | 31d | 0d | start no earlier than 2018-06-11 | CEMENTO PORTLAND TIPO IP (42.5 kg) [52875%]; ADITIVO IMPERMEABILIZANTE [1175%]; OPERARIO [1000%]; OFICIAL [2500%]; PEON [6800%]; VIBRADOR DE CONCRETO 4 HP 1.25" [97.9%]; MEZCLADORA DE CONCRETO 11 P3 (23 HP) [97.9%]; HERRAMIENTAS MANUALES [470%]; PIEDRA CHANCADA DE 1/2" Ó 3/4" (D cant.Prom=0.52 km) [4400%]; ARENA GRUESA (D cant.prom = 0.52 km) [2900%]; AGUA [1600%] | 877.07h | 27,994.32 | 04.02.02.03.01 | 000000000000309 | 58.75 | 476.51 | 27994.96 | 10 |
| 312 | 1.5.2.2.3.2 | ENCOFRADO Y DESENCOFRADO | 4d | 2019-05-17 | 2019-05-21 | 313 | 0d |  | start no earlier than 2018-06-11 | OPERARIO [1000%]; OFICIAL [950%]; PEON [1950%]; ALAMBRE NEGRO N° 8 [5807.5%]; CLAVOS 2" - 4" [8711.2%]; MADERA NACIONAL P/ENCOFRADO-CARP [131540%]; TRIPLAY DE 1.20X2.40 m X 18 mm [1451.9%]; HERRAMIENTAS MANUALES [240%] | 1303.7h | 29,531.19 | 04.02.02.03.02 | 000000000000310 | 580.75 | 50.85 | 29531.14 | 15 |
| 313 | 1.5.2.2.3.3 | ACERO DE REFUERZO GRADO 60 | 2d | 2019-05-15 | 2019-05-17 | 309 | 0d |  | start no earlier than 2018-06-11 | OPERARIO [460%]; PEON [480%]; ACERO CORRUGADO fy = 4200 kg/cm2 GRADO 60 [236070%]; HERRAMIENTAS MANUALES [60%] | 160.4h | 11,804.66 | 04.02.02.03.03 | 000000000000311 | 2360.7 |  | 11803.5 | 250 |
| 314 | 1.5.2.2.4 | **VARIOS** | 5d | 2019-05-21 | 2019-05-26 |  | 0d |  |  |  | 119.5h | 5,188.73 | 04.02.02.04 | 000000000000312 |  |  |  |  |
| 315 | 1.5.2.2.4.1 | TAPA METALICA 0.65 X 0.65 m e=1/4" | 2d | 2019-05-22 | 2019-05-24 | 311 | 32d | 0d | start no earlier than 2018-06-11 | OPERARIO; PEON; TAPA METALICA 0.65 X 0.65 m e= 1/ 4" [400%]; HERRAMIENTAS MANUALES [15%] | 34.25h | 1,408.56 | 04.02.02.04.01 | 000000000000313 |  | 352 | 1408 |  |
| 316 | 1.5.2.2.4.2 | TAPA METALICA 0.60 X 0.60 m e=1/4" | 4d | 2019-05-22 | 2019-05-26 | 315SS | 32d |  | start no earlier than 2018-06-11 | OPERARIO; PEON; TAPA METALICA 0.60 X 0.60 m e= 1/4" [400%]; HERRAMIENTAS MANUALES [15%] | 68.3h | 2,045.36 | 04.02.02.04.02 | 000000000000314 |  | 511.47 | 2045.88 |  |
| 317 | 1.5.2.2.4.3 | VALVULA DE GLOBO 4" | 1d | 2019-05-21 | 2019-05-22 | 312 | 0d |  | start no earlier than 2018-06-11 | OPERARIO [80%]; PEON [80%]; VALVULA ESFERICA DE 4" [400%]; HERRAMIENTAS MANUALES [30%] | 14.7h | 1,618.56 | 04.02.02.04.03 | 000000000000315 |  | 404.62 | 1618.48 |  |
| 318 | 1.5.2.2.4.4 | TUBERIA PVC 110 mm | 1d | 2019-05-22 | 2019-05-23 | 317 | 0d |  | start no earlier than 2018-06-11 | OPERARIO [13.3%]; PEON [13.3%]; TUBERIA PVC C-10 110 mm [600%]; HERRAMIENTAS MANUALES [1%] | 2.25h | 116.25 | 04.02.02.04.04 | 000000000000316 |  | 19.37 | 116.22 | 45 |
| 319 | 1.6 | **CANAL LATERAL B** | 230d | 2018-11-09 | 2019-06-27 |  | 0d |  |  |  | 12206.2h | 487,976.63 | 05 | 000000000000317 |  |  |  |  |
| 320 | 1.6.1 | **CANAL DE CONDUCCION** | 40d | 2018-11-09 | 2018-12-19 |  | 190d |  |  |  | 10209.3h | 427,432.31 | 05.01 | 000000000000318 |  |  |  |  |
| 321 | 1.6.1.1 | **TRABAJOS PRELIMINARES** | 6d | 2018-11-09 | 2018-11-15 |  | 190d |  |  |  | 382.26h | 7,401.13 | 05.01.01 | 000000000000319 |  |  |  |  |
| 322 | 1.6.1.1.1 | TRAZO, NIVELACION Y REPLANTEO | 4d | 2018-11-09 | 2018-11-13 | 283 | 190d | 0d | start no earlier than 2018-06-11 | YESO BOLSA 28 kg [18500%]; ESTACION TOTAL [11.6%]; PEON [500%]; MADERA TORNILLO [7400%]; HERRAMIENTAS MANUALES [300%] | 259.54h | 5,550.31 | 05.01.01.01 | 000000000000320 | 3700 | 1.5 | 5550 | 500 |
| 323 | 1.6.1.1.2 | DESBROCE Y LIMPIEZA | 6d | 2018-11-09 | 2018-11-15 | 322SS | 190d | 0d | start no earlier than 2018-06-11 | PEON [243%]; HERRAMIENTAS MANUALES [9%] | 122.72h | 1,850.82 | 05.01.01.02 | 000000000000321 | 3700 | 0.5 | 1850 | 500 |
| 324 | 1.6.1.2 | **MOVIMIENTO DE TIERRAS** | 34d | 2018-11-15 | 2018-12-19 |  | 190d |  |  |  | 8713.05h | 251,434.85 | 05.01.02 | 000000000000322 |  |  |  |  |
| 325 | 1.6.1.2.1 | EXCAVACION EN MATERIAL SUELTO | 12d | 2018-11-15 | 2018-11-27 | 323 | 190d | 0d | start no earlier than 2018-06-11 | OFICIAL [10%]; PEON [115%]; EXCAVADORA SOBRE LLANTAS 1.20 M3 [115%]; HERRAMIENTAS MANUALES [20%] | 236.6h | 23,319.96 | 05.01.02.01 | 000000000000323 | 6169.27 | 3.78 | 23319.84 | 450 |
| 326 | 1.6.1.2.2 | EXCAVACION EN ROCA SUELTA | 8d | 2018-11-19 | 2018-11-27 | 325FF | 212d |  | start no earlier than 2018-06-11 | PEON [280%]; TRACTOR DE ORUGAS CAT D6D; HERRAMIENTAS MANUALES [3%]; PERFORACIÓN Y DISPARO EN ROCA SUELTA [268600%] | 244.7h | 41,375.47 | 05.01.02.02 | 000000000000324 | 2686.71 | 15.4 | 41375.33 | 320 |
| 327 | 1.6.1.2.3 | EXCAVACION EN ROCA FIJA | 5d | 2018-11-22 | 2018-11-27 | 325FF | 190d | 0d | start no earlier than 2018-06-11 | PEON [180%]; TRACTOR DE ORUGAS CAT D6D; HERRAMIENTAS MANUALES [10%]; PERFORACIÓN Y DISPARO EN ROCA FIJA [120700%] | 114.71h | 32,194.76 | 05.01.02.03 | 000000000000325 | 1251.26 | 25.73 | 32194.92 | 280 |
| 328 | 1.6.1.2.4 | RELLENO Y COMPACTADO DE MATERIAL PROPIO | 7d | 2018-11-22 | 2018-11-29 | 327SS | 190d | 0d | start no earlier than 2018-06-11 | PEON [11%]; TRACTOR DE ORUGAS CAT D6D [13%]; HERRAMIENTAS MANUALES [1%] | 14.44h | 1,583.17 | 05.01.02.04 | 000000000000326 | 360.67 | 4.39 | 1583.34 | 400 |
| 329 | 1.6.1.2.5 | REFINE Y NIVELACION DE ZANJAS | 15d | 2018-11-16 | 2018-12-01 | 328FS-13d | 191d | 0d | start no earlier than 2018-06-11 | PEON [617%]; HERRAMIENTAS MANUALES [35%] | 782.3h | 11,692.2 | 05.01.02.05 | 000000000000327 | 3700 | 3.16 | 11692 | 40 |
| 330 | 1.6.1.2.6 | CAMA DE APOYO (MATERIAL ZARANDEADO) | 12d | 2018-11-23 | 2018-12-05 | 329SS+7d | 191d | 0d | start no earlier than 2018-06-11 | PEON [500%]; HERRAMIENTAS MANUALES [30%] | 509.5h | 7,599.2 | 05.01.02.06 | 000000000000328 | 240.5 | 31.6 | 7599.8 |  |
| 331 | 1.6.1.2.7 | RELLENO Y COMPACTADO DE MATERIAL SELECCIONADO | 25d | 2018-11-23 | 2018-12-18 | 330SS | 191d | 0d | start no earlier than 2018-06-11 | OPERARIO [85%]; PEON [830%]; COMPACTADORA VIBRATORIA TIPO PLANCHA 7 HP [830%]; HERRAMIENTAS MANUALES [55%] | 3559.1h | 54,833.75 | 05.01.02.07 | 000000000000329 | 1443 | 38 | 54834 |  |
| 332 | 1.6.1.2.8 | RELLENO DE MATERIAL PROPIO ZARANDEADO | 25d | 2018-11-23 | 2018-12-18 | 331SS | 191d |  | start no earlier than 2018-06-11 | PEON [1333%]; HERRAMIENTAS MANUALES [95%] | 2815.5h | 42,092.44 | 05.01.02.08 | 000000000000330 | 1332 | 31.6 | 42091.2 |  |
| 333 | 1.6.1.2.9 | ELIMINACION DE MATERIAL EXCEDENTE | 20d | 2018-11-29 | 2018-12-19 | 328 | 190d |  | start no earlier than 2018-06-11 | OFICIAL [110%]; CARGADOR FRONTAL 200-250 HP [53%]; CAMION VOLQUETE DE 15 m3 [110%] | 436.2h | 36,743.89 | 05.01.02.09 | 000000000000331 | 9746.57 | 3.77 | 36744.57 | 450 |

| ID | WBS | Task | Duration | Start | Finish | Predecessors | Total slack | Free slack | Constraint | Resources | Work | Cost | Text1 | Text8 | Text2 | Text3 | Text4 | Text6 |
| --- | --- | --- | --- | --- | --- | --- | --- | --- | --- | --- | --- | --- | --- | --- | --- | --- | --- | --- |
| 334 | 1.6.1.3 | **SUMINISTRO DE TUBERIA LINEA DE CONDUCCION** | 19d | 2018-11-29 | 2018-12-18 |  | 191d |  |  |  | 1114h | 168,596.34 | 05.01.03 | 000000000000332 |  |  |  |  |
| 335 | 1.6.1.3.1 | SUMIN. E INSTALACION TUBERIA PERFILADA 250 mm | 8d | 2018-11-29 | 2018-12-07 | 331SS+6d | 191d | 0d | start no earlier than 2018-06-11 | OPERARIO [500%]; PEON [1000%]; TUBERIA PERFILADA PVC D=250 mm [224659%]; HERRAMIENTAS MANUALES | 995.5h | 89,460.25 | 05.01.03.01 | 000000000000333 | 2246.59 | 39.82 | 89459.21 | 40 |
| 336 | 1.6.1.3.2 | SUMIN. E INSTALACION TUBERIA PVC NTP 1452 PN-5 DE Ø 200mm | 1d | 2018-12-07 | 2018-12-08 | 335 | 191d | 0d | start no earlier than 2018-06-11 | OPERARIO [40.4%]; PEON [40.4%]; TUBERIA Ø 200MM PVC-U NTP ISO 1452 UF PN-5 INC. ANILLO [10593.5%]; HERRAMIENTAS MANUALES [2%] | 6.68h | 2,813.06 | 05.01.03.02 | 000000000000334 | 100.89 | 27.89 | 2813.82 | 250 |
| 337 | 1.6.1.3.3 | SUMIN. E INSTALACION TUBERIA PVC NTP 1452 PN-7.5 DE Ø 200mm | 1d | 2018-12-08 | 2018-12-09 | 336 | 191d | 0d | start no earlier than 2018-06-11 | OPERARIO [31.8%]; PEON [31.8%]; TUBERIA Ø 200MM PVC-U NTP ISO 1452 UF PN-7.5 INC. ANILLO [8343.3%]; HERRAMIENTAS MANUALES [2%] | 5.35h | 3,081.43 | 05.01.03.03 | 000000000000335 | 79.46 | 38.78 | 3081.46 | 250 |
| 338 | 1.6.1.3.4 | SUMIN. E INSTALACION TUBERIA PVC NTP 1452 PN-10 DE Ø 200mm | 1d | 2018-12-09 | 2018-12-10 | 337 | 191d | 0d | start no earlier than 2018-06-11 | OPERARIO [18.2%]; PEON [18.2%]; TUBERIA Ø 200MM PVC-U NTP ISO 1452 UF PN-10 INC. ANILLO [4768.1%]; HERRAMIENTAS MANUALES [2%] | 3.07h | 2,311.31 | 05.01.03.04 | 000000000000336 | 45.41 | 50.9 | 2311.37 | 250 |
| 339 | 1.6.1.3.5 | SUMIN. E INSTALACION TUBERIA PVC NTP 1452 PN-5 DE Ø 250mm | 4d | 2018-12-10 | 2018-12-14 | 338 | 191d | 0d | start no earlier than 2018-06-11 | OPERARIO [82.1%]; PEON [82.1%]; TUBERIA Ø 250MM PVC-U NTP ISO 1452 UF PN-5 INC. ANILLO [75748.1%]; HERRAMIENTAS MANUALES [10%] | 56.42h | 31,489.73 | 05.01.03.05 | 000000000000337 | 721.41 | 43.65 | 31489.55 | 220 |
| 340 | 1.6.1.3.6 | SUMIN. E INSTALACION TUBERIA PVC NTP 1452 PN-5 DE Ø 315mm | 2d | 2018-12-14 | 2018-12-16 | 339 | 191d | 0d | start no earlier than 2018-06-11 | OPERARIO [86.1%]; PEON [86.1%]; TUBERIA Ø 315MM PVC-U NTP ISO 1452 UF PN-5 INC. ANILLO [32584.7%]; HERRAMIENTAS MANUALES [2%] | 29.26h | 21,186.3 | 05.01.03.06 | 000000000000338 | 310.33 | 68.27 | 21186.23 | 180 |
| 341 | 1.6.1.3.7 | SUMIN. E INSTALACION TUBERIA PVC NTP 1452 PN-7.5 DE Ø 315mm | 2d | 2018-12-16 | 2018-12-18 | 340 | 191d |  | start no earlier than 2018-06-11 | OPERARIO [52.3%]; PEON [52.3%]; TUBERIA Ø 315MM PVC-U NTP ISO 1452 UF PN-7.5 INC. ANILLO [19790.4%]; HERRAMIENTAS MANUALES [3%] | 17.74h | 18,254.26 | 05.01.03.07 | 000000000000339 | 188.48 | 96.85 | 18254.29 | 180 |
| 342 | 1.6.2 | **OBRAS DE ARTE** | 35d | 2019-05-23 | 2019-06-27 |  | 0d |  |  |  | 1996.88h | 60,544.32 | 05.02 | 000000000000340 |  |  |  |  |
| 343 | 1.6.2.1 | **CAMARA ROMPEPRESION - TOMA LATERAL (06 UND)** | 17d | 2019-05-23 | 2019-06-09 |  | 0d |  |  |  | 746.89h | 27,731.94 | 05.02.01 | 000000000000341 |  |  |  |  |
| 344 | 1.6.2.1.1 | **MOVIMIENTO DE TIERRAS** | 17d | 2019-05-23 | 2019-06-09 |  | 0d |  |  |  | 48.21h | 1,270.82 | 05.02.01.01 | 000000000000342 |  |  |  |  |
| 345 | 1.6.2.1.1.1 | EXCAVACION EN ROCA SUELTA | 1d | 2019-05-23 | 2019-05-24 | 318 | 0d |  | start no earlier than 2018-06-11 | PEON [19%]; TRACTOR DE ORUGAS CAT D6D [9.4%]; HERRAMIENTAS MANUALES [1%]; PERFORACIÓN Y DISPARO EN ROCA SUELTA [3100%] | 2.31h | 463.79 | 05.02.01.01.01 | 000000000000343 | 30.06 | 15.4 | 462.92 | 320 |
| 346 | 1.6.2.1.1.2 | ELIMINACION DE MATERIAL EXCEDENTE | 1d | 2019-05-24 | 2019-05-25 | 345 | 0d |  | start no earlier than 2018-06-11 | OFICIAL [7.4%]; CARGADOR FRONTAL 200-250 HP [3.7%]; CAMION VOLQUETE DE 15 m3 [7.4%] | 1.47h | 124.72 | 05.02.01.01.02 | 000000000000344 | 33.06 | 3.77 | 124.64 | 450 |
| 347 | 1.6.2.1.1.3 | RELLENO Y COMPACTADO DE MATERIAL SELECCIONADO | 3d | 2019-06-06 | 2019-06-09 | 351 | 18d |  | start no earlier than 2018-06-11 | OPERARIO [8.5%]; PEON [85.5%]; COMPACTADORA VIBRATORIA TIPO PLANCHA 7 HP [85.5%]; HERRAMIENTAS MANUALES [4%] | 44.43h | 682.3 | 05.02.01.01.03 | 000000000000345 | 17.95 | 38 | 682.1 |  |
| 348 | 1.6.2.1.2 | **CONCRETO SIMPLE** | 1d | 2019-05-25 | 2019-05-26 |  | 0d |  |  |  | 14.85h | 486.74 | 05.02.01.02 | 000000000000346 |  |  |  |  |
| 349 | 1.6.2.1.2.1 | SOLADO DE CONCRETO FC=100 KG/CM2 | 1d | 2019-05-25 | 2019-05-26 | 346 | 0d |  | start no earlier than 2018-06-11 | CEMENTO PORTLAND TIPO IP (42.5 kg) [705%]; OPERARIO [32%]; OFICIAL [31.2%]; PEON [90%]; VIBRADOR DE CONCRETO 4 HP 1.25" [14.7%]; MEZCLADORA DE CONCRETO 11 P3 (23 HP) [14.7%]; PIEDRA CHANCADA DE 1/2" Ó 3/4" (D cant.Prom=0.52 km) [169%]; ARENA GRUESA (D cant.prom = 0.52 km) [110%]; AGUA [50%]; HERRAMIENTAS MANUALES [3%] | 14.85h | 486.74 | 05.02.01.02.01 | 000000000000347 | 2.35 | 207.06 | 486.59 | 16 |
| 350 | 1.6.2.1.3 | **CONCRETO ARMADO** | 11d | 2019-05-26 | 2019-06-06 |  | 0d |  |  |  | 520.03h | 15,383.56 | 05.02.01.03 | 000000000000348 |  |  |  |  |
| 351 | 1.6.2.1.3.1 | CONCRETO FC=175 KG/CM2 | 2d | 2019-06-04 | 2019-06-06 | 353 | 18d | 0d | start no earlier than 2018-06-11 | CEMENTO PORTLAND TIPO IP (42.5 kg) [11457%]; ADITIVO IMPERMEABILIZANTE [254.6%]; OPERARIO [134.5%]; OFICIAL [259.7%]; PEON [667.3%]; VIBRADOR DE CONCRETO 4 HP 1.25" [63.6%]; MEZCLADORA DE CONCRETO 11 P3 (23 HP) [63.6%]; PIEDRA CHANCADA DE 1/2" Ó 3/4" (D cant.Prom=0.52 km) [917%]; ARENA GRUESA (D cant.prom = 0.52 km) [590%]; AGUA [242%]; HERRAMIENTAS MANUALES [35%] | 195.8h | 6,064.14 | 05.02.01.03.01 | 000000000000349 | 12.73 | 476.51 | 6065.97 | 10 |
| 352 | 1.6.2.1.3.2 | CONCRETO FC=210 KG/CM2 | 1d | 2019-06-05 | 2019-06-06 | 351FF | 21d |  | start no earlier than 2018-06-11 | CEMENTO PORTLAND TIPO IP (42.5 kg) [473%]; ADITIVO IMPERMEABILIZANTE [8.6%]; OPERARIO [17.7%]; OFICIAL [17.5%]; PEON [45.1%]; VIBRADOR DE CONCRETO 4 HP 1.25" [8.6%]; MEZCLADORA DE CONCRETO 11 P3 (23 HP) [4.3%]; HERRAMIENTAS MANUALES [2%]; PIEDRA CHANCADA DE 1/2" Ó 3/4" (D cant.Prom=0.52 km) [31%]; ARENA GRUESA (D cant.prom = 0.52 km) [20%]; AGUA [8%] | 7.52h | 238.54 | 05.02.01.03.02 | 000000000000350 | 0.43 | 554.24 | 238.32 | 10 |
| 353 | 1.6.2.1.3.3 | ACERO DE REFUERZO GRADO 60 | 3d | 2019-06-01 | 2019-06-04 | 354FS-3d | 18d | 0d | start no earlier than 2018-06-11 | OPERARIO [75.8%]; PEON [75.8%]; ACERO CORRUGADO fy = 4200 kg/cm2 GRADO 60 [56851%]; HERRAMIENTAS MANUALES [8%] | 38.3h | 2,842.86 | 05.02.01.03.03 | 000000000000351 | 568.51 |  | 2842.55 | 250 |
| 354 | 1.6.2.1.3.4 | ENCOFRADO Y DESENCOFRADO | 9d | 2019-05-26 | 2019-06-04 | 349 | 0d |  | start no earlier than 2018-06-11 | OPERARIO [90.9%]; OFICIAL [90.9%]; PEON [181.8%]; ALAMBRE NEGRO N° 8 [1226.8%]; CLAVOS 2" - 4" [1840.2%]; MADERA NACIONAL P/ENCOFRADO-CARP [27787%]; TRIPLAY DE 1.20X2.40 m X 18 mm [306.7%]; HERRAMIENTAS MANUALES [30%] | 278.41h | 6,238.02 | 05.02.01.03.04 | 000000000000352 | 122.68 | 50.85 | 6238.28 | 15 |
| 355 | 1.6.2.1.4 | **VARIOS** | 4d | 2019-05-26 | 2019-05-30 |  | 0d |  |  |  | 163.79h | 10,590.81 | 05.02.01.04 | 000000000000353 |  |  |  |  |
| 356 | 1.6.2.1.4.1 | TAPA METALICA 0.80 X 0.80 m e=1/4" | 2d | 2019-05-26 | 2019-05-28 | 354SS | 28d | 0d | start no earlier than 2018-06-11 | OPERARIO [150%]; PEON [150%]; TAPA METALICA 0.80 X 0.80 m e= 1/ 4" [600%]; HERRAMIENTAS MANUALES [23%] | 51.3h | 2,405.64 | 05.02.01.04.01 | 000000000000354 |  | 400.9 | 2405.4 |  |
| 357 | 1.6.2.1.4.2 | TAPA METALICA 1.05 X 0.60 m e=1/4" | 2d | 2019-05-28 | 2019-05-30 | 356 | 28d |  | start no earlier than 2018-06-11 | OPERARIO [150%]; PEON [150%]; TAPA METALICA 1.05 X 0.60 m e= 1/ 4" [600%]; HERRAMIENTAS MANUALES [23%] | 51.3h | 2,405.64 | 05.02.01.04.02 | 000000000000355 |  | 400.9 | 2405.4 |  |
| 358 | 1.6.2.1.4.3 | TUBERIA PVC 110 mm | 1d | 2019-05-26 | 2019-05-27 | 354SS | 0d |  | start no earlier than 2018-06-11 | OPERARIO [58.7%]; PEON [58.7%]; TUBERIA PVC C-10 110 mm [2640%]; HERRAMIENTAS MANUALES [7%] | 9.99h | 511.01 | 05.02.01.04.03 | 000000000000356 | 26.4 | 19.37 | 511.37 | 45 |
| 359 | 1.6.2.1.4.4 | CODOS PVC DE 110 mm | 1d | 2019-05-26 | 2019-05-27 | 358SS | 0d |  | start no earlier than 2018-06-11 | OPERARIO [60%]; PEON [60%]; CODO PVC DE 110 mm [1200%]; HERRAMIENTAS MANUALES [7%] | 10.2h | 413.21 | 05.02.01.04.04 | 000000000000357 | 12 | 34.48 | 413.76 | 20 |
| 360 | 1.6.2.1.4.5 | VALVULA DE BOLA 4" C/R | 3d | 2019-05-26 | 2019-05-29 | 359SS | 0d |  | start no earlier than 2018-06-11 | OPERARIO [80%]; PEON [80%]; VALVULA ESFERICA DE 4" [1200%]; HERRAMIENTAS MANUALES [5%] | 41h | 4,855.31 | 05.02.01.04.05 | 000000000000358 | 12 | 404.62 | 4855.44 |  |

| ID | WBS | Task | Duration | Start | Finish | Predecessors | Total slack | Free slack | Constraint | Resources | Work | Cost | Text1 | Text8 | Text2 | Text3 | Text4 | Text6 |
| --- | --- | --- | --- | --- | --- | --- | --- | --- | --- | --- | --- | --- | --- | --- | --- | --- | --- | --- |
| 361 | 1.6.2.2 | **TOMAS LATERALES (10 UND)** | 29d | 2019-05-29 | 2019-06-27 |  | 0d |  |  |  | 1249.99h | 32,812.38 | 05.02.02 | 000000000000359 |  |  |  |  |
| 362 | 1.6.2.2.1 | **MOVIMIENTO DE TIERRAS** | 29d | 2019-05-29 | 2019-06-27 |  | 0d |  |  |  | 77.11h | 1,733.86 | 05.02.02.01 | 000000000000360 |  |  |  |  |
| 363 | 1.6.2.2.1.1 | EXCAVACION EN ROCA SUELTA | 1d | 2019-05-29 | 2019-05-30 | 360 | 0d |  | start no earlier than 2018-06-11 | PEON [20%]; TRACTOR DE ORUGAS CAT D6D [9.5%]; HERRAMIENTAS MANUALES [6%]; PERFORACIÓN Y DISPARO EN ROCA SUELTA [3000%] | 2.96h | 470.43 | 05.02.02.01.01 | 000000000000361 | 30.52 | 15.4 | 470.01 | 320 |
| 364 | 1.6.2.2.1.2 | ELIMINACION DE MATERIAL EXCEDENTE | 1d | 2019-05-30 | 2019-05-31 | 363 | 0d |  | start no earlier than 2018-06-11 | OFICIAL [7.5%]; CARGADOR FRONTAL 200-250 HP [3.7%]; CAMION VOLQUETE DE 15 m3 [7.5%] | 1.49h | 126.65 | 05.02.02.01.02 | 000000000000362 | 33.57 | 3.77 | 126.56 | 450 |
| 365 | 1.6.2.2.1.3 | RELLENO Y COMPACTADO DE MATERIAL SELECCIONADO | 12d | 2019-06-15 | 2019-06-27 | 369 | 0d |  | start no earlier than 2018-06-11 | OPERARIO [8.5%]; PEON [85.5%]; COMPACTADORA VIBRATORIA TIPO PLANCHA 7 HP [85.5%]; HERRAMIENTAS MANUALES [4%] | 72.65h | 1,136.78 | 05.02.02.01.03 | 000000000000363 | 29.91 | 38 | 1136.58 |  |
| 366 | 1.6.2.2.2 | **CONCRETO SIMPLE** | 1d | 2019-05-31 | 2019-06-01 |  | 0d |  |  |  | 15.38h | 505.88 | 05.02.02.02 | 000000000000364 |  |  |  |  |
| 367 | 1.6.2.2.2.1 | SOLADO DE CONCRETO FC=100 KG/CM2 | 1d | 2019-05-31 | 2019-06-01 | 364 | 0d |  | start no earlier than 2018-06-11 | CEMENTO PORTLAND TIPO IP (42.5 kg) [732%]; OPERARIO [31%]; OFICIAL [32.4%]; PEON [98%]; VIBRADOR DE CONCRETO 4 HP 1.25" [15.2%]; MEZCLADORA DE CONCRETO 11 P3 (23 HP) [15.2%]; HERRAMIENTAS MANUALES [1%]; PIEDRA CHANCADA DE 1/2" Ó 3/4" (D cant.Prom=0.52 km) [175%]; ARENA GRUESA (D cant.prom = 0.52 km) [114%]; AGUA [56%] | 15.38h | 505.88 | 05.02.02.02.01 | 000000000000365 | 2.44 | 207.06 | 505.23 | 16 |
| 368 | 1.6.2.2.3 | **CONCRETO ARMADO** | 14d | 2019-06-01 | 2019-06-15 |  | 0d |  |  |  | 621.95h | 17,600.06 | 05.02.02.03 | 000000000000366 |  |  |  |  |
| 369 | 1.6.2.2.3.1 | CONCRETO FC=175 KG/CM2 | 2d | 2019-06-13 | 2019-06-15 | 370 | 0d |  | start no earlier than 2018-06-11 | CEMENTO PORTLAND TIPO IP (42.5 kg) [13356%]; ADITIVO IMPERMEABILIZANTE [296.8%]; OPERARIO [156.8%]; OFICIAL [305%]; PEON [779%]; VIBRADOR DE CONCRETO 4 HP 1.25" [74.2%]; MEZCLADORA DE CONCRETO 11 P3 (23 HP) [74.2%]; HERRAMIENTAS MANUALES [30%]; PIEDRA CHANCADA DE 1/2" Ó 3/4" (D cant.Prom=0.52 km) [1068%]; ARENA GRUESA (D cant.prom = 0.52 km) [690%]; AGUA [280%] | 227.77h | 7,070.4 | 05.02.02.03.01 | 000000000000367 | 14.84 | 476.51 | 7071.41 | 10 |
| 370 | 1.6.2.2.3.2 | ENCOFRADO Y DESENCOFRADO | 9d | 2019-06-04 | 2019-06-13 | 371 | 0d |  | start no earlier than 2018-06-11 | OPERARIO [125%]; OFICIAL [126%]; PEON [188%]; ALAMBRE NEGRO N° 8 [1551%]; CLAVOS 2" - 4" [2326.5%]; MADERA NACIONAL P/ENCOFRADO-CARP [35130.1%]; TRIPLAY DE 1.20X2.40 m X 18 mm [387.8%]; HERRAMIENTAS MANUALES [59%] | 358.59h | 7,886.06 | 05.02.02.03.02 | 000000000000368 | 155.1 | 50.85 | 7886.84 | 15 |
| 371 | 1.6.2.2.3.3 | ACERO DE REFUERZO GRADO 60 | 3d | 2019-06-01 | 2019-06-04 | 367 | 0d |  | start no earlier than 2018-06-11 | OPERARIO [70.5%]; PEON [70.5%]; ACERO CORRUGADO fy = 4200 kg/cm2 GRADO 60 [52872%]; HERRAMIENTAS MANUALES [30%] | 35.59h | 2,643.6 | 05.02.02.03.03 | 000000000000369 | 528.72 |  | 2643.6 | 250 |
| 372 | 1.6.2.2.4 | **VARIOS** | 3d | 2019-06-04 | 2019-06-07 |  | 20d |  |  |  | 535.55h | 12,972.58 | 05.02.02.04 | 000000000000370 |  |  |  |  |
| 373 | 1.6.2.2.4.1 | TAPA METALICA 0.65 X 0.65 m e=1/4" | 3d | 2019-06-04 | 2019-06-07 | 370SS | 20d | 0d | start no earlier than 2018-06-11 | OPERARIO [150%]; PEON [200%]; TAPA METALICA 0.65 X 0.65 m e= 1/ 4" [1000%]; HERRAMIENTAS MANUALES [3%] | 324.72h | 3,520.8 | 05.02.02.04.01 | 000000000000371 | 10 | 352 | 3520 |  |
| 374 | 1.6.2.2.4.2 | TAPA METALICA 0.60 X 0.60 m e=1/4" | 2d | 2019-06-04 | 2019-06-06 | 373SS | 21d |  | start no earlier than 2018-06-11 | OPERARIO [500%]; PEON [500%]; TAPA METALICA 0.60 X 0.60 m e= 1/4" [1000%]; HERRAMIENTAS MANUALES [70%] | 170.9h | 5,114.6 | 05.02.02.04.02 | 000000000000372 | 10 | 511.47 | 5114.7 |  |
| 375 | 1.6.2.2.4.3 | VALVULA DE GLOBO 4" | 2d | 2019-06-04 | 2019-06-06 | 370SS | 20d | 0d | start no earlier than 2018-06-11 | OPERARIO; PEON; VALVULA ESFERICA DE 4" [1000%]; HERRAMIENTAS MANUALES [29%] | 34.2h | 4,046.36 | 05.02.02.04.03 | 000000000000373 | 10 | 404.62 | 4046.2 |  |
| 376 | 1.6.2.2.4.4 | TUBERIA PVC 110 mm | 1d | 2019-06-06 | 2019-06-07 | 375 | 20d |  | start no earlier than 2018-06-11 | OPERARIO [33.3%]; PEON [33.3%]; TUBERIA PVC C-10 110 mm [1500%]; HERRAMIENTAS MANUALES [5%] | 5.73h | 290.82 | 05.02.02.04.04 | 000000000000374 | 15 | 19.37 | 290.55 | 45 |
| 377 | 1.7 | **ELABORACION, IMPLEMENTACION Y ADMINISTRACION DEL PLAN DE SEGURIDAD Y SALUD EN EL TRABAJO** | 144.5d | 2018-07-01 | 2018-11-22 |  |  |  |  |  | 18144.3h | 82,870.7 | 06 | 000000000000375 |  |  |  |  |
| 378 | 1.7.1 | EQUIPOS DE PROTECCION PERSONAL | 358d | 2018-07-02 | 2019-06-24 | 5SS | 2d | 0d | start no earlier than 2018-06-11 | GUANTES DE CUERO [20000%]; GUANTES DE JEBE [20000%]; BOTAS DE JEBE [20000%]; CASCOS [20000%]; LENTES DE SEGURIDAD [20000%]; TAPON PARA OIDOS [25000%]; MASCARILLA PARA POLVO [15000%]; CHALECO DE SEGURIDAD [20000%]; ZAPATOS DE SEGURIDAD [20000%]; OVEROL [20000%] | 15992.8h | 70,894.98 | 06.01 | 000000000000376 |  | 70894 | 70894 |  |
| 379 | 1.7.2 | EQUIPOS DE PROTECCION COLECTIVA | 358d | 2018-07-02 | 2019-06-24 | 378SS | 2d |  | start no earlier than 2018-06-11 | CONOS REFLECTANTES [10000%]; CINTA DE SEGURIDAD [5000%]; MALLA DE SEGURIDAD [5000%] | 1599.5h | 5,169.88 | 06.02 | 000000000000377 |  | 5169 | 5169 |  |
| 380 | 1.7.3 | SEÑALIZACION TEMPORAL DE SERVICIOS | 358d | 2018-07-02 | 2019-06-24 | 378SS | 2d |  | start no earlier than 2018-06-11 | SEÑALIZACION INFORMATIVA 1.00 X 2.20 m [5000%] | 400h | 212 | 06.03 | 000000000000378 |  | 212 | 212 |  |
| 381 | 1.7.4 | CAPACITACION EN SEGURIDAD Y SALUD | 358d | 2018-07-02 | 2019-06-24 | 378SS | 2d |  | start no earlier than 2018-06-11 | CAPACITACION EN SEGURIDAD Y SALUD [1500%] | 120h | 6,356.4 | 06.04 | 000000000000379 |  | 6355.95 | 6355.95 |  |
| 382 | 1.7.5 | RECURSO DE RESPUESTA ANTE EMERGENCIA EN SEGURIDAD Y SALUD DURANTE EL TRABAJO | 90d | 2018-07-02 | 2018-09-29 | 378SS | 270d |  | start no earlier than 2018-06-11 | BOTIQUIN PARA LA OBRA [400%] | 32h | 237.44 | 06.05 | 000000000000380 |  | 237.28 | 237.28 |  |
| 383 | 1.8 | **MITIGACION DE IMPACTO AMBIENTAL** | 347d | 2018-07-02 | 2019-06-13 |  | 14d |  |  |  | 131h | 94,915.55 | 07 | 000000000000381 |  |  |  |  |
| 384 | 1.8.1 | **PLAN DE MITIGACION Y/O PREVENSION** | 90d | 2018-07-02 | 2018-09-29 |  | 271d |  |  |  | 24h | 37,288.16 | 07.01 | 000000000000382 |  |  |  |  |
| 385 | 1.8.1.1 | PROGRAMA DE PREVENCION, CONTROL Y MITIGACION AMBIENTAL | 90d | 2018-07-02 | 2018-09-29 | 5SS | 270d | 0d | start no earlier than 2018-06-11 | PROGRAMA DE PREVENCION CONTROL Y MITIGACIONAMBIENTAL | 8h | 18,220.32 | 07.01.01 | 000000000000383 |  | 18220.34 | 18220.34 |  |
| 386 | 1.8.1.2 | PROGRAMA DE MANEJO DE RESIDUOS SOLIDOS Y EFLUENTES | 90d | 2018-07-02 | 2018-09-29 | 385SS | 270d |  | start no earlier than 2018-06-11 | PROGRAMA DE MANEJO DE RESIDUOS SOLIDOS Y EFLUENTES | 8h | 12,288.16 | 07.01.02 | 000000000000384 |  | 12288.14 | 12288.14 |  |
| 387 | 1.8.1.3 | PROGRAMA DE MEDIDA DE CONTINGENCIAS | 90d | 2018-07-02 | 2018-09-29 | 385SS | 270d |  | start no earlier than 2018-06-11 | PROGRAMA DE MEDIDA DE CONTINGENCIAS | 8h | 6,779.68 | 07.01.03 | 000000000000385 |  | 6779.66 | 6779.66 |  |

| ID | WBS | Task | Type | Duration | Start | Finish | Predecessors | Total slack | Constraint | Resources | Work | Cost | Text1 | Text8 | Text3 | Text4 |
| --- | --- | --- | --- | --- | --- | --- | --- | --- | --- | --- | --- | --- | --- | --- | --- | --- |
| 388 | 1.8.2 | **PLAN DE SEGUIMIENTO Y CONTROL** |  | 90d | 2018-07-02 | 2018-09-29 |  | 271d |  |  | 8h | 8,474.56 | 07.02 | 000000000000386 |  |  |
| 389 | 1.8.2.1 | PLAN DE SEGUIMIENTO Y CONTROL |  | 90d | 2018-07-02 | 2018-09-29 | 385SS | 270d | start no earlier than 2018-06-11 | PLAN DE CIERRE | 8h | 8,474.56 | 07.02.01 | 000000000000387 | 8474.58 | 8474.58 |
| 390 | 1.8.3 | **PLAN DE MONITOREO AMBIENTAL** |  | 90d | 2018-07-02 | 2018-09-29 |  | 271d |  |  | 72h | 10,169.76 | 07.03 | 000000000000388 |  |  |
| 391 | 1.8.3.1 | CALIDAD DE AIRE (PM10 Y PM 2.5) |  | 90d | 2018-07-02 | 2018-09-29 | 385SS | 270d | start no earlier than 2018-06-11 | CALIDAD DEL AGUA SUPERFICIAL [300%] | 24h | 4,576.32 | 07.03.01 | 000000000000389 | 1525.42 | 4576.26 |
| 392 | 1.8.3.2 | CALIDAD DE AGUA |  | 90d | 2018-07-02 | 2018-09-29 | 385SS | 270d | start no earlier than 2018-06-11 | CALIDAD DE AGUA [300%] | 24h | 3,559.44 | 07.03.02 | 000000000000390 | 1186.44 | 3559.32 |
| 393 | 1.8.3.3 | MONITOREO DE RUIDOS |  | 90d | 2018-07-02 | 2018-09-29 | 385SS | 270d | start no earlier than 2018-06-11 | MONITOREO DE RUIDOS [300%] | 24h | 2,034 | 07.03.03 | 000000000000391 | 677.97 | 2033.91 |
| 394 | 1.8.4 | **PLAN DE CIERRE** |  | 20d | 2019-05-24 | 2019-06-13 |  | 14d |  |  | 16h | 22,033.92 | 07.04 | 000000000000392 |  |  |
| 395 | 1.8.4.1 | REACONDICIONAMIENTO DE CANTERAS, BOTADERO Y CAMPAMENTO |  | 20d | 2019-05-24 | 2019-06-13 | 345 | 14d | start no earlier than 2018-06-11 | REACONDICIONAMIENTO DE CANTERAS BOTADERO Y CAMPAMENTO | 8h | 11,864.4 | 07.04.01 | 000000000000393 | 11864.41 | 11864.41 |
| 396 | 1.8.4.2 | REVEGETACION DE AREA UTILIZADA COMO BOTADERO |  | 20d | 2019-05-24 | 2019-06-13 | 345 | 14d | start no earlier than 2018-06-11 | REVEGETACIÓN DE ÁREA UTILIZADA COMO BOTADERO | 8h | 10,169.52 | 07.04.02 | 000000000000394 | 10169.49 | 10169.49 |
| 397 | 1.8.5 | **PLAN DE MONITOREO ARQUEOLOGICO** |  | 5d | 2018-07-02 | 2018-07-06 |  | 356d |  |  | 11h | 16,949.15 | 07.05 | 000000000000395 |  |  |
| 398 | 1.8.5.1 | ARQUEOLOGO |  | 5d | 2018-07-02 | 2018-07-06 | 5SS | 355d | start no earlier than 2018-06-11 | ARQUEOLOGO [7%] | 3h | 12,711.87 | 07.05.01 | 000000000000396 | 12711.87 | 12711.87 |
| 399 | 1.8.5.2 | PLAN DE MONITOREO ARQUEOLOGICO |  | 5d | 2018-07-02 | 2018-07-06 | 5SS | 355d | start no earlier than 2018-06-11 | PLAN DE MONITOREO ARQUEOLOGICO | 8h | 4,237.28 | 07.05.02 | 000000000000397 | 4237.29 | 4237.29 |
| 400 | 1.9 | FIN DE OBRA | milestone | 0d | 2018-07-02 | 2018-07-02 |  | 360d |  |  |  |  |  |  |  |  |
